# SPIRE STM-CQM AIV Draft 7

Schedule from MS Project, 2003-03-26 to 2005-03-01, status date 2002-09-10, A marks actual dates.
CCLRC

## Calendars

- Standard: Mon-Fri 08:00-12:00, 13:00-17:00; Sat-Sun off. Exceptions (off unless hours are given): 2003-04-18 to 2003-04-21, 2003-05-05, 2003-05-26, 2003-12-22 to 2004-01-02.

## Resources

| Resource |
| --- |
| Technician |
| Electronics Engineer |
| AS Scientific |
| Mike Trower |
| Cardiff University |
| Dave Smith |
| Martin Caldwell |
| Bruce Swinyard |
| Andy Matheson |
| Mark Ferlet |
| Sam Heys |
| Doug Griffin |
| Ken King |

## Schedule

| ID | WBS | Task | Type | Duration | Start | Finish | Predecessors | Complete | Remaining | Baseline start | Baseline finish | Baseline duration | Total slack | Free slack | Constraint |
| --- | --- | --- | --- | --- | --- | --- | --- | --- | --- | --- | --- | --- | --- | --- | --- |
| 1 | 1 | **SM AIV programme** |  | 25d | 2003-03-26 A | 2003-05-01 |  | 68% | 7.97d | 2003-02-12 | 2003-11-27 | 205.5d | 466d |  |  |
| 2 | 1.1 | **SM FPU Subsystem deliveries** |  | 3d | 2003-04-25 A | 2003-04-30 |  | 49% | 1.53d | 2002-10-18 | 2003-02-03 | 70d | 467d |  |  |
| 3 | 1.1.1 | CQM Mirrors and OGSE Delivery | milestone | 0d | 2003-04-25 A | 2003-04-25 A |  | 100% |  | 2002-10-18 | 2002-10-18 | 0d |  |  | start no earlier than 2003-04-25 |
| 4 | 1.1.2 | CQM Mirrors Acceptance |  | 3d | 2003-04-28 A | 2003-04-30 A | 3 | 100% |  | 2002-10-18 | 2002-10-22 | 3d |  |  | start no earlier than 2003-04-25 |
| 5 | 1.1.3 | STM Filters, Dichroics, Beamsplitters and OGSE Delivery | milestone | 0d | 2003-04-25 A | 2003-04-25 A |  | 100% |  | 2002-10-18 | 2002-10-18 | 0d |  |  | start no earlier than 2003-04-25 |
| 6 | 1.1.4 | STM Filters, Dichroics, Beamsplitters Acceptance |  | 3d | 2003-04-28 A | 2003-04-30 A | 5 | 100% |  | 2002-10-18 | 2002-10-22 | 3d |  |  | start no earlier than 2003-04-25 |
| 7 | 1.1.5 | STM BSMm Delivery | milestone | 0d | 2003-04-25 A | 2003-04-25 A |  | 100% |  | 2002-10-18 | 2002-10-18 | 0d |  |  | start no earlier than 2003-04-25 |
| 8 | 1.1.6 | STM BSMm Acceptance |  | 3d | 2003-04-28 A | 2003-04-30 A | 7 | 100% |  | 2002-10-18 | 2002-10-22 | 3d |  |  | start no earlier than 2003-04-25 |
| 9 | 1.1.7 | CQM BSM Harness Delivery | milestone | 0d | 2003-04-25 | 2003-04-25 |  |  |  | 2002-10-18 | 2002-10-18 | 0d | 126d | 0d | start no earlier than 2003-04-25 |
| 10 | 1.1.8 | CQM BSM Harness Acceptance |  | 3d | 2003-04-28 | 2003-04-30 | 9 |  |  | 2002-10-18 | 2002-10-22 | 3d | 126d | 52d | start no earlier than 2003-04-25 |
| 11 | 1.1.9 | Optical Dummy SMECm Delivery | milestone | 0d | 2003-04-25 A | 2003-04-25 A |  | 100% |  | 2002-10-30 | 2002-10-30 | 0d |  |  | start no earlier than 2003-04-25 |
| 12 | 1.1.10 | Optical Dummy SMECm Acceptance |  | 3d | 2003-04-28 A | 2003-04-30 A | 11 | 100% |  | 2002-10-30 | 2002-10-30 | 1d |  |  | start no earlier than 2003-04-25 |
| 13 | 1.1.11 | CQM Thermal Straps Delivery | milestone | 0d | 2003-04-25 | 2003-04-25 |  |  |  | 2002-11-15 | 2002-11-15 | 0d | 467d | 0d | start no earlier than 2003-04-25 |
| 14 | 1.1.12 | CQM Thermal Straps Acceptance |  | 3d | 2003-04-28 | 2003-04-30 | 13 |  |  | 2002-11-15 | 2002-11-19 | 3d | 467d |  | start no earlier than 2003-04-25 |
| 15 | 1.1.13 | STM Cooler Delivery | milestone | 0d | 2003-04-25 A | 2003-04-25 A |  | 100% |  | 2002-12-16 | 2002-12-18 | 3d |  |  | start no earlier than 2003-04-25 |
| 16 | 1.1.14 | STM Cooler Acceptance |  | 3d | 2003-04-28 A | 2003-04-30 A | 15 | 100% |  | 2002-12-19 | 2002-12-19 | 3d |  |  | start no earlier than 2003-04-25 |
| 17 | 1.1.15 | CQM Cooler Harness Delivery | milestone | 0d | 2003-04-25 | 2003-04-25 |  |  |  | 2002-12-16 | 2002-12-16 | 0d | 126d | 0d | start no earlier than 2003-04-25 |
| 18 | 1.1.16 | CQM Cooler Harness Acceptance |  | 3d | 2003-04-28 | 2003-04-30 | 17 |  |  | 2002-12-16 | 2002-12-18 | 3d | 126d | 52d | start no earlier than 2003-04-25 |
| 19 | 1.1.17 | STM BDAs Delivery | milestone | 0d | 2003-04-25 A | 2003-04-25 A |  | 100% |  | 2002-12-18 | 2002-12-18 | 0d |  |  | start no earlier than 2003-04-25 |
| 20 | 1.1.18 | STM BDAs Acceptance |  | 1d | 2003-04-28 A | 2003-04-28 A | 19 | 100% |  | 2002-12-18 | 2002-12-18 | 1d |  |  | start no earlier than 2003-04-25 |
| 21 | 1.1.19 | CQM BDAs Harness Delivery | milestone | 0d | 2003-04-25 | 2003-04-25 |  |  |  | 2002-12-16 | 2002-12-16 | 0d | 126d | 0d | start no earlier than 2003-04-25 |
| 22 | 1.1.20 | CQM BDAs Harness Acceptance |  | 3d | 2003-04-28 | 2003-04-30 | 21 |  |  | 2002-12-16 | 2002-12-18 | 3d | 126d | 52d | start no earlier than 2003-04-25 |
| 23 | 1.1.21 | STM SCAL Delivery | milestone | 0d | 2003-04-25 A | 2003-04-25 A |  | 100% |  | 2002-12-18 | 2002-12-18 | 0d |  |  | start no earlier than 2003-04-25 |
| 24 | 1.1.22 | STM SCAL Acceptance |  | 1d | 2003-04-28 A | 2003-04-28 A | 23 | 100% |  | 2002-12-18 | 2002-12-18 | 1d |  |  | start no earlier than 2003-04-25 |
| 25 | 1.1.23 | STM SCAL Harness Delivery | milestone | 0d | 2003-04-25 | 2003-04-25 |  |  |  | 2002-12-16 | 2002-12-16 | 0d | 126d | 0d | start no earlier than 2003-04-25 |
| 26 | 1.1.24 | STM SCAL Harness Acceptance |  | 3d | 2003-04-28 | 2003-04-30 | 25 |  |  | 2002-12-16 | 2002-12-18 | 3d | 126d | 52d | start no earlier than 2003-04-25 |
| 27 | 1.1.25 | STM SMECm Delivery | milestone | 0d | 2003-04-25 A | 2003-04-25 A |  | 100% |  | 2002-12-18 | 2002-12-18 | 0d |  |  | start no earlier than 2003-04-25 |
| 28 | 1.1.26 | STM SMECm Acceptance |  | 1d | 2003-04-28 A | 2003-04-28 A | 27 | 100% |  | 2002-12-18 | 2002-12-18 | 1d |  |  | start no earlier than 2003-04-25 |
| 29 | 1.1.27 | STM SMECm Harness Delivery | milestone | 0d | 2003-04-25 | 2003-04-25 |  |  |  | 2002-12-16 | 2002-12-16 | 0d | 126d | 0d | start no earlier than 2003-04-25 |
| 30 | 1.1.28 | STM SMECm Harness Acceptance |  | 3d | 2003-04-28 | 2003-04-30 | 29 |  |  | 2002-12-16 | 2002-12-18 | 3d | 126d | 52d | start no earlier than 2003-04-25 |
| 31 | 1.1.29 | CQM FPU RF Filter Modules Delivery | milestone | 0d | 2003-04-25 | 2003-04-25 |  |  |  | 2002-12-18 | 2002-12-18 | 0d | 128d | 0d | start no earlier than 2003-04-25 |
| 32 | 1.1.30 | CQM FPU RF Filter Modules Acceptance |  | 1d | 2003-04-28 | 2003-04-28 | 31 |  |  | 2002-12-18 | 2002-12-18 | 1d | 128d | 54d | start no earlier than 2003-04-25 |
| 33 | 1.1.31 | STM/CQM 300mK strap delivery | milestone | 0d | 2003-04-25 A | 2003-04-25 A |  | 100% |  | 2003-01-06 | 2003-01-06 | 0d |  |  | start no earlier than 2003-04-25 |
| 34 | 1.1.32 | STM/CQM 300mK strap acceptance |  | 3d | 2003-04-28 A | 2003-04-30 A | 33 | 100% |  | 2003-01-06 | 2003-01-08 | 3d |  |  | start no earlier than 2003-04-25 |
| 35 | 1.1.33 | CQM Cooler Delivery | milestone | 0d | 2003-04-25 | 2003-04-25 |  |  |  | 2003-01-30 | 2003-01-30 | 0d | 467d | 0d | start no earlier than 2003-04-25 |
| 36 | 1.1.34 | CQM Cooler Acceptance |  | 3d | 2003-04-28 | 2003-04-30 | 35 |  |  | 2003-01-30 | 2003-02-03 | 3d | 467d |  | start no earlier than 2003-04-25 |

| ID | WBS | Task | Type | Duration | Start | Finish | Predecessors | Complete | Remaining | Baseline start | Baseline finish | Baseline duration | Total slack | Free slack | Constraint |
| --- | --- | --- | --- | --- | --- | --- | --- | --- | --- | --- | --- | --- | --- | --- | --- |
| 37 | 1.2 | **SM Structure Integration** |  | 17d | 2003-03-26 A | 2003-04-17 A |  | 100% |  | 2002-10-21 | 2002-11-07 | 14d |  |  |  |
| 38 | 1.2.1 | SM Structure Parts Delivery to RAL |  | 2d | 2003-03-26 A | 2003-03-27 A |  | 100% |  | 2002-10-21 | 2002-10-21 | 1d |  |  | start no earlier than 2003-03-26 |
| 39 | 1.2.2 | Clean |  | 1d | 2003-03-28 A | 2003-03-28 A | 38 | 100% |  | 2002-10-21 | 2002-10-21 | 2d |  |  |  |
| 40 | 1.2.3 | Bakeout |  | 2d | 2003-03-31 A | 2003-04-01 A | 39 | 100% |  | 2002-10-22 | 2002-10-24 | 3d |  |  |  |
| 41 | 1.2.4 | Assembly of SOB on MGSE |  | 1d | 2003-04-02 A | 2003-04-02 A | 40 | 100% |  | 2003-04-02 | 2003-04-02 | 1d |  |  |  |
| 42 | 1.2.5 | Bakeout at MSSL |  | 6d | 2003-03-31 A | 2003-04-07 A | 39 | 100% |  | 2003-03-31 | 2003-04-07 | 6d |  |  |  |
| 43 | 1.2.6 | Integration of all MSSL parts |  | 2d | 2003-04-08 A | 2003-04-09 A | 41, 42 | 100% |  | 2002-10-24 | 2002-10-24 | 1d |  |  |  |
| 44 | 1.2.7 | Integrate mirrors without alignment |  | 2d | 2003-04-10 A | 2003-04-11 A | 4, 43 | 100% |  | 2003-03-17 | 2003-03-18 | 2d |  |  |  |
| 45 | 1.2.8 | Integrate STM SMEC |  | 1d | 2003-04-15 A | 2003-04-15 A | 28, 46, 44 | 100% |  | 2003-03-24 | 2003-03-25 | 2d |  |  |  |
| 46 | 1.2.9 | Integrate STM cooler |  | 1d | 2003-04-14 A | 2003-04-14 A | 16, 44 | 100% |  | 2003-03-21 | 2003-03-21 | 1d |  |  |  |
| 47 | 1.2.10 | Integrate STM BDAs |  | 1d | 2003-04-17 A | 2003-04-17 A | 48, 20, 45 | 100% |  | 2003-03-27 | 2003-03-27 | 1d |  |  |  |
| 48 | 1.2.11 | Integrate STM BSM |  | 1d | 2003-04-16 A | 2003-04-16 A | 45, 8 | 100% |  | 2003-03-26 | 2003-03-26 | 1d |  |  |  |
| 49 | 1.3 | **Early vibration test** |  | 9d | 2003-04-17 A | 2003-05-01 A |  | 100% |  | 2003-03-14 | 2003-04-07 | 17d |  |  |  |
| 50 | 1.3.1 | Prepare for test |  | 2d | 2003-04-17 A | 2003-04-22 A | 48 | 100% |  | 2003-04-23 | 2003-04-24 | 2d |  |  | start no earlier than 2003-03-17 |
| 51 | 1.3.2 | Initial vibration test |  | 2d | 2003-04-28 A | 2003-04-29 A | 50 | 100% |  | 2003-03-28 | 2003-04-03 | 5d |  |  | start no earlier than 2003-04-25 |
| 52 | 1.3.3 | Return to G56, prepare for reconfig |  | 2d | 2003-04-30 A | 2003-05-01 A | 51 | 100% |  | 2003-04-30 | 2003-05-01 | 2d |  |  | start no earlier than 2003-04-25 |
| 53 | 2 | **AM programme** |  | 48d | 2003-05-02 A | 2003-07-10 |  | 43% | 27.29d | 2003-04-30 | 2003-06-12 | 32d | 418d |  |  |
| 54 | 2.1 | **Reconfigure to AM** |  | 19d | 2003-05-02 A | 2003-05-30 A |  | 100% |  | 2003-04-30 | 2003-05-13 | 10d |  |  |  |
| 55 | 2.1.1 | Adjust BSM shoe |  | 1d | 2003-05-02 A | 2003-05-02 A | 52 | 100% |  | 2003-05-02 | 2003-05-02 | 1d |  |  | start no earlier than 2003-04-25 |
| 56 | 2.1.2 | Rectify CM3 interface issue |  | 1d | 2003-05-06 A | 2003-05-06 A | 55 | 100% |  | 2003-05-06 | 2003-05-06 | 1d |  |  | start no earlier than 2003-04-25 |
| 57 | 2.1.3 | Fit OGSE, SMEC dummy etc |  | 2d | 2003-05-07 A | 2003-05-08 A | 56 | 100% |  | 2003-04-30 | 2003-05-06 | 5d |  |  |  |
| 58 | 2.1.4 | Carry out trial alignment TBD |  | 15d | 2003-05-09 A | 2003-05-30 A | 57 | 100% |  | 2003-04-04 | 2003-04-07 | 2d |  |  |  |
| 59 | 2.2 | **Cold alignment verification AM** |  | 33d | 2003-05-27 A | 2003-07-10 |  | 24% | 24.97d | 2002-12-19 | 2003-01-21 | 17d | 418d |  |  |
| 60 | 2.2.1 | Complete Optical Alignment |  | 2d | 2003-05-28 A | 2003-05-29 A |  | 100% |  | 2003-05-28 | 2003-05-29 | 2d |  |  |  |
| 61 | 2.2.2 | Install Thermometers into FPU |  | 1d | 2003-06-04 | 2003-06-04 | 60 |  |  | 2003-06-04 | 2003-06-04 | 1d | 74d | 0d | start no earlier than 2003-06-04 |
| 62 | 2.2.3 | Make Heater Blocks for Instrument |  | 7d | 2003-05-29 A | 2003-06-06 |  | 43% | 4d | 2003-05-29 | 2003-06-06 | 7d | 442d |  | start no earlier than 2003-05-29 |
| 63 | 2.2.4 | Prepare FPU for cold tests |  | 1d | 2003-06-05 | 2003-06-05 | 61 |  |  | 2003-06-05 | 2003-06-05 | 1d | 74d | 0d |  |
| 64 | 2.2.5 | Install STM JFET unit |  | 1d | 2003-06-06 | 2003-06-06 | 63 |  |  | 2003-06-06 | 2003-06-06 | 1d | 74d | 0d |  |
| 65 | 2.2.6 | Build up MGSE for cold trials |  | 1d | 2003-06-09 | 2003-06-09 | 64, 68 |  |  | 2003-06-09 | 2003-06-09 | 1d | 74d | 0d |  |
| 66 | 2.2.7 | Plumbing for Cryostat |  | 4d | 2003-05-27 A | 2003-06-03 |  | 75% | 1d | 2003-05-27 | 2003-06-03 | 4d | 83d | 9d | start no earlier than 2003-05-27 |
| 67 | 2.2.8 | Vacuum Window Tests |  | 2d | 2003-05-29 A | 2003-05-30 A |  | 100% |  | 2003-05-29 | 2003-05-30 | 2d |  |  | start no earlier than 2003-05-29 |
| 68 | 2.2.9 | Modifications to MGSE trolley |  | 1d | 2003-06-02 A | 2003-06-02 A | 67 | 100% |  | 2003-06-02 | 2003-06-02 | 1d |  |  |  |
| 69 | 2.2.10 | Modifications to 77K End Cap |  | 10d | 2003-05-29 A | 2003-06-11 |  | 30% | 7d | 2003-05-29 | 2003-06-11 | 10d | 77.5d | 3.5d | start no earlier than 2003-05-29 |
| 70 | 2.2.11 | Reinstall L0 Strap Heaters |  | 1d | 2003-06-04 | 2003-06-04 | 68 |  |  | 2003-06-04 | 2003-06-04 | 1d | 74d | 0d | start no earlier than 2003-06-04 |
| 71 | 2.2.12 | Clean up Laboratory |  | 2d | 2003-06-05 | 2003-06-06 | 70 |  |  | 2003-06-05 | 2003-06-06 | 2d | 74d | 0d |  |
| 72 | 2.2.13 | Cleanliness Inspection |  | 1d | 2003-06-09 | 2003-06-09 | 71 |  |  | 2003-06-09 | 2003-06-09 | 1d | 74d | 0d |  |
| 73 | 2.2.14 | Move SPIRE to Cryolab | milestone | 0d | 2003-06-09 | 2003-06-09 | 65, 72 |  |  | 2003-06-09 | 2003-06-09 | 0d? | 74d | 0d | start no earlier than 2003-06-09 |
| 74 | 2.2.15 | Install SPIRE into Cryostat |  | 4d | 2003-06-10 | 2003-06-13 | 73 |  |  | 2003-06-10 | 2003-06-13 | 4d | 74d | 0d |  |
| 75 | 2.2.16 | Warm Alignment Check |  | 1d | 2003-06-16 | 2003-06-16 | 74 |  |  | 2003-06-16 | 2003-06-16 | 1d | 74d | 0d |  |
| 76 | 2.2.17 | Test Readiness Review |  | 0.5d | 2003-06-17 | 2003-06-17 | 66, 75 |  |  | 2003-06-17 | 2003-06-17 | 0.5d | 74d | 0d |  |
| 77 | 2.2.18 | Pump-Down |  | 2d | 2003-06-17 | 2003-06-19 | 76, 69 |  |  | 2003-06-17 | 2003-06-19 | 2d | 74d | 0d |  |
| 78 | 2.2.19 | Purge He Can with N2 |  | 0.5d | 2003-06-19 | 2003-06-19 | 77FS-1d |  |  | 2003-06-19 | 2003-06-19 | 0.5d | 74d | 0d | start no earlier than 2003-06-19 |
| 79 | 2.2.20 | Warm Alignment Check |  | 1d | 2003-06-19 | 2003-06-20 | 77, 78 |  |  | 2003-06-19 | 2003-06-20 | 1d | 74d | 0d |  |
| 80 | 2.2.21 | Fill 77K shield |  | 1d | 2003-06-20 | 2003-06-23 | 79 |  |  | 2003-06-20 | 2003-06-23 | 1d | 74d | 0d |  |
| 81 | 2.2.22 | Precool He Vessel with LN2 |  | 2.5d | 2003-06-23 | 2003-06-25 | 80 |  |  | 2003-06-23 | 2003-06-25 | 2.5d | 74d | 0d |  |
| 82 | 2.2.23 | Fill He vessel with LHe |  | 1d | 2003-06-26 | 2003-06-26 | 81 |  |  | 2003-06-26 | 2003-06-26 | 1d | 74d | 0d |  |
| 83 | 2.2.24 | Cold Alignment Check |  | 2d | 2003-06-27 | 2003-06-30 | 82 |  |  | 2003-06-27 | 2003-06-30 | 2d | 74d | 0d |  |
| 84 | 2.2.25 | Warm up to Ambient |  | 4d | 2003-07-01 | 2003-07-04 | 83 |  |  | 2003-07-01 | 2003-07-04 | 4d | 74d | 0d |  |
| 85 | 2.2.26 | Warm Alignment |  | 1d | 2003-07-07 | 2003-07-07 | 84 |  |  | 2003-07-07 | 2003-07-07 | 1d | 74d | 0d |  |
| 86 | 2.2.27 | Let-Up to Air |  | 1d | 2003-07-08 | 2003-07-08 | 85 |  |  | 2003-07-08 | 2003-07-08 | 1d | 74d | 0d |  |
| 87 | 2.2.28 | Remove SPIRE from Cryostat |  | 2d | 2003-07-09 | 2003-07-10 | 86 |  |  | 2003-07-09 | 2003-07-10 | 2d | 74d | 0d |  |
| 88 | 2.2.29 | FPU Ready for CQM Integration | milestone | 0d | 2003-07-10 | 2003-07-10 | 87 |  |  | 2003-07-10 | 2003-07-10 | 0d? | 74d | 0d |  |

| ID | WBS | Task | Type | Duration | Start | Finish | Predecessors | Complete | Baseline start | Baseline finish | Baseline duration | Total slack | Free slack | Constraint | Resources | Work | Text1 | Text2 |
| --- | --- | --- | --- | --- | --- | --- | --- | --- | --- | --- | --- | --- | --- | --- | --- | --- | --- | --- |
| 89 | 3 | **AVM programme** |  | 15d | 2003-04-28 A | 2003-05-19 A |  | 100% | 2003-04-28 | 2003-05-19 | 15d |  |  |  |  |  |  |  |
| 90 | 3.1 | DPU testing with simulator and EGSE |  | 15d | 2003-04-28 A | 2003-05-19 A |  | 100% | 2003-04-28 | 2003-05-19 | 15d |  |  | start no earlier than 2003-04-28 |  |  |  |  |
| 91 | 4 | **Warm electronics programme** |  | 10d | 2003-07-25 | 2003-08-07 |  |  | 2003-06-30 | 2003-07-11 | 10d | 74d |  |  |  |  |  |  |
| 92 | 4.1 | DRCU QM1 delivery | milestone | 0d | 2003-07-25 | 2003-07-25 |  |  | 2003-06-30 | 2003-06-30 | 0d | 74d | 0d | start no earlier than 2003-07-25 |  |  |  |  |
| 93 | 4.2 | DRCU QM1 integration and test |  | 10d | 2003-07-25 | 2003-08-07 | 92, 90 |  | 2003-06-30 | 2003-07-11 | 10d | 74d | 0d | start no earlier than 2003-04-28 |  |  |  |  |
| 94 | 4.3 | DRCU QM1 available for CQM | milestone | 0d | 2003-08-07 | 2003-08-07 | 93 |  | 2003-07-11 | 2003-07-11 | 0d | 74d | 0d | start no earlier than 2003-04-28 |  |  |  |  |
| 95 | 5 | **CQM programme** |  | 155d | 2003-06-18 | 2004-02-03 |  |  | 2003-05-25 | 2003-12-17 | 148d | 91d |  |  |  | 32h |  |  |
| 96 | 5.1 | **STM/CQM FTB Subsystem Deliveries** |  | 15d | 2003-06-18 | 2003-07-08 |  |  | 2003-01-06 | 2003-01-08 | 2d | 95d |  |  |  | 32h | RAL | STM |
| 97 | 5.1.1 | STM JFET racks Delivery | milestone | 0d | 2003-06-18 | 2003-06-18 |  |  | 2003-01-06 | 2003-01-06 | 0d | 108d | 13d | start no earlier than 2003-06-18 |  |  | MSSL | STM |
| 98 | 5.1.2 | STM JFET Modules Delivery | milestone | 0d | 2003-07-03 | 2003-07-03 |  |  | 2003-01-06 | 2003-01-06 | 0d | 97d | 2d | start no earlier than 2003-07-03 |  |  | JPL | STM |
| 99 | 5.1.3 | CQM JFET module delivery (1 off) | milestone | 0d | 2003-07-06 | 2003-07-06 |  |  | 2003-06-16 | 2003-06-16 | 0d | 95d | 0d | start no earlier than 2003-07-06 |  |  |  |  |
| 100 | 5.1.4 | STM/CQM FTB RF Filter Modules Delivery | milestone | 0d | 2003-06-24 | 2003-06-24 |  |  | 2003-01-08 | 2003-01-08 | 0d | 100d | 26d | start no earlier than 2003-06-24 |  |  | JPL | STM |
| 101 | 5.1.5 | JFET Module STM/CQM Integration |  | 2d | 2003-07-07 | 2003-07-08 | 97, 98, 99 |  | 2003-01-06 | 2003-01-07 | 2d | 95d | 21d | start no earlier than 2003-03-28 | Technician; Electronics Engineer | 32h | RAL | STM |
| 102 | 5.2 | **Preparation of CQM** |  | 28d | 2003-07-11 | 2003-08-19 |  |  | 2003-01-22 | 2003-02-11 | 15d | 74d |  |  |  |  |  |  |
| 103 | 5.2.1 | Remove Instrument Covers and place into MGSE |  | 2d | 2003-07-11 | 2003-07-14 | 88 |  | 2003-01-22 | 2003-01-23 | 2d | 74d | 0d |  |  |  |  |  |
| 104 | 5.2.2 | Remove OGSE |  | 1d | 2003-07-15 | 2003-07-15 | 103 |  | 2003-01-24 | 2003-01-24 | 1d | 74d | 0d |  |  |  |  |  |
| 105 | 5.2.3 | Integration of STM Subsystems |  | 8d | 2003-07-16 | 2003-07-25 | 104, 16, 18, 20, 22, 24, 26, 28, 30, 32, 34, 10 |  | 2003-01-27 | 2003-02-05 | 8d | 74d | 0d |  |  |  |  |  |
| 106 | 5.2.4 | Integrate CQM cooler |  | 1d | 2003-07-28 | 2003-07-28 | 105 |  | 2003-07-01 | 2003-07-01 | 1d | 74d | 0d | start no earlier than 2003-04-25 |  |  |  |  |
| 107 | 5.2.5 | Integrate PLW BDA |  | 1d | 2003-07-29 | 2003-07-29 | 106 |  | 2003-06-23 | 2003-06-24 | 2d | 74d | 0d | start no earlier than 2003-03-31 |  |  |  |  |
| 108 | 5.2.6 | Integrate RF filter modules |  | 1d | 2003-07-30 | 2003-07-30 | 100, 107 |  | 2003-07-03 | 2003-07-03 | 1d | 74d | 0d | start no earlier than 2003-04-25 |  |  |  |  |
| 109 | 5.2.7 | Integrate all internal harness |  | 3d | 2003-07-31 | 2003-08-04 | 108 |  | 2003-07-04 | 2003-07-08 | 3d | 74d | 0d | start no earlier than 2003-04-25 |  |  |  |  |
| 110 | 5.2.8 | Fit L0 straps |  | 1d | 2003-08-05 | 2003-08-05 | 109 |  | 2003-07-09 | 2003-07-09 | 1d | 74d | 0d | start no earlier than 2003-04-25 |  |  |  |  |
| 111 | 5.2.9 | Refit Covers |  | 1d | 2003-08-06 | 2003-08-06 | 110 |  | 2003-02-06 | 2003-02-06 | 1d | 74d | 0d |  |  |  |  |  |
| 112 | 5.2.10 | Integrate JFET Boxes and harnesses |  | 1d | 2003-08-07 | 2003-08-07 | 111, 101 |  | 2003-02-07 | 2003-02-07 | 1d | 74d | 0d |  |  |  |  |  |
| 113 | 5.2.11 | Fuctional check |  | 6d | 2003-08-08 | 2003-08-15 | 112, 94 |  | 2003-07-14 | 2003-07-21 | 6d | 74d | 0d | start no earlier than 2003-04-25 |  |  |  |  |
| 114 | 5.2.12 | Prepare Instrument and Transport to Vibration Facility |  | 1d | 2003-08-18 | 2003-08-18 | 113 |  | 2003-02-10 | 2003-02-10 | 1d | 74d | 0d |  |  |  |  |  |
| 115 | 5.2.13 | STM Warm Vibration Test Readiness Review |  | 1d | 2003-08-19 | 2003-08-19 | 114 |  | 2003-02-11 | 2003-02-11 | 1d | 74d | 0d |  |  |  |  |  |

| ID | WBS | Task | Type | Duration | Start | Finish | Predecessors | Baseline start | Baseline finish | Baseline duration | Total slack | Free slack |
| --- | --- | --- | --- | --- | --- | --- | --- | --- | --- | --- | --- | --- |
| 116 | 5.3 | **CQM Warm Environmental Test** |  | 9d | 2003-08-20 | 2003-09-01 |  | 2003-01-22 | 2003-02-27 | 27d | 74d |  |
| 117 | 5.3.1 | **CQM Warm Vibration** |  | 9d | 2003-08-20 | 2003-09-01 |  | 2003-02-12 | 2003-02-27 | 12d | 74d |  |
| 118 | 5.3.1.1 | 3 axes - I day per axis plus setup |  | 5d | 2003-08-20 | 2003-08-26 | 115 | 2003-02-12 | 2003-02-18 | 5d | 74d | 0d |
| 119 | 5.3.1.2 | Preparation and Transport to Integration Facility |  | 1d | 2003-08-27 | 2003-08-27 | 118 | 2003-02-19 | 2003-02-19 | 1d | 74d | 0d |
| 120 | 5.3.1.3 | Post-Vibration Test |  | 2d | 2003-08-28 | 2003-08-29 | 119 | 2003-02-20 | 2003-02-26 | 5d | 74d | 0d |
| 121 | 5.3.1.4 | Review Preparation |  | 3d | 2003-08-20 | 2003-08-22 | 115 | 2003-02-12 | 2003-02-14 | 3d | 79d | 5d |
| 122 | 5.3.1.5 | STM Interim Review | milestone | 1d | 2003-09-01 | 2003-09-01 | 121, 120 | 2003-02-27 | 2003-02-27 | 1d | 74d | 0d |
| 123 | 5.4 | **CQM Cold Verification 1** |  | 27d | 2003-09-02 | 2003-10-08 |  | 2003-02-28 | 2003-04-10 | 29.5d | 74d |  |
| 124 | 5.4.1 | Prepare and Transport to Cryolab |  | 2d | 2003-09-02 | 2003-09-03 | 122 | 2003-03-07 | 2003-03-07 | 0.5d | 74d | 0d |
| 125 | 5.4.2 | Integrate into Cryostat and Thermometry |  | 3d | 2003-09-04 | 2003-09-08 | 124 | 2003-03-07 | 2003-03-12 | 3d | 74d | 0d |
| 126 | 5.4.3 | Replace cryostat optical filters with FIR filters |  | 1d | 2003-09-09 | 2003-09-09 | 125 | 2003-03-11 | 2003-03-12 | 1d | 74d | 0d |
| 127 | 5.4.4 | Cold Thermal Test Readiness Review | milestone | 1d | 2003-09-10 | 2003-09-10 | 126, 125 | 2003-03-12 | 2003-03-13 | 1d | 74d | 0d |
| 128 | 5.4.5 | Pump Down |  | 1d | 2003-09-11 | 2003-09-11 | 125, 127 | 2003-03-13 | 2003-03-14 | 1d | 74d | 0d |
| 129 | 5.4.6 | Cooldown |  | 3d | 2003-09-12 | 2003-09-16 | 128 | 2003-03-14 | 2003-03-19 | 3d | 74d | 0d |
| 130 | 5.4.7 | Thermal Verification Tests |  | 10d | 2003-09-17 | 2003-09-30 | 129 | 2003-03-19 | 2003-04-02 | 10d | 74d | 0d |
| 131 | 5.4.8 | Warm up and let up to ambient pressure |  | 3d | 2003-10-01 | 2003-10-03 | 130 | 2003-04-02 | 2003-04-07 | 3d | 74d | 0d |
| 132 | 5.4.9 | De-integrate Instrument from Cryostat and return to Integration Area |  | 3d | 2003-10-06 | 2003-10-08 | 131 | 2003-04-07 | 2003-04-10 | 3d | 74d | 0d |
| 133 | 5.5 | **CQM Cold Vibration** |  | 30d | 2003-10-09 | 2003-11-19 |  | 2003-04-10 | 2003-05-21 | 29d | 74d |  |
| 134 | 5.5.1 | Cold Vibration Test Readiness Review |  | 1d | 2003-10-09 | 2003-10-09 | 132 | 2003-04-10 | 2003-04-11 | 1d | 74d | 0d |
| 135 | 5.5.2 | Instrument preparation for Vibration |  | 3d | 2003-10-10 | 2003-10-14 | 134 | 2003-04-11 | 2003-04-16 | 3d | 74d | 0d |
| 136 | 5.5.3 | Instrument Placed in Transport Container(s) and packing |  | 1d | 2003-10-15 | 2003-10-15 | 135 | 2003-04-16 | 2003-04-21 | 3d | 74d | 0d |
| 137 | 5.5.4 | Transport to facility |  | 2d | 2003-10-16 | 2003-10-17 | 136 | 2003-04-21 | 2003-04-23 | 2d | 74d | 0d |
| 138 | 5.5.5 | Cold Vibration Campaign |  | 20d | 2003-10-20 | 2003-11-14 | 137 | 2003-04-23 | 2003-05-14 | 15d | 74d | 0d |
| 139 | 5.5.6 | Instrument Placed in Transport Container and packing |  | 1d | 2003-11-17 | 2003-11-17 | 138 | 2003-05-14 | 2003-05-19 | 3d | 74d | 0d |
| 140 | 5.5.7 | Transport to RAL |  | 2d | 2003-11-18 | 2003-11-19 | 139 | 2003-05-19 | 2003-05-21 | 2d | 74d | 0d |

| ID | WBS | Task | Type | Duration | Start | Finish | Predecessors | Baseline start | Baseline finish | Baseline duration | Total slack | Free slack | Constraint |
| --- | --- | --- | --- | --- | --- | --- | --- | --- | --- | --- | --- | --- | --- |
| 141 | 5.6 | **CQM Cold Verification 2** |  | 22d | 2003-11-20 | 2003-12-19 |  | 2003-05-21 | 2003-06-20 | 22d | 74d |  |  |
| 142 | 5.6.1 | Integrate into Cryostat and Thermometry |  | 3d | 2003-11-20 | 2003-11-24 | 140 | 2003-05-21 | 2003-05-26 | 3d | 74d | 0d |  |
| 143 | 5.6.2 | Pump Down |  | 1d | 2003-11-25 | 2003-11-25 | 142 | 2003-05-26 | 2003-05-27 | 1d | 74d | 0d |  |
| 144 | 5.6.3 | Cooldown |  | 3d | 2003-11-26 | 2003-11-28 | 143 | 2003-05-27 | 2003-05-30 | 3d | 74d | 0d |  |
| 145 | 5.6.4 | Thermal verification and Cold Alignment Tests |  | 10d | 2003-12-01 | 2003-12-12 | 144 | 2003-05-30 | 2003-06-13 | 10d | 74d | 0d |  |
| 146 | 5.6.5 | Warm up and let up to ambient pressure |  | 3d | 2003-12-15 | 2003-12-17 | 145 | 2003-06-13 | 2003-06-18 | 3d | 74d | 0d |  |
| 147 | 5.6.6 | De-integrate Instrument from Cryostat and return to Integration Area |  | 2d | 2003-12-18 | 2003-12-19 | 146 | 2003-06-18 | 2003-06-20 | 2d | 74d | 0d |  |
| 148 | 5.7 | **CQM modifications before delivery** |  | 10d | 2004-01-05 | 2004-01-16 | 147 | 2003-06-20 | 2003-06-30 | 6d | 280d |  |  |
| 149 | 5.7.1 | Remove unwanted subsystems |  | 5d | 2004-01-05 | 2004-01-09 |  | 2003-06-25 | 2003-06-30 | 3d | 280d | 0d |  |
| 150 | 5.7.2 | Final checkout |  | 5d | 2004-01-12 | 2004-01-16 | 149 | 2003-12-17 | 2004-01-14 | 10d | 280d | 0d | start no earlier than 2003-03-31 |
| 151 | 5.8 | **CQM Delivery Preparation** |  | 57d | 2003-11-03 | 2004-02-03 |  | 2003-12-04 | 2003-12-19 | 11d | 280d |  |  |
| 152 | 5.8.1 | Mass properties Measurement |  | 3d | 2004-01-19 | 2004-01-21 | 150 | 2003-12-04 | 2003-12-08 | 2d | 280d | 0d |  |
| 153 | 5.8.2 | Interface measurements |  | 3d | 2004-01-22 | 2004-01-26 | 152 | 2003-11-05 | 2003-11-06 | 2d | 280d | 0d |  |
| 154 | 5.8.3 | Packing and shipment |  | 3d | 2004-01-27 | 2004-01-29 | 153 | 2003-12-08 | 2003-12-11 | 3d | 280d | 0d |  |
| 155 | 5.8.4 | Preparation of Delivery Data Package |  | 42d | 2003-11-03 | 2004-01-13 |  | 2003-12-11 | 2003-12-18 | 5d | 292d | 12d | start no earlier than 2003-11-03 |
| 156 | 5.8.5 | CQM Delivery Readiness Review |  | 1d | 2004-01-30 | 2004-01-30 | 155, 154 | 2003-12-18 | 2003-12-19 | 1d | 280d | 0d |  |
| 157 | 5.8.6 | Ship to Alcatel |  | 2d | 2004-02-02 | 2004-02-03 | 156 | 2003-11-13 | 2003-11-14 | 2d | 280d | 0d |  |
| 158 | 5.9 | Delivery of STM/CQM to ESA | milestone | 0d | 2004-02-03 | 2004-02-03 | 157 | 2003-12-19 | 2003-12-19 | 0d | 280d |  |  |
| 160 | 6 | **PFM AIV programme** |  | 372d | 2003-09-15 | 2005-03-01 |  | 2003-06-10 | 2004-04-28 | 222d | 0d |  |  |
| 161 | 6.1 | **CQM/PFM FPU Subsystem Deliveries** |  | 13d | 2003-09-15 | 2003-10-01 |  | 2003-05-27 | 2003-05-30 | 3d | 122d |  |  |
| 162 | 6.1.1 | PFM structure delivery (part) | milestone | 0d | 2003-09-15 | 2003-09-15 |  | 2003-11-03 | 2003-11-03 | 0d | 125d | 0d | start no earlier than 2003-09-15 |
| 163 | 6.1.2 | PFM structure assembly |  | 10d | 2003-09-15 | 2003-09-26 | 162 | 2003-11-03 | 2003-11-14 | 10d | 125d | 3d | start no earlier than 2003-03-24 |
| 164 | 6.1.3 | CQM Filters, Dichroics and Beamsplitters Delivery | milestone | 0d | 2003-09-29 | 2003-09-29 |  | 2003-05-27 | 2003-05-27 | 0d | 122d | 0d | start no earlier than 2003-09-29 |
| 165 | 6.1.4 | CQM Filters, Dichroics and Beamsplitters Acceptance |  | 3d | 2003-09-29 | 2003-10-01 | 164 | 2003-05-27 | 2003-05-30 | 3d | 122d | 0d |  |
| 166 | 6.1.5 | CQM BDAs Delivery | milestone | 0d | 2003-09-29 | 2003-09-29 |  | 2003-05-27 | 2003-05-27 | 0d | 122d | 0d | start no earlier than 2003-09-29 |
| 167 | 6.1.6 | CQM BDAs Acceptance |  | 3d | 2003-09-29 | 2003-10-01 | 166 | 2003-05-27 | 2003-05-30 | 3d | 122d | 0d |  |
| 168 | 6.1.7 | CQM SMECm Delivery | milestone | 0d | 2003-09-29 | 2003-09-29 |  | 2003-05-27 | 2003-05-27 | 0d | 122d | 0d | start no earlier than 2003-09-29 |
| 169 | 6.1.8 | CQM SMECm Acceptance |  | 3d | 2003-09-29 | 2003-10-01 | 168 | 2003-05-27 | 2003-05-30 | 3d | 122d | 0d |  |
| 170 | 6.1.9 | CQM SCAL Delivery | milestone | 0d | 2003-09-29 | 2003-09-29 |  | 2003-05-27 | 2003-05-27 | 0d | 122d | 0d | start no earlier than 2003-09-29 |
| 171 | 6.1.10 | CQM SCAL Acceptance |  | 3d | 2003-09-29 | 2003-10-01 | 170 | 2003-05-27 | 2003-05-30 | 3d | 122d | 0d |  |
| 172 | 6.1.11 | CQM BSMm Delivery | milestone | 0d | 2003-09-29 | 2003-09-29 |  | 2003-05-27 | 2003-05-27 | 0d | 122d | 0d | start no earlier than 2003-09-29 |
| 173 | 6.1.12 | CQM BSMm Acceptance |  | 3d | 2003-09-29 | 2003-10-01 | 172 | 2003-05-27 | 2003-05-30 | 3d | 122d | 0d |  |
| 174 | 6.1.13 | CQM FPU RF Filters Delivery | milestone | 0d | 2003-09-29 | 2003-09-29 |  | 2003-05-27 | 2003-05-27 | 0d | 122d | 0d | start no earlier than 2003-09-29 |
| 175 | 6.1.14 | CQM FPU RF Filters Acceptance |  | 3d | 2003-09-29 | 2003-10-01 | 174 | 2003-05-27 | 2003-05-30 | 3d | 122d | 0d |  |

| ID | WBS | Task | Type | Duration | Start | Finish | Predecessors | Baseline start | Baseline finish | Baseline duration | Total slack | Free slack | Constraint |
| --- | --- | --- | --- | --- | --- | --- | --- | --- | --- | --- | --- | --- | --- |
| 176 | 6.2 | **CQM/PFM FTB Subsystem Deliveries** |  | 8d | 2003-10-13 | 2003-10-22 |  | 2003-05-30 | 2003-06-19 | 14.5d | 336d |  |  |
| 177 | 6.2.1 | CQM JFET Modules Delivery | milestone | 0d | 2003-10-13 | 2003-10-13 |  | 2003-05-30 | 2003-05-30 | 0d | 341d | 0d | start no earlier than 2003-10-13 |
| 178 | 6.2.2 | CQM JFET Modules Acceptance |  | 3d | 2003-10-13 | 2003-10-15 | 177 | 2003-06-17 | 2003-06-19 | 3d | 341d | 5d |  |
| 179 | 6.2.3 | CQM FTB RF Filter Modules Delivery | milestone | 0d | 2003-10-20 | 2003-10-20 |  | 2003-05-30 | 2003-05-30 | 0d | 336d | 0d | start no earlier than 2003-10-20 |
| 180 | 6.2.4 | CQM FTB RF Filter Modules Acceptance |  | 3d | 2003-10-20 | 2003-10-22 | 179 | 2003-06-17 | 2003-06-19 | 3d | 336d | 0d |  |
| 181 | 6.3 | **CQM/PFM FTB Integration** |  | 8d | 2003-10-23 | 2003-11-03 |  | 2003-07-18 | 2003-07-29 | 8d | 336d |  |  |
| 182 | 6.3.1 | JFET Module Integration |  | 2d | 2003-10-23 | 2003-10-24 | 178, 180 | 2003-07-18 | 2003-07-21 | 2d | 336d | 0d |  |
| 183 | 6.3.2 | RF Filter Modules Integration |  | 1d | 2003-10-27 | 2003-10-27 | 182 | 2003-07-22 | 2003-07-22 | 1d | 336d | 0d |  |
| 184 | 6.3.3 | FTB Final Integration |  | 5d | 2003-10-28 | 2003-11-03 | 183 | 2003-07-23 | 2003-07-29 | 5d | 336d |  |  |
| 185 | 6.4 | **FPU Integration** |  | 9d | 2003-10-02 | 2003-10-14 | 175, 165, 167, 169, 171, 173 | 2003-06-27 | 2003-08-01 | 25.5d | 122d |  |  |
| 186 | 6.4.1 | **FPU integration phase 1** |  | 9d | 2003-10-02 | 2003-10-14 |  | 2003-10-20 | 2003-10-30 | 9d | 122d |  |  |
| 187 | 6.4.1.1 | **Spectrometer side Integration** |  | 9d | 2003-10-02 | 2003-10-14 |  | 2003-07-03 | 2003-07-08 | 3d | 122d |  |  |
| 188 | 6.4.1.1.1 | Spectrometer Detector Box Integration and Alignement |  | 1d | 2003-10-02 | 2003-10-02 | 163 | 2003-07-14 | 2003-07-15 | 1d | 122d | 0d |  |
| 189 | 6.4.1.1.2 | Spectrometer Detector Harness Integration |  | 1d | 2003-10-03 | 2003-10-03 | 188 | 2003-07-15 | 2003-07-15 | 0.5d | 122d | 0d |  |
| 190 | 6.4.1.1.3 | SLW BDA Integration and Alignment |  | 1d | 2003-10-06 | 2003-10-06 | 189 | 2003-07-03 | 2003-07-04 | 1d | 122d | 0d |  |
| 191 | 6.4.1.1.4 | SSW BDA Integration and Alignment |  | 1d | 2003-10-07 | 2003-10-07 | 190 | 2003-07-04 | 2003-07-07 | 1d | 122d | 0d |  |
| 192 | 6.4.1.1.5 | Filter Integration |  | 2d | 2003-10-08 | 2003-10-09 | 191 | 2003-07-07 | 2003-07-08 | 1d | 122d | 0d |  |
| 193 | 6.4.1.1.6 | FPU RF Filters Integration |  | 1d | 2003-10-10 | 2003-10-10 | 192 | 2003-07-08 | 2003-07-09 | 1d | 122d | 0d |  |
| 194 | 6.4.1.1.7 | SMECm CQM Integration |  | 1d | 2003-10-13 | 2003-10-13 | 193 | 2003-07-09 | 2003-07-10 | 1d | 122d | 0d |  |
| 195 | 6.4.1.1.8 | SCAL integration |  | 1d | 2003-10-14 | 2003-10-14 | 194 | 2003-10-30 | 2003-10-30 | 1d | 122d | 48d | start no earlier than 2003-04-28 |
| 196 | 6.5 | **QM2 Warm electronics Deliveries** |  | 30d | 2003-10-13 | 2003-11-21 |  | 2003-04-09 | 2003-04-11 | 3d | 68d |  |  |
| 197 | 6.5.1 | QM2 DRCU Delivery to RAL | milestone | 0d | 2003-11-17 | 2003-11-17 |  | 2003-04-09 | 2003-04-09 | 0d | 68d | 0d | start no earlier than 2003-11-17 |
| 198 | 6.5.2 | QM2 DRCU Acceptance |  | 5d | 2003-11-17 | 2003-11-21 | 197 | 2003-04-09 | 2003-04-11 | 3d | 68d | 0d |  |
| 199 | 6.5.3 | QM2 WIH Delivery to RAL | milestone | 0d | 2003-11-10 | 2003-11-10 |  | 2003-04-09 | 2003-04-09 | 0d | 75d | 0d | start no earlier than 2003-11-10 |
| 200 | 6.5.4 | QM2 WIH Acceptance |  | 3d | 2003-11-10 | 2003-11-12 | 199 | 2003-04-09 | 2003-04-11 | 3d | 75d | 7d |  |
| 201 | 6.5.5 | FPU Simulator#2 Delivery to RAL | milestone | 0d | 2003-11-10 | 2003-11-10 |  | 2003-04-09 | 2003-04-09 | 0d | 75d | 0d | start no earlier than 2003-11-10 |
| 202 | 6.5.6 | FPU Simulator#2 Acceptance |  | 3d | 2003-11-10 | 2003-11-12 | 201 | 2003-04-09 | 2003-04-11 | 3d | 75d | 7d |  |
| 203 | 6.5.7 | QM DPU Delivery to RAL | milestone | 0d | 2003-11-10 | 2003-11-10 |  | 2003-06-09 | 2003-06-09 | 0d | 73d | 0d | start no earlier than 2003-11-10 |
| 204 | 6.5.8 | QM DPU Acceptance |  | 1w | 2003-11-10 | 2003-11-14 | 203 | 2003-06-09 | 2003-06-20 | 2w | 73d | 5d |  |
| 205 | 6.5.9 | EGSE#3 Available | milestone | 0d | 2003-10-13 | 2003-10-13 |  | 2003-06-09 | 2003-06-09 | 0d | 98d | 30d | start no earlier than 2003-10-13 |

| ID | WBS | Task | Duration | Start | Finish | Predecessors | Baseline start | Baseline finish | Baseline duration | Total slack | Free slack | Constraint |
| --- | --- | --- | --- | --- | --- | --- | --- | --- | --- | --- | --- | --- |
| 206 | 6.6 | **QM2 Warm Electronics Integration** | 30d | 2003-11-24 | 2004-01-16 |  | 2003-05-12 | 2003-07-07 | 40d | 68d |  |  |
| 207 | 6.6.1 | Warm Electronics Integration Test | 4w | 2003-11-24 | 2003-12-19 | 202, 198, 200, 204, 205, 214 | 2003-05-12 | 2003-06-06 | 4w | 68d | 0d |  |
| 208 | 6.6.2 | Test Facility Integration | 2w | 2004-01-05 | 2004-01-16 | 207 | 2003-06-23 | 2003-07-04 | 2w | 68d | 0d |  |
| 209 | 6.7 | **FPU test phase 1** | 57d | 2004-01-05 | 2004-03-23 |  | 2003-10-20 | 2004-02-25 | 83d | 74d |  |  |
| 210 | 6.7.1 | **Instrument Integration I** | 13d | 2004-01-05 | 2004-01-21 | 147 | 2003-08-06 | 2003-08-14 | 7d | 68d |  |  |
| 211 | 6.7.1.1 | FPUFTB Preparation and Transport to Cryolab | 1d | 2004-01-05 | 2004-01-05 | 195 | 2003-08-06 | 2003-08-06 | 1d | 74d | 0d |  |
| 212 | 6.7.1.2 | FPU/FTB Integration into Cryostat | 2d | 2004-01-06 | 2004-01-07 | 211 | 2003-08-07 | 2003-08-08 | 2d | 74d | 0d |  |
| 213 | 6.7.1.3 | FPU/FTB Integration with Warm Electronics | 1d | 2004-01-08 | 2004-01-08 | 212 | 2003-08-11 | 2003-08-11 | 1d | 74d | 6d |  |
| 214 | 6.7.1.4 | Warm Functional Test I | 3d | 2004-01-19 | 2004-01-21 | 213, 208, 195 | 2003-08-12 | 2003-08-14 | 3d | 68d | 0d |  |
| 215 | 6.7.2 | **Instrument Cold Verification 1** | 44d | 2004-01-22 | 2004-03-23 |  | 2003-09-26 | 2003-11-19 | 38d | 68d |  |  |
| 216 | 6.7.2.1 | Pumpdown | 1d | 2004-01-22 | 2004-01-22 | 214 | 2003-09-26 | 2003-09-29 | 1d | 68d | 0d |  |
| 217 | 6.7.2.2 | Cooldown | 3d | 2004-01-23 | 2004-01-27 | 216 | 2003-09-29 | 2003-10-02 | 3d | 68d | 0d |  |
| 218 | 6.7.2.3 | Thermal performance verification | 3d | 2004-01-28 | 2004-01-30 | 217 | 2003-09-09 | 2003-09-11 | 3d | 68d | 0d |  |
| 219 | 6.7.2.4 | FIR alignment check | 5d | 2004-02-02 | 2004-02-06 | 218, 208 | 2003-09-12 | 2003-09-18 | 5d | 68d | 0d |  |
| 220 | 6.7.2.5 | Cold Functional Test III | 2d | 2004-02-09 | 2004-02-10 | 219 | 2003-10-02 | 2003-10-06 | 2d | 68d | 0d |  |
| 221 | 6.7.2.6 | Subsystem Performance Verification | 5d | 2004-02-11 | 2004-02-17 | 220 | 2003-10-06 | 2003-10-13 | 5d | 68d | 0d |  |
| 222 | 6.7.2.7 | Instrument verification 1 | 20d | 2004-02-18 | 2004-03-16 | 221 | 2004-01-29 | 2004-02-25 | 20d | 68d | 0d | start no earlier than 2003-04-25 |
| 223 | 6.7.2.8 | Warmup | 3d | 2004-03-17 | 2004-03-19 | 222 | 2003-11-12 | 2003-11-17 | 3d | 245d | 0d |  |
| 224 | 6.7.2.9 | FPU/FTB De-integration from Cryostat | 2d | 2004-03-22 | 2004-03-23 | 223 | 2003-11-17 | 2003-11-19 | 2d | 245d |  |  |
| 225 | 6.8 | **FPU integration phase 2** | 14d | 2004-03-17 | 2004-04-05 |  | 2004-02-26 | 2004-03-16 | 14d | 68d |  |  |
| 226 | 6.8.1 | **Photometer side Integration** | 14d | 2004-03-17 | 2004-04-05 |  | 2003-06-27 | 2003-07-03 | 4d | 68d |  |  |
| 227 | 6.8.1.1 | PLW BDA Integration and Alignment | 2d | 2004-03-17 | 2004-03-18 | 222 | 2003-06-27 | 2003-06-30 | 1d | 68d | 0d |  |
| 228 | 6.8.1.2 | PMW BDA Integration and Alignment | 2d | 2004-03-19 | 2004-03-22 | 227 | 2003-06-30 | 2003-07-01 | 1d | 68d | 0d |  |
| 229 | 6.8.1.3 | PSW BDA Integration and Alignment | 2d | 2004-03-23 | 2004-03-24 | 228 | 2003-07-01 | 2003-07-02 | 1d | 68d | 0d |  |
| 230 | 6.8.1.4 | Dichroic and Filter Integration | 3d | 2004-03-25 | 2004-03-29 | 229 | 2003-07-02 | 2003-07-03 | 1d | 68d | 0d |  |
| 231 | 6.8.1.5 | Other upgrades to full FM spec | 5d | 2004-03-30 | 2004-04-05 | 230 | 2004-03-10 | 2004-03-16 | 5d | 236d |  | start no earlier than 2003-04-28 |

| ID | WBS | Task | Type | Duration | Start | Finish | Predecessors | Baseline start | Baseline finish | Baseline duration | Total slack | Free slack | Constraint | Text2 |
| --- | --- | --- | --- | --- | --- | --- | --- | --- | --- | --- | --- | --- | --- | --- |
| 232 | 6.9 | **FPU test phase 2** |  | 20d | 2004-03-30 | 2004-04-26 |  | 2003-07-16 | 2003-08-01 | 13d | 68d |  |  |  |
| 233 | 6.9.1 | Instrument integration |  | 10d | 2004-03-30 | 2004-04-12 | 230 | 2004-03-10 | 2004-03-23 | 10d | 68d | 0d | start no earlier than 2003-04-28 |  |
| 234 | 6.9.2 | Instrument test |  | 10d | 2004-04-13 | 2004-04-26 | 233 | 2004-03-24 | 2004-04-06 | 10d | 68d | 0d | start no earlier than 2003-04-28 |  |
| 235 | 6.10 | **PFM Verification** |  | 167d | 2004-04-27 | 2004-12-15 |  | 2003-12-08 | 2004-03-24 | 71d | 0d |  |  | PFM |
| 236 | 6.10.1 | **PFM Instrument Cold Tests I** |  | 21d | 2004-04-27 | 2004-05-25 |  | 2003-12-08 | 2004-01-14 | 21d | 68d | 0d |  | PFM |
| 237 | 6.10.1.1 | Cool down |  | 4d | 2004-04-27 | 2004-04-30 | 234 | 2003-12-08 | 2003-12-11 | 4d | 68d | 0d |  | PFM |
| 238 | 6.10.1.2 | Interface Checks |  | 2d | 2004-05-03 | 2004-05-04 | 237 | 2003-12-12 | 2003-12-15 | 2d | 68d | 0d |  | PFM |
| 239 | 6.10.1.3 | Cold Functional Tests I |  | 5d | 2004-05-05 | 2004-05-11 | 238 | 2003-12-16 | 2003-12-22 | 5d | 68d | 0d |  | PFM |
| 240 | 6.10.1.4 | Pre-vibration Performance Tests |  | 5d | 2004-05-12 | 2004-05-18 | 239 | 2003-12-23 | 2004-01-07 | 5d | 68d | 0d |  | PFM |
| 241 | 6.10.1.5 | Warm Up |  | 4d | 2004-05-19 | 2004-05-24 | 240 | 2004-01-08 | 2004-01-13 | 4d | 68d | 0d |  | PFM |
| 242 | 6.10.1.6 | Warm Functional Tests II |  | 1d | 2004-05-25 | 2004-05-25 | 241 | 2004-01-14 | 2004-01-14 | 1d | 68d |  |  | PFM |
| 243 | 6.10.2 | **PFM Cold Vibration** |  | 7d | 2004-05-25 | 2004-06-03 | 236 | 2004-01-15 | 2004-03-09 | 39d | 68d | 0d |  | PFM |
| 244 | 6.10.2.1 | FPU/FTB Packing and preparation |  | 5d | 2004-05-26 | 2004-06-01 |  | 2004-01-15 | 2004-01-21 | 5d | 68d | 0d |  | PFM |
| 245 | 6.10.2.2 | Ship FPU/FTB to Cold Vibration Facility |  | 2d | 2004-06-02 | 2004-06-03 | 244 | 2004-01-22 | 2004-01-23 | 2d | 68d | 0d |  | PFM |
| 246 | 6.10.2.3 | Delivery of FPU/FTB to Cold Vibration Facility | milestone | 0d | 2004-06-03 | 2004-06-03 | 245 | 2004-01-23 | 2004-01-23 | 0d | 68d |  |  | PFM |
| 247 | 6.10.2.4 | Delivery of FPU/FTB from Cold Vibration Facility | milestone | 0d | 2004-05-25 | 2004-05-25 |  | 2004-02-27 | 2004-02-27 | 0d | 68d | 0d |  | PFM |
| 248 | 6.10.2.5 | FPU/FTB Integration into Test Cryostat |  | 3d | 2004-05-26 | 2004-05-28 | 247 | 2004-03-01 | 2004-03-03 | 3d | 68d | 0d |  | PFM |
| 249 | 6.10.2.6 | FPU/FTB Integration with Cryoharness |  | 3d | 2004-05-31 | 2004-06-02 | 248 | 2004-03-04 | 2004-03-08 | 3d | 68d | 0d |  | PFM |
| 250 | 6.10.2.7 | Warm Functional Tests III |  | 1d | 2004-06-03 | 2004-06-03 | 249 | 2004-03-09 | 2004-03-09 | 1d | 68d |  |  | PFM |
| 251 | 6.10.3 | **PFM Instrument Cold Tests II** |  | 71d | 2004-06-04 | 2004-09-10 | 243 | 2004-03-10 | 2004-03-24 | 11d | 68d |  |  | PFM |
| 252 | 6.10.3.1 | Cool Down |  | 3d | 2004-06-04 | 2004-06-08 |  | 2004-03-10 | 2004-03-12 | 3d | 68d | 0d |  | PFM |
| 253 | 6.10.3.2 | Cold Functional Tests II |  | 3d | 2004-06-09 | 2004-06-11 | 252 | 2004-03-15 | 2004-03-17 | 3d | 68d | 0d |  | PFM |
| 254 | 6.10.3.3 | Post-vibration Performance Tests |  | 5d | 2004-06-14 | 2004-06-18 | 253 | 2004-03-18 | 2004-03-24 | 5d | 68d | 0d |  | PFM |
| 255 | 6.10.3.4 | Trial calibration runs with QM2 DRCU |  | 60d | 2004-06-21 | 2004-09-10 | 254 | 2004-06-14 | 2004-09-03 | 60d | 68d |  | start no earlier than 2003-02-26 |  |

| ID | WBS | Task | Type | Duration | Start | Finish | Predecessors | Baseline start | Baseline finish | Baseline duration | Total slack | Free slack | Constraint | Text1 | Text2 |
| --- | --- | --- | --- | --- | --- | --- | --- | --- | --- | --- | --- | --- | --- | --- | --- |
| 256 | 6.10.4 | **PFM Warm Electronics Integration** |  | 53d | 2004-10-04 | 2004-12-15 |  | 2004-03-01 | 2004-03-17 | 13d | 0d |  |  | RAL | PFM |
| 257 | 6.10.4.1 | PFM DPU Delivery to RAL | milestone | 0d | 2004-10-04 | 2004-10-04 |  | 2004-03-01 | 2004-03-01 | 0d | 40d | 0d | start no earlier than 2004-10-04 | IFSI | PFM |
| 258 | 6.10.4.2 | PFM DPU Acceptance |  | 3d | 2004-10-04 | 2004-10-06 | 257 | 2004-03-01 | 2004-03-03 | 3d | 40d | 0d |  | RAL | PFM |
| 259 | 6.10.4.3 | PFM DPU Verification |  | 1w | 2004-10-07 | 2004-10-13 | 258 | 2004-03-04 | 2004-03-10 | 1w | 40d |  |  | RAL | PFM |
| 260 | 6.10.4.4 | PFM DRCU Delivery to RAL | milestone | 0d | 2004-12-06 | 2004-12-06 |  | 2004-03-01 | 2004-03-01 | 0d | 0d |  | start no earlier than 2004-12-06 | SAp | PFM |
| 261 | 6.10.4.5 | PFM DRCU Acceptance |  | 3d | 2004-12-06 | 2004-12-08 | 260 | 2004-03-01 | 2004-03-03 | 3d | 0d |  |  | RAL | PFM |
| 262 | 6.10.4.6 | PFM WIH Delivery to RAL | milestone | 0d | 2004-11-01 | 2004-11-01 |  | 2004-03-01 | 2004-03-01 | 0d | 25d | 0d | start no earlier than 2004-11-01 | SAp | PFM |
| 263 | 6.10.4.7 | PFM WIH Acceptance |  | 3d | 2004-11-01 | 2004-11-03 | 262 | 2004-03-01 | 2004-03-03 | 3d | 25d |  |  | RAL | PFM |
| 264 | 6.10.4.8 | PFM DRCU Verification |  | 1w | 2004-12-09 | 2004-12-15 | 259, 261, 263 | 2004-03-11 | 2004-03-17 | 1w | 0d |  |  | RAL | PFM |
| 265 | 6.10.4.9 | PFM WE Available for PFM Calibration | milestone | 0d | 2004-12-15 | 2004-12-15 | 264 | 2004-03-17 | 2004-03-17 | 0d | 0d |  |  | RAL | PFM |
| 266 | 6.11 | **PFM Instrument Calibration** |  | 40d | 2004-12-16 | 2005-02-09 | 235, 256 | 2004-03-25 | 2004-05-27 | 46d | 0d |  |  |  | PFM |
| 267 | 6.11.1 | Integrate PFM WE into Test Facility |  | 2d | 2004-12-16 | 2004-12-17 |  | 2004-03-25 | 2004-03-26 | 2d | 0d |  |  | RAL | PFM |
| 268 | 6.11.2 | Cold Functional Tests III |  | 2d | 2004-12-20 | 2004-12-21 | 267 | 2004-03-29 | 2004-03-30 | 2d | 0d |  |  |  |  |
| 269 | 6.11.3 | Warm Electronics Thermal Range Tests |  | 5d | 2004-12-22 | 2004-12-28 | 268 | 2004-03-31 | 2004-04-06 | 5d | 0d |  |  |  | PFM |
| 270 | 6.11.4 | Calibration |  | 20d | 2004-12-29 | 2005-01-25 | 269, 265 | 2004-04-07 | 2004-05-18 | 30d | 0d |  |  |  | PFM |
| 271 | 6.11.5 | Cold Functional Test IV |  | 3d | 2005-01-26 | 2005-01-28 | 270 | 2004-05-19 | 2004-05-21 | 3d | 0d |  |  |  | PFM |
| 272 | 6.11.6 | Warm Up |  | 4d | 2005-01-31 | 2005-02-03 | 271 | 2004-05-24 | 2004-05-27 | 4d | 0d |  |  |  | PFM |
| 273 | 6.11.7 | Remove from test faciulity |  | 4d | 2005-02-04 | 2005-02-09 | 272 |  |  |  | 0d |  | start no earlier than 2003-06-05 |  |  |
| 274 | 6.12 | **PFM delivery preparation** |  | 42d | 2005-01-03 | 2005-03-01 |  |  |  |  | 0d |  |  |  |  |
| 275 | 6.12.1 | Mass properties Measurement |  | 3d | 2005-02-10 | 2005-02-14 | 273 |  |  |  | 0d |  | start no earlier than 2003-06-05 |  |  |
| 276 | 6.12.2 | Interface measurements |  | 4d | 2005-02-15 | 2005-02-18 | 275 |  |  |  | 0d |  | start no earlier than 2003-06-05 |  |  |
| 277 | 6.12.3 | Packing and shipment |  | 4d | 2005-02-21 | 2005-02-24 | 276 |  |  |  | 0d |  | start no earlier than 2003-06-05 |  |  |
| 278 | 6.12.4 | Preparation of Delivery Data Package |  | 29d | 2005-01-03 | 2005-02-10 |  |  |  |  | 13d |  | start no earlier than 2005-01-03 |  |  |
| 279 | 6.12.5 | CQM Delivery Readiness Review |  | 1d | 2005-02-25 | 2005-02-25 | 277 |  |  |  | 0d |  | start no earlier than 2003-06-05 |  |  |
| 280 | 6.12.6 | Ship to Alcatel |  | 2d | 2005-02-28 | 2005-03-01 | 279 |  |  |  | 0d |  | start no earlier than 2003-06-05 |  |  |
| 281 | 6.13 | Delivery of STM/CQM to ESA | milestone | 0d | 2005-03-01 | 2005-03-01 | 280, 278 |  |  |  | 0d |  | start no earlier than 2003-06-05 |  |  |
