# SPIRE

Schedule from MS Project, 1997-07-01 to 2007-04-01, A marks actual dates.
CLRC

## Calendars

- Standard: Mon-Fri 08:00-12:00, 13:00-17:00; Sat-Sun off. Exceptions (off unless hours are given): 2001-12-25 to 2002-01-04, 2002-12-25 to 2003-01-03, 2003-12-25 to 2004-01-02, 2004-12-27 to 2004-12-31, 2005-01-03 to 2005-01-07, 2005-12-26 to 2005-12-30, 2006-01-02 to 2006-01-06, 2006-12-25 to 2006-12-29, 2007-01-01 to 2007-01-05.

## Resources

| Resource |
| --- |
| Russell JW |
| Baillie TEC |
| Morrison GF |
| Laidlaw K |
| Atad E |
| AIV/Facility Eng |
| Fac. TECH |
| INSTRUMENT Scientist |
| TEST Scientist |
| Staff Years |
| UK Million Pounds |
| Cunningham CR |
| Pain I |
| Wright GS |
| Bennett RJ |
| Fisher M |
| MPIA |
| Bach H |
| Henry DM |
| Contract |
| Hannon F |
| Bon VC |
| CDL Systems |
| Paul TA |
| mssl |
| Wilson B |
| LAM |
| RAL |
| Control team |
| Industry |
| Mech Design Service |
| Workshop |
| Envir Test Service |
| 300K Vibrator |
| Cryostat |
| CryoVibrator |
| Dave Smith |
| Mark Harman |
| Contracts |
| OM |
| AIV Facility |
| QMW |
| TBD |
| Bruce Swinyard |
| Martin Caldwell |

## Schedule

| ID | WBS | Task | Type | Duration | Start | Finish | Predecessors | Remaining | Baseline start | Baseline finish | Baseline duration | Total slack | Free slack | Constraint |
| --- | --- | --- | --- | --- | --- | --- | --- | --- | --- | --- | --- | --- | --- | --- |
| 1 | 1 | **ESA Milestones** |  | 2422d | 1997-10-03 | 2007-04-01 |  |  | 1997-10-03 | 2007-04-01 | 2422d | 0d |  |  |
| 2 | 1.1 | Issue of AO | milestone | 0d | 1997-10-03 | 1997-10-03 |  |  | 1997-10-03 | 1997-10-03 | 0d | 0d |  | must start on 1997-10-03 |
| 3 | 1.2 | Payload Pre-selection | milestone | 0d | 1998-05-28 | 1998-05-28 |  |  | 1998-05-28 | 1998-05-28 | 0d | 0d |  | must finish on 1998-05-28 |
| 4 | 1.3 | Payload Selection | milestone | 0d | 1999-02-01 | 1999-02-01 |  |  | 1999-02-01 | 1999-02-01 | 0d | 0d |  | must finish on 1999-02-01 |
| 5 | 1.4 | ITT Release | milestone | 0d | 2000-10-01 | 2000-10-01 |  |  | 2000-10-01 | 2000-10-01 | 0d | 0d |  | must start on 2000-10-01 |
| 6 | 1.5 | Start of Phase B | milestone | 0d | 2001-07-01 | 2001-07-01 |  |  | 2001-07-01 | 2001-07-01 | 0d | 0d |  | must start on 2001-07-01 |
| 7 | 1.6 | Start of Phase C/D | milestone | 0d | 2002-06-01 | 2002-06-01 |  |  | 2002-06-01 | 2002-06-01 | 0d | 0d |  | must start on 2002-06-01 |
| 8 | 1.7 | AVM Delivery | milestone | 0d | 2003-04-01 | 2003-04-01 |  |  | 2003-04-01 | 2003-04-01 | 0d | 0d |  | must start on 2003-04-01 |
| 9 | 1.8 | CQM Delivery | milestone | 0d | 2003-04-01 | 2003-04-01 |  |  | 2003-04-01 | 2003-04-01 | 0d | 0d |  | must start on 2003-04-01 |
| 10 | 1.9 | PFM Delivery | milestone | 0d | 2004-07-01 | 2004-07-01 |  |  | 2004-07-01 | 2004-07-01 | 0d | 0d |  | must start on 2004-07-01 |
| 11 | 1.10 | FS Delivery | milestone | 0d | 2005-07-01 | 2005-07-01 |  |  | 2005-07-01 | 2005-07-01 | 0d | 0d |  | must start on 2005-07-01 |
| 12 | 1.11 | Launch | milestone | 0d | 2007-04-01 | 2007-04-01 |  |  | 2007-04-01 | 2007-04-01 | 0d | 0d |  | must start on 2007-04-01 |
| 13 | 2 | **Instrument Development** |  | 1184d | 1998-05-29 A | 2002-12-24 |  | 1181.76d | 1998-05-29 | 2001-03-23 | 736d | 1068d |  |  |
| 14 | 2.1 | **Design** |  | 936d | 1998-05-29 A | 2002-01-10 |  | 933.97d | 1998-05-29 | 2001-03-23 | 736d | 1316d |  |  |
| 15 | 2.1.1 | **System Design** |  | 335d | 1998-05-29 | 1999-09-09 |  |  | 1998-05-29 | 1999-09-09 | 335d | 8d |  |  |
| 16 | 2.1.1.1 | **Scientific Requirements** |  | 272d | 1998-05-29 | 1999-06-15 |  |  | 1998-05-29 | 1999-06-15 | 272d | 0d |  |  |
| 17 | 2.1.1.1.1 | SRD First Draft |  | 26w | 1998-05-29 | 1998-11-26 | 3 |  | 1998-05-29 | 1998-11-26 | 26w | 22d | 0d |  |
| 18 | 2.1.1.1.2 | SRD Second Draft |  | 12w | 1998-11-27 | 1999-02-18 | 17 |  | 1998-11-27 | 1999-02-18 | 12w | 22d | 0d |  |
| 19 | 2.1.1.1.3 | SRD Issue 1 |  | 12w | 1999-02-19 | 1999-05-13 | 18 |  | 1999-02-19 | 1999-05-13 | 12w | 22d |  |  |
| 20 | 2.1.1.1.4 | SRD Issue 1 released | milestone | 0d | 1999-06-15 | 1999-06-15 | 19 |  | 1999-06-15 | 1999-06-15 | 0d | 0d |  | must start on 1999-06-15 |
| 21 | 2.1.1.2 | **Engineering Requirements** |  | 255d | 1998-05-29 | 1999-05-20 |  |  | 1998-05-29 | 1999-05-20 | 255d | 8d |  |  |
| 22 | 2.1.1.2.1 | System Design |  | 40w | 1998-05-29 | 1999-03-04 | 3 |  | 1998-05-29 | 1999-03-04 | 40w | 8d | 0d |  |
| 23 | 2.1.1.2.2 | Budgets Specification |  | 3w | 1999-03-05 | 1999-03-25 | 22 |  | 1999-03-05 | 1999-03-25 | 3w | 18d | 0d |  |
| 24 | 2.1.1.2.3 | IRD First Draft |  | 4w | 1999-03-26 | 1999-04-22 | 23, 18 |  | 1999-03-26 | 1999-04-22 | 4w | 18d | 0d |  |
| 25 | 2.1.1.2.4 | IRD Issue 1 |  | 4w | 1999-04-23 | 1999-05-20 | 24 |  | 1999-04-23 | 1999-05-20 | 4w | 33d | 0d |  |
| 26 | 2.1.1.2.5 | IRD Issue1 released | milestone | 0d | 1999-05-20 | 1999-05-20 | 25 |  | 1999-05-20 | 1999-05-20 | 0d | 33d | 0d |  |

| ID | WBS | Task | Type | Duration | Start | Finish | Predecessors | Complete | Baseline start | Baseline finish | Baseline duration | Total slack | Free slack | Constraint |
| --- | --- | --- | --- | --- | --- | --- | --- | --- | --- | --- | --- | --- | --- | --- |
| 27 | 2.1.1.3 | **Verification Requirements** |  | 15d | 1999-04-23 | 1999-05-13 |  |  | 1999-04-23 | 1999-05-13 | 15d | 18d |  |  |
| 28 | 2.1.1.3.1 | VRD Issue 1 |  | 3w | 1999-04-23 | 1999-05-13 | 24 |  | 1999-04-23 | 1999-05-13 | 3w | 18d | 0d |  |
| 29 | 2.1.1.3.2 | VRD Issue 1 released | milestone | 0d | 1999-05-13 | 1999-05-13 | 28 |  | 1999-05-13 | 1999-05-13 | 0d | 18d | 10d |  |
| 30 | 2.1.1.4 | **AIV Plan** |  | 310d | 1998-05-29 | 1999-08-05 |  |  | 1998-05-29 | 1999-08-05 | 310d | 168d |  |  |
| 31 | 2.1.1.4.1 | AIV Plan First Draft |  | 20w | 1998-05-29 | 1998-10-15 | 3 |  | 1998-05-29 | 1998-10-15 | 20w | 168d | 160d |  |
| 32 | 2.1.1.4.2 | AIV Plan Issue 1 |  | 3w | 1999-07-16 | 1999-08-05 | 31, 28, 41FS-4w |  | 1999-07-16 | 1999-08-05 | 3w | 1922d | 0d |  |
| 33 | 2.1.1.4.3 | AIV Plan Issue 1 released | milestone | 0d | 1999-08-05 | 1999-08-05 | 32 |  | 1999-08-05 | 1999-08-05 | 0d | 1922d | 5d |  |
| 34 | 2.1.1.5 | **Instrument Development Plan** |  | 175d | 1999-01-08 | 1999-09-09 |  |  | 1999-01-08 | 1999-09-09 | 175d | 8d |  |  |
| 35 | 2.1.1.5.1 | FPU Preliminary Design |  | 12w | 1999-01-08 | 1999-04-01 | 22FS-8w |  | 1999-01-08 | 1999-04-01 | 12w | 8d | 0d |  |
| 36 | 2.1.1.5.2 | Qualification Plans |  | 4w | 1999-04-02 | 1999-04-29 | 35 |  | 1999-04-02 | 1999-04-29 | 4w | 8d | 0d |  |
| 37 | 2.1.1.5.3 | Subsystem development plans |  | 4w | 1999-04-02 | 1999-04-29 | 35 |  | 1999-04-02 | 1999-04-29 | 4w | 8d | 0d |  |
| 38 | 2.1.1.5.4 | IDP First Draft |  | 4w | 1999-04-30 | 1999-05-27 | 37, 36 |  | 1999-04-30 | 1999-05-27 | 4w | 8d | 0d |  |
| 39 | 2.1.1.5.5 | IDP Issue 1 |  | 4w | 1999-05-28 | 1999-06-24 | 38, 29, 31 |  | 1999-05-28 | 1999-06-24 | 4w | 8d | 0d |  |
| 40 | 2.1.1.5.6 | IDP Issue 1 released | milestone | 0d | 1999-06-24 | 1999-06-24 | 39 |  | 1999-06-24 | 1999-06-24 | 0d | 8d |  |  |
| 41 | 2.1.1.5.7 | WE Preliminary design |  | 12w | 1999-05-21 | 1999-08-12 | 26 |  | 1999-05-21 | 1999-08-12 | 12w | 1917d | 0d |  |
| 42 | 2.1.1.5.8 | IDP Issue 2 |  | 4w | 1999-08-13 | 1999-09-09 | 41, 33 |  | 1999-08-13 | 1999-09-09 | 4w | 1917d | 0d |  |
| 43 | 2.1.1.5.9 | IDP Issue 2 released | milestone | 0d | 1999-09-09 | 1999-09-09 | 42 |  | 1999-09-09 | 1999-09-09 | 0d | 1917d |  |  |
| 44 | 2.1.1.6 | **Interface Control** |  | 115d | 1999-04-02 | 1999-09-09 |  |  | 1999-04-02 | 1999-09-09 | 115d | 8d |  |  |
| 45 | 2.1.1.6.1 | ICP First Draft |  | 8w | 1999-04-02 | 1999-05-27 | 35 |  | 1999-04-02 | 1999-05-27 | 8w | 8d | 0d |  |
| 46 | 2.1.1.6.2 | ICP Issue 1 |  | 4w | 1999-05-28 | 1999-06-24 | 45 |  | 1999-05-28 | 1999-06-24 | 4w | 8d | 0d |  |
| 47 | 2.1.1.6.3 | ICP Issue 1 released | milestone | 0d | 1999-06-24 | 1999-06-24 | 46 |  | 1999-06-24 | 1999-06-24 | 0d | 8d |  |  |
| 48 | 2.1.1.6.4 | ICP Issue 2 |  | 4w | 1999-08-13 | 1999-09-09 | 47, 41 |  | 1999-08-13 | 1999-09-09 | 4w | 1917d | 0d |  |
| 49 | 2.1.1.6.5 | ICP Issue 2 released | milestone | 0d | 1999-09-09 | 1999-09-09 | 48 |  | 1999-09-09 | 1999-09-09 | 0d | 1917d |  |  |
| 50 | 2.1.2 | Preliminary Design Review (Cold FPU) | milestone | 3d | 1999-07-07 | 1999-07-09 | 26, 20, 40, 47 |  | 1999-07-07 | 1999-07-09 | 3d | 0d |  | must start on 1999-07-07 |
| 51 | 2.1.3 | Warm Electronics Review | milestone | 2d | 1999-12-06 A | 1999-12-07 A | 43, 49 | 100% | 1999-12-06 | 1999-12-07 | 2d |  |  | start no earlier than 1999-12-06 |

| ID | WBS | Task | Type | Duration | Start | Finish | Predecessors | Complete | Baseline start | Baseline finish | Baseline duration | Total slack | Free slack | Constraint |
| --- | --- | --- | --- | --- | --- | --- | --- | --- | --- | --- | --- | --- | --- | --- |
| 52 | 2.1.4 | **Detector Array Development** |  | 425d | 1998-05-29 | 2000-01-13 |  |  | 1998-05-29 | 2000-01-13 | 425d | 1827d |  |  |
| 53 | 2.1.4.1 | PUD Array Development |  | 65w | 1998-05-29 | 1999-08-26 | 3 |  | 1998-05-29 | 1999-08-26 | 65w | 1827d | 0d |  |
| 54 | 2.1.4.2 | Delivery of Evaluation PUD Array to QMW | milestone | 0d | 1999-08-26 | 1999-08-26 | 53 |  | 1999-08-26 | 1999-08-26 | 0d | 1827d | 0d |  |
| 55 | 2.1.4.3 | Feedhorn Array Development |  | 65w | 1998-05-29 | 1999-08-26 | 3 |  | 1998-05-29 | 1999-08-26 | 65w | 1827d | 0d |  |
| 56 | 2.1.4.4 | Delivery of Evaluation Feedhorn Array to QMW | milestone | 0d | 1999-08-26 | 1999-08-26 | 55 |  | 1999-08-26 | 1999-08-26 | 0d | 1827d | 0d |  |
| 57 | 2.1.4.5 | **CEA Evaluation Array Development** |  | 325d | 1998-05-29 | 1999-08-26 |  |  | 1998-05-29 | 1999-08-26 | 325d | 1827d |  |  |
| 58 | 2.1.4.5.1 | CEA 1st Evaluation Detector Manufacture |  | 40w | 1998-05-29 | 1999-03-04 | 3 |  | 1998-05-29 | 1999-03-04 | 40w | 1827d | 0d |  |
| 59 | 2.1.4.5.2 | CEA 1st Evaluation Detector Delivery to QMW | milestone | 0d | 1999-03-04 | 1999-03-04 | 58 |  | 1999-03-04 | 1999-03-04 | 0d | 1827d | 0d |  |
| 60 | 2.1.4.5.3 | CEA 2nd Evaluation Array Manufacture |  | 13w | 1999-03-05 | 1999-06-03 | 59 |  | 1999-03-05 | 1999-06-03 | 13w | 1827d | 0d |  |
| 61 | 2.1.4.5.4 | CEA 2nd Evaluation Array Delivery to QMW | milestone | 0d | 1999-06-03 | 1999-06-03 | 60 |  | 1999-06-03 | 1999-06-03 | 0d | 1827d | 0d |  |
| 62 | 2.1.4.5.5 | CEA 3rd Evaluation Array Manufacture |  | 12w | 1999-06-04 | 1999-08-26 | 61 |  | 1999-06-04 | 1999-08-26 | 12w | 1827d | 0d |  |
| 63 | 2.1.4.6 | CEA Evaluation Array Delivery to QMW | milestone | 0d | 1999-08-26 | 1999-08-26 | 62 |  | 1999-08-26 | 1999-08-26 | 0d | 1827d | 0d |  |
| 64 | 2.1.4.7 | **Evaluation Facility** |  | 425d | 1998-05-29 | 2000-01-13 |  |  | 1998-05-29 | 2000-01-13 | 425d | 1827d |  |  |
| 65 | 2.1.4.7.1 | Evaluation Facility Development |  | 35w | 1998-05-29 | 1999-01-28 | 3 |  | 1998-05-29 | 1999-01-28 | 35w | 1897d | 0d |  |
| 66 | 2.1.4.7.2 | Characterise Cryogenics |  | 10w | 1999-01-29 | 1999-04-08 | 65 |  | 1999-01-29 | 1999-04-08 | 10w | 1897d | 0d |  |
| 67 | 2.1.4.7.3 | Integrate and Test BACUS |  | 6w | 1999-04-09 | 1999-05-20 | 66 |  | 1999-04-09 | 1999-05-20 | 6w | 1897d | 70d |  |
| 68 | 2.1.4.7.4 | Array Evaluation |  | 20w | 1999-08-27 | 2000-01-13 | 54, 56, 67, 63 |  | 1999-08-27 | 2000-01-13 | 20w | 1827d |  |  |
| 69 | 2.1.5 | Detector Array Selection | milestone | 1d | 2000-01-31 A | 2000-01-31 A | 68FS+2w | 100% | 2000-01-31 | 2000-01-31 | 1d |  |  | start no earlier than 2000-01-31 |
| 70 | 2.1.6 | Preliminary Design Review (Delta) | milestone | 1d | 2000-06-26 A | 2000-06-26 A | 69, 51, 50 | 100% | 2000-06-26 | 2000-06-26 | 1d |  |  | start no earlier than 2000-06-26 |
| 71 | 2.1.7 | Interface Definition |  | 20w | 2000-06-27 | 2000-11-13 | 70 |  | 2000-06-27 | 2000-11-13 | 20w | 1610d |  |  |
| 72 | 2.1.8 | Instrument Interface Review | milestone | 2d | 2000-11-28 A | 2000-11-29 A | 70, 71 | 100% | 2000-11-28 | 2000-11-29 | 2d |  |  | start no earlier than 2000-11-28 |
| 73 | 2.1.9 | Detailed Design |  | 52w | 2000-11-30 | 2001-11-28 | 72 |  | 2000-11-30 | 2001-02-21 | 12w | 35d | 0d |  |
| 74 | 2.1.10 | Detailed Design Review |  | 26w | 2001-05-31 | 2001-11-28 | 73FS-26w |  | 2001-03-22 | 2001-03-23 | 2d | 35d | 0d |  |
| 75 | 2.1.11 | Instrument Baseline Design Review | milestone | 2d | 2002-01-09 | 2002-01-10 | 74FS+4w |  |  |  |  | 35d |  | finish no later than 2002-02-28 |
| 76 | 2.2 | Subsystem Manufacturing and Test |  | 80w | 2001-05-31 | 2002-12-24 | 74SS |  |  |  |  | 1068d |  |  |

| ID | WBS | Task | Type | Duration | Start | Finish | Predecessors | Baseline start | Baseline finish | Baseline duration | Total slack | Free slack | Text2 | Text1 |
| --- | --- | --- | --- | --- | --- | --- | --- | --- | --- | --- | --- | --- | --- | --- |
| 77 | 3 | **AIV** |  | 887d | 2002-06-01 | 2005-11-29 |  | 1997-07-01 | 2005-09-29 | 2119d? | 75d |  |  |  |
| 78 | 3.1 | **Avionics Model** |  | 237d | 2002-06-01 | 2003-05-09 |  | 2002-06-01 | 2003-05-12 | 237.5d | 15d |  | AVM |  |
| 79 | 3.1.1 | **Preliminary Integration** |  | 63d | 2002-06-01 | 2002-08-28 |  | 2002-06-01 | 2002-08-28 | 63d | 142d | 127d | AVM | RAL |
| 80 | 3.1.1.1 | AVM DPU Delivery to RAL | milestone | 0d | 2002-06-01 | 2002-06-01 | 560 | 2002-06-01 | 2002-06-01 | 0d | 142d | 0d | AVM | IFSI |
| 81 | 3.1.1.2 | AVM DPU Acceptance |  | 3d | 2002-06-03 | 2002-06-05 | 80 | 2002-06-03 | 2002-06-05 | 3d | 142d | 0d | AVM | RAL |
| 82 | 3.1.1.3 | DRCU Simulator#2 Delivery to RAL | milestone | 0d | 2002-06-01 | 2002-06-01 | 561 | 2002-06-01 | 2002-06-01 | 0d | 142d | 0d | AVM | SO |
| 83 | 3.1.1.4 | DRCU Simulator#2 Acceptance |  | 3d | 2002-06-03 | 2002-06-05 | 82 | 2002-06-03 | 2002-06-05 | 3d | 142d | 0d | AVM | RAL |
| 84 | 3.1.1.5 | EGSE#2 Available | milestone | 0d | 2002-06-01 | 2002-06-01 | 562 | 2002-08-01 | 2002-08-01 | 0d | 145d | 3d | AVM | RAL |
| 85 | 3.1.1.6 | DPU Verification |  | 12w | 2002-06-06 | 2002-08-28 | 81, 84, 83 | 2002-08-01 | 2002-08-28 | 4w | 142d | 0d | AVM | RAL |
| 86 | 3.1.1.7 | AVM DPU Available for CQM Testing | milestone | 0d | 2002-08-28 | 2002-08-28 | 85 | 2002-08-28 | 2002-08-28 | 0d | 142d |  | AVM | RAL |
| 87 | 3.1.2 | **AVM Verification** |  | 63d | 2003-02-01 | 2003-04-30 |  | 2003-01-01 | 2003-05-01 | 83.5d | 15d |  | AVM | RAL |
| 88 | 3.1.2.1 | AVM DPU Available for Delivery | milestone | 0d | 2003-04-16 | 2003-04-16 | 289 | 2003-04-17 | 2003-04-17 | 0d | 15d | 0d | AVM | RAL |
| 89 | 3.1.2.2 | EGSE#4 Available for Delivery | milestone | 0w | 2003-02-01 | 2003-02-01 | 575 | 2003-04-17 | 2003-04-17 | 0w | 68d | 20d |  |  |
| 90 | 3.1.2.3 | DRCU Simulator#3 Delivery to RAL | milestone | 0d | 2003-02-01 | 2003-02-01 | 576 | 2003-01-01 | 2003-01-01 | 0d | 68d | 20d | AVM | SO |
| 91 | 3.1.2.4 | AVM Verification |  | 2w | 2003-04-17 | 2003-04-30 | 90, 88, 89 | 2003-04-17 | 2003-05-01 | 2w | 15d | 0d | AVM | RAL |
| 92 | 3.1.3 | **Delivery** |  | 17d | 2003-04-17 | 2003-05-09 |  | 2003-04-17 | 2003-05-12 | 17d | 15d |  | AVM | RAL |
| 93 | 3.1.3.1 | Preparation of Delivery Data Package |  | 2w | 2003-04-17 | 2003-04-30 | 91FF | 2003-04-17 | 2003-05-01 | 2w | 15d | 0d | AVM | RAL |
| 94 | 3.1.3.2 | AVM Readiness Review | milestone | 2d | 2003-05-01 | 2003-05-02 | 93, 91 | 2003-05-01 | 2003-05-05 | 2d | 15d | 0d | AVM | RAL |
| 95 | 3.1.3.3 | Pack and Ship to ESA |  | 1w | 2003-05-05 | 2003-05-09 | 94 | 2003-05-05 | 2003-05-12 | 1w | 15d | 0d | AVM | RAL |
| 96 | 3.1.4 | AVM Delivery to ESA | milestone | 0d | 2003-05-09 | 2003-05-09 | 95 | 2003-05-12 | 2003-05-12 | 0d | 15d |  | AVM | RAL |
| 97 | 3.2 | **Structural Thermal Model** |  | 212d | 2002-07-01 | 2003-05-02 |  | 2002-04-01 | 2003-02-10 | 218d? | 1d |  | STM |  |
| 98 | 3.2.1 | **STM FPU Subsystem deliveries** |  | 57d | 2002-07-01 | 2002-09-17 |  | 2002-04-01 | 2002-07-03 | 68d? | 55d |  | STM |  |
| 99 | 3.2.1.1 | CQM Structure and MGSE Delivery | milestone | 0d | 2002-08-13 | 2002-08-13 | 522 | 2002-07-01 | 2002-07-01 | 0d | 24d | 0d | STM | MSSL |
| 100 | 3.2.1.2 | CQM Structure Acceptance |  | 3d | 2002-08-13 | 2002-08-15 | 99 | 2002-07-01 | 2002-07-03 | 3d | 24d | 0d | STM | RAL |
| 101 | 3.2.1.3 | CQM Thermal Straps Delivery | milestone | 0d | 2002-09-13 | 2002-09-13 | 523 | 2002-07-01 | 2002-07-01 | 0d | 1d | 0d | STM | MSSL |
| 102 | 3.2.1.4 | CQM Thermal Straps Acceptance |  | 3d | 2002-09-13 | 2002-09-17 | 101 | 2002-07-01 | 2002-07-03 | 3d | 1d | 0d | STM | RAL |
| 103 | 3.2.1.5 | CQM Mirrors and OGSE Delivery | milestone | 0d | 2002-07-01 | 2002-07-01 | 524 | 2002-07-01 | 2002-07-01 | 0d | 55d | 0d | STM | LAM |
| 104 | 3.2.1.6 | CQM Mirrors Acceptance |  | 3d | 2002-07-01 | 2002-07-03 | 103 | 2002-07-01 | 2002-07-03 | 3d | 55d | 0d | STM | RAL |
| 105 | 3.2.1.7 | STM Filters, Dichroics, Beamsplitters and OGSE Delivery | milestone | 0d | 2002-07-01 | 2002-07-01 | 525 | 2002-07-01 | 2002-07-01 | 0d | 55d | 0d | STM | QMW |
| 106 | 3.2.1.8 | STM Filters, Dichroics, Beamsplitters Acceptance |  | 3d | 2002-07-01 | 2002-07-03 | 105 | 2002-07-01 | 2002-07-03 | 3d | 55d | 0d | STM | RAL |
| 107 | 3.2.1.9 | STM BSMm Delivery | milestone | 0d | 2002-07-01 | 2002-07-01 | 526 | 2002-07-01 | 2002-07-01 | 0d | 66d | 0d | STM | ATC |
| 108 | 3.2.1.10 | STM BSMm Acceptance |  | 3d | 2002-07-01 | 2002-07-03 | 107 | 2002-07-01 | 2002-07-03 | 3d | 66d | 11d | STM | RAL |
| 109 | 3.2.1.11 | CQM BSM Harness Delivery | milestone | 0d | 2002-07-01 | 2002-07-01 | 527 |  |  |  | 100.5d | 0d | STM | ATC |
| 110 | 3.2.1.12 | CQM BSM Harness Acceptance |  | 1d | 2002-07-01 | 2002-07-01 | 109 |  |  |  | 100.5d | 45.5d | STM | RAL |
| 111 | 3.2.1.13 | Optical Dummy SMECm Delivery | milestone | 0d | 2002-07-01 | 2002-07-01 | 528 | 2002-07-01 | 2002-07-01 | 0d | 66d | 0d | STM | LAM |
| 112 | 3.2.1.14 | Optical Dummy SMECm Acceptance |  | 3d | 2002-07-01 | 2002-07-03 | 111 | 2002-07-01 | 2002-07-03 | 3d | 66d | 11d | STM | RAL |
| 113 | 3.2.1.15 | FOB SImulatorDelivery | milestone | 0d | 2002-07-01 | 2002-07-01 | 529 | 2002-07-01 | 2002-07-01 | 0d | 69d | 14d | STM | RAL |
| 114 | 3.2.1.16 | STM Cooler Delivery | milestone | 0d | 2002-08-01 | 2002-08-01 | 530 | 2002-07-01 | 2002-07-01 | 0d | 75.5d | 0d | STM | Genoble |
| 115 | 3.2.1.17 | STM Cooler Acceptance |  | 3d | 2002-08-01 | 2002-08-05 | 114 | 2002-07-01 | 2002-07-03 | 3d | 75.5d | 20.5d | STM | RAL |
| 116 | 3.2.1.18 | CQM Cooler Harness Delivery | milestone | 0d | 2002-08-01 | 2002-08-01 | 531 |  |  |  | 77.5d | 0d | STM | Grenoble |
| 117 | 3.2.1.19 | CQM Cooler Harness Acceptance |  | 1d | 2002-08-01 | 2002-08-01 | 116 |  |  |  | 77.5d | 22.5d | STM | RAL |
| 118 | 3.2.1.20 | STM BDAs Delivery | milestone | 0d | 2002-08-01 | 2002-08-01 | 532 | 2002-04-01 | 2002-04-01 | 0d | 75.5d | 0d | STM | JPL |
| 119 | 3.2.1.21 | STM BDAs Acceptance |  | 3d | 2002-08-01 | 2002-08-05 | 118 | 2002-04-01 | 2002-04-03 | 3d | 75.5d | 20.5d | STM | RAL |
| 120 | 3.2.1.22 | CQM BDAs Harness Delivery | milestone | 0d | 2002-08-01 | 2002-08-01 | 533 |  |  |  | 77.5d | 0d | STM | JPL |
| 121 | 3.2.1.23 | CQM BDAs Harness Acceptance |  | 1d | 2002-08-01 | 2002-08-01 | 120 |  |  |  | 77.5d | 22.5d | STM | RAL |
| 122 | 3.2.1.24 | STM Shutter Delivery | milestone | 0d | 2002-08-01 | 2002-08-01 | 534 | 2002-04-10 | 2002-04-10 | 0d | 75.5d | 0d | STM | USK |
| 123 | 3.2.1.25 | STM Shutter Acceptance |  | 3d | 2002-08-01 | 2002-08-05 | 122 | 2002-04-10 | 2002-04-12 | 3d | 75.5d | 20.5d | STM | RAL |
| 124 | 3.2.1.26 | CQM Shutter Harness Delivery | milestone | 0d | 2002-08-01 | 2002-08-01 | 535 |  |  |  | 77.5d | 0d | STM | USK |
| 125 | 3.2.1.27 | CQM Shutter Harness Acceptance |  | 1d | 2002-08-01 | 2002-08-01 | 124 |  |  |  | 77.5d | 22.5d | STM | RAL |
| 126 | 3.2.1.28 | STM SCAL Delivery | milestone | 0d | 2002-08-01 | 2002-08-01 | 536 | 2002-04-10 | 2002-04-10 | 0d | 75.5d | 0d | STM | QMW |
| 127 | 3.2.1.29 | STM SCAL Acceptance |  | 3d | 2002-08-01 | 2002-08-05 | 126 | 2002-04-10 | 2002-04-12 | 3d | 75.5d | 20.5d | STM | RAL |
| 128 | 3.2.1.30 | STM SCAL Harness Delivery | milestone | 0d | 2002-08-01 | 2002-08-01 | 537 |  |  |  | 77.5d | 0d | STM | QMW |
| 129 | 3.2.1.31 | STM SCAL Harness Acceptance |  | 1d | 2002-08-01 | 2002-08-01 | 128 |  |  |  | 77.5d | 22.5d | STM | RAL |
| 130 | 3.2.1.32 | STM SMECm Delivery | milestone | 0d | 2002-08-01 | 2002-08-01 | 538 | 2002-07-01 | 2002-07-01 | 0d | 75.5d | 0d | STM | LAM |
| 131 | 3.2.1.33 | STM SMECm Acceptance |  | 3d | 2002-08-01 | 2002-08-05 | 130 | 2002-07-01 | 2002-07-01 | 1d? | 75.5d | 20.5d | STM | RAL |
| 132 | 3.2.1.34 | STM SMECm Harness Delivery | milestone | 0d | 2002-08-01 | 2002-08-01 | 539 |  |  |  | 77.5d | 0d | STM | LAM |
| 133 | 3.2.1.35 | STM SMECm Harness Acceptance |  | 1d | 2002-08-01 | 2002-08-01 | 132 |  |  |  | 77.5d | 22.5d | STM | RAL |
| 134 | 3.2.1.36 | CQM FPU RF Filter Modules Delivery | milestone | 0d | 2002-08-01 | 2002-08-01 | 540 | 2002-07-01 | 2002-07-01 | 0d | 75.5d | 0d | STM | JPL |
| 135 | 3.2.1.37 | CQM FPU RF Filter Modules Acceptance |  | 3d | 2002-08-01 | 2002-08-05 | 134 | 2002-07-01 | 2002-07-03 | 3d | 75.5d | 20.5d | STM | RAL |
| 136 | 3.2.1.38 | CQM Cooler Delivery | milestone | 0d | 2002-09-01 | 2002-09-01 | 541 | 2002-07-01 | 2002-07-01 | 0d | 80.5d | 0d | STM | Grenoble |
| 137 | 3.2.1.39 | CQM Cooler Acceptance |  | 3d | 2002-09-02 | 2002-09-04 | 136 | 2002-07-01 | 2002-07-03 | 3d | 80.5d | 25.5d | STM | RAL |

| ID | WBS | Task | Type | Duration | Start | Finish | Predecessors | Baseline start | Baseline finish | Baseline duration | Total slack | Free slack | Text1 | Text2 |
| --- | --- | --- | --- | --- | --- | --- | --- | --- | --- | --- | --- | --- | --- | --- |
| 138 | 3.2.2 | **STM FPU Alignment** |  | 77.5d | 2002-08-01 | 2002-11-18 |  | 2002-07-04 | 2002-09-03 | 43.5d | 1d | 0d | RAL | STM |
| 139 | 3.2.2.1 | **3-D Metrology** |  | 11d | 2002-09-18 | 2002-10-02 | 100, 102, 104, 106 | 2002-07-04 | 2002-07-18 | 11d | 1d | 0d | RAL | STM |
| 140 | 3.2.2.1.1 | Preparation |  | 2d | 2002-09-18 | 2002-09-19 |  | 2002-07-04 | 2002-07-05 | 2d | 1d | 0d | RAL | STM |
| 141 | 3.2.2.1.2 | Fit OGSE into Detector Boxes |  | 1d | 2002-09-20 | 2002-09-20 | 140 | 2002-07-08 | 2002-07-08 | 1d | 1d | 0d | RAL | STM |
| 142 | 3.2.2.1.3 | Fit and Align Detector Mirrors and Dichroic Mounts |  | 2d | 2002-09-23 | 2002-09-24 | 141 | 2002-07-09 | 2002-07-10 | 2d | 1d | 0d | RAL | STM |
| 143 | 3.2.2.1.4 | Fit Detector Boxes into Structure |  | 1d | 2002-09-25 | 2002-09-25 | 142 | 2002-07-11 | 2002-07-11 | 1d | 1d | 0d | RAL | STM |
| 144 | 3.2.2.1.5 | Partial Structure moved to Metrology Araea |  | 0.5d | 2002-09-26 | 2002-09-26 | 143 | 2002-07-12 | 2002-07-12 | 0.5d | 1d | 0d | RAL | STM |
| 145 | 3.2.2.1.6 | 3-D Metrology |  | 4d | 2002-09-26 | 2002-10-02 | 144 | 2002-07-12 | 2002-07-18 | 4d | 1d | 0d | RAL | STM |
| 146 | 3.2.2.1.7 | Partial Structure returned to Intgration Area |  | 0.5d | 2002-10-02 | 2002-10-02 | 145 | 2002-07-18 | 2002-07-18 | 0.5d | 1d |  | RAL | STM |
| 147 | 3.2.2.2 | **Alignment during Integration** |  | 20d | 2002-10-03 | 2002-10-30 | 139, 113, 108, 112 | 2002-07-19 | 2002-08-15 | 20d | 1d | 0d | RAL | STM |
| 148 | 3.2.2.2.1 | Mount Structure into MGSE and fit OGSE |  | 2d | 2002-10-03 | 2002-10-04 |  | 2002-07-19 | 2002-07-22 | 2d | 1d | 0d | RAL | STM |
| 149 | 3.2.2.2.2 | Fit and Align Mirrors |  | 10d | 2002-10-07 | 2002-10-18 | 148 | 2002-07-23 | 2002-08-05 | 10d | 1d | 0d | RAL | STM |
| 150 | 3.2.2.2.3 | External Alignment verification |  | 1d | 2002-10-21 | 2002-10-21 | 149 | 2002-08-06 | 2002-08-06 | 1d | 1d | 0d | RAL | STM |
| 151 | 3.2.2.2.4 | Pupil Quality Verification |  | 1d | 2002-10-22 | 2002-10-22 | 150 | 2002-08-07 | 2002-08-07 | 1d | 1d | 0d | RAL | STM |
| 152 | 3.2.2.2.5 | Image Quality Verification |  | 1d | 2002-10-23 | 2002-10-23 | 151 | 2002-08-08 | 2002-08-08 | 1d | 1d | 0d | RAL | STM |
| 153 | 3.2.2.2.6 | Fit Covers and Mount on FOB Simulator |  | 2d | 2002-10-24 | 2002-10-25 | 152 | 2002-08-09 | 2002-08-12 | 2d | 1d | 0d | RAL | STM |
| 154 | 3.2.2.2.7 | Alignment of SOR wrt FOR |  | 1d | 2002-10-28 | 2002-10-28 | 153 | 2002-08-13 | 2002-08-13 | 1d | 1d | 0d | RAL | STM |
| 155 | 3.2.2.2.8 | Verify Image Quality and Stability |  | 2d | 2002-10-29 | 2002-10-30 | 154 | 2002-08-14 | 2002-08-15 | 2d | 1d |  | RAL | STM |
| 156 | 3.2.2.3 | Test Cryostat Commissioned | milestone | 0d | 2002-08-01 | 2002-08-01 | 569 |  |  |  | 66d | 11d |  |  |
| 157 | 3.2.2.4 | **Cold Alignment Verification** |  | 12.5d | 2002-10-31 | 2002-11-18 | 147, 156 | 2002-08-16 | 2002-09-03 | 12.5d | 1d |  | RAL | STM |
| 158 | 3.2.2.4.1 | Instrument Preparation and Transport to Cryolab |  | 0.5d | 2002-10-31 | 2002-10-31 |  | 2002-08-16 | 2002-08-16 | 0.5d | 1d | 0d | RAL | STM |
| 159 | 3.2.2.4.2 | Integrate Instrument into Cryostat |  | 1.5d | 2002-10-31 | 2002-11-01 | 158 | 2002-08-16 | 2002-08-19 | 1.5d | 1d | 0d | RAL | STM |
| 160 | 3.2.2.4.3 | Pump down |  | 1d | 2002-11-04 | 2002-11-04 | 159 | 2002-08-20 | 2002-08-20 | 1d | 1d | 0d | RAL | STM |
| 161 | 3.2.2.4.4 | Cooldown |  | 2d | 2002-11-05 | 2002-11-06 | 160 | 2002-08-21 | 2002-08-22 | 2d | 1d | 0d | RAL | STM |
| 162 | 3.2.2.4.5 | Cold Alignment Verification |  | 3d | 2002-11-07 | 2002-11-11 | 161 | 2002-08-23 | 2002-08-27 | 3d | 1d | 0d | RAL | STM |
| 163 | 3.2.2.4.6 | Warm up and let up to ambient pressure |  | 3d | 2002-11-12 | 2002-11-14 | 162 | 2002-08-28 | 2002-08-30 | 3d | 1d | 0d | RAL | STM |
| 164 | 3.2.2.4.7 | De-integrate Instrument from Cryostat and return to Integration Area |  | 1.5d | 2002-11-15 | 2002-11-18 | 163 | 2002-09-02 | 2002-09-03 | 1.5d | 1d |  | RAL | STM |

| ID | WBS | Task | Type | Duration | Start | Finish | Predecessors | Baseline start | Baseline finish | Baseline duration | Total slack | Free slack | Text1 | Text2 |
| --- | --- | --- | --- | --- | --- | --- | --- | --- | --- | --- | --- | --- | --- | --- |
| 165 | 3.2.3 | **STM FTB Integration** |  | 4d | 2002-08-01 | 2002-08-06 |  | 2002-04-01 | 2002-04-04 | 4d | 74.5d | 19.5d | RAL | STM |
| 166 | 3.2.3.1 | **STM FTB Subsystem Deliveries** |  | 0d | 2002-08-01 | 2002-08-01 |  | 2002-04-01 | 2002-04-01 | 0d | 74.5d |  | RAL | STM |
| 167 | 3.2.3.1.1 | CQM FTB Enclosure Delivery | milestone | 0d | 2002-08-01 | 2002-08-01 | 542 | 2002-04-01 | 2002-04-01 | 0d | 74.5d | 0d | MSSL | STM |
| 168 | 3.2.3.1.2 | STM JFET Modules Delivery | milestone | 0d | 2002-08-01 | 2002-08-01 | 543 | 2002-04-01 | 2002-04-01 | 0d | 74.5d | 0d | JPL | STM |
| 169 | 3.2.3.1.3 | STM FTB RF Filter Modules Delivery | milestone | 0d | 2002-08-01 | 2002-08-01 | 544 | 2002-04-01 | 2002-04-01 | 0d | 76.5d | 2d | JPL | STM |
| 170 | 3.2.3.2 | JFET Module STM Integration |  | 2d | 2002-08-01 | 2002-08-02 | 167, 168 | 2002-04-01 | 2002-04-02 | 2d | 74.5d | 0d | RAL | STM |
| 171 | 3.2.3.3 | FTB RF Filter Module STM integration |  | 1d | 2002-08-05 | 2002-08-05 | 167, 169, 170 | 2002-04-03 | 2002-04-03 | 1d | 74.5d | 0d | RAL | STM |
| 172 | 3.2.3.4 | FTB STM Enclosure Final Integration |  | 1d | 2002-08-06 | 2002-08-06 | 171 | 2002-04-04 | 2002-04-04 | 1d | 74.5d |  | RAL | STM |
| 173 | 3.2.4 | **STM Warm Environmental Test** |  | 24d | 2002-11-18 | 2002-12-20 | 138, 165 | 2002-09-03 | 2002-09-30 | 19d | 1d | 0d | RAL | STM |
| 174 | 3.2.4.1 | **Preparation of STM** |  | 14d | 2002-11-18 | 2002-12-06 | 135, 115, 119, 123, 127, 131, 117, 110, 121, 125, 129, 133 | 2002-09-03 | 2002-09-23 | 14d | 1d | 0d | RAL | STM |
| 175 | 3.2.4.1.1 | Remove InstrumentCovers and place into MGSE |  | 2d | 2002-11-18 | 2002-11-20 |  | 2002-09-03 | 2002-09-05 | 2d | 1d | 0d | RAL | STM |
| 176 | 3.2.4.1.2 | Remove OGSE |  | 1d | 2002-11-20 | 2002-11-21 | 175 | 2002-09-05 | 2002-09-06 | 1d | 1d | 0d | RAL | STM |
| 177 | 3.2.4.1.3 | Integration of STM Subsystems |  | 8d | 2002-11-21 | 2002-12-03 | 176 | 2002-09-06 | 2002-09-18 | 8d | 1d | 0d | RAL | STM |
| 178 | 3.2.4.1.4 | Refit Covers |  | 1d | 2002-12-03 | 2002-12-04 | 177 | 2002-09-18 | 2002-09-19 | 1d | 1d | 0d | RAL | STM |
| 179 | 3.2.4.1.5 | Integrate JFET Boxes and harnesses |  | 1d | 2002-12-04 | 2002-12-05 | 178 | 2002-09-19 | 2002-09-20 | 1d | 1d | 0d | RAL | STM |
| 180 | 3.2.4.1.6 | Prepare Instrument and Transport to Vibration Facility |  | 1d | 2002-12-05 | 2002-12-06 | 179 | 2002-09-20 | 2002-09-23 | 1d | 1d |  | RAL | STM |
| 181 | 3.2.4.1.7 | STM Warm Vibration Test Readiness Review | milestone | 1d | 2002-12-05 | 2002-12-06 | 179 |  |  |  | 1d |  | RAL | STM |
| 182 | 3.2.4.2 | **STM Warm Vibration** |  | 10d | 2002-12-06 | 2002-12-20 | 174 | 2002-09-23 | 2002-09-30 | 5d | 1d |  | RAL | STM |
| 183 | 3.2.4.2.1 | 3 axes - I day per axis plus setup |  | 4d | 2002-12-06 | 2002-12-12 |  | 2002-09-23 | 2002-09-27 | 4d | 1d | 0d | RAL | STM |
| 184 | 3.2.4.2.2 | Preparation and Transport to Integration Facility |  | 1d | 2002-12-12 | 2002-12-13 | 183 | 2002-09-27 | 2002-09-30 | 1d | 1d | 0d | RAL | STM |
| 185 | 3.2.4.2.3 | Post-Vibration Test |  | 5d | 2002-12-13 | 2002-12-20 | 184 |  |  |  | 1d |  | RAL | STM |
| 186 | 3.2.5 | Review Preparation |  | 2d | 2002-12-20 | 2002-12-24 | 173 | 2002-09-30 | 2002-10-02 | 2d | 1d | 0d | RAL | STM |
| 187 | 3.2.6 | STM Interim Review | milestone | 1d | 2002-12-24 | 2003-01-06 | 186 | 2002-10-02 | 2002-10-03 | 1d | 1d | 0d | RAL | STM |
| 188 | 3.2.7 | **STM Cold Thermal Verification** |  | 22d | 2003-01-06 | 2003-02-05 | 187, 137 | 2002-10-03 | 2002-11-04 | 22d | 1d | 0d | RAL | STM |
| 189 | 3.2.7.1 | Remove Instrument Covers and Place in MGSE |  | 2d | 2003-01-06 | 2003-01-08 |  | 2002-10-03 | 2002-10-07 | 2d | 1d | 0d | RAL | STM |
| 190 | 3.2.7.2 | Remove STM Cooler and Integrate CQM Cooler |  | 2d | 2003-01-08 | 2003-01-10 | 189 | 2002-10-07 | 2002-10-09 | 2d | 1d | 0d | RAL | STM |
| 191 | 3.2.7.3 | Refit Covers and mount on FOB Simulator |  | 2d | 2003-01-10 | 2003-01-14 | 190 | 2002-10-09 | 2002-10-11 | 2d | 1d | 0d | RAL | STM |
| 192 | 3.2.7.4 | Prepare and Transport to Cryolab |  | 0.5d | 2003-01-14 | 2003-01-14 | 191 | 2002-10-11 | 2002-10-11 | 0.5d | 1d | 0d | RAL | STM |
| 193 | 3.2.7.5 | Integrate into Cryostat and Thermometry |  | 3d | 2003-01-15 | 2003-01-17 | 192 | 2002-10-14 | 2002-10-16 | 3d | 1d | 0d | RAL | STM |
| 194 | 3.2.7.6 | Cold Thermal Test Readiness Review | milestone | 1d | 2003-01-20 | 2003-01-20 | 193 |  |  |  | 12.5d |  | RAL | STM |
| 195 | 3.2.7.7 | Pump Down |  | 1d | 2003-01-20 | 2003-01-20 | 193 | 2002-10-17 | 2002-10-17 | 1d | 1d | 0d | RAL | STM |
| 196 | 3.2.7.8 | Cooldown |  | 2d | 2003-01-21 | 2003-01-22 | 195 | 2002-10-18 | 2002-10-21 | 2d | 1d | 0d | RAL | STM |
| 197 | 3.2.7.9 | Thermal Verification Tests |  | 5d | 2003-01-23 | 2003-01-29 | 196 | 2002-10-22 | 2002-10-28 | 5d | 1d | 0d | RAL | STM |
| 198 | 3.2.7.10 | Warm up and let up to ambient pressure |  | 3d | 2003-01-30 | 2003-02-03 | 197 | 2002-10-29 | 2002-10-31 | 3d | 1d | 0d | RAL | STM |
| 199 | 3.2.7.11 | De-integrate Instrument from Cryostat and return to Integration Area |  | 1.5d | 2003-02-04 | 2003-02-05 | 198 | 2002-11-01 | 2002-11-04 | 1.5d | 1d |  | RAL | STM |

| ID | WBS | Task | Type | Duration | Start | Finish | Predecessors | Baseline start | Baseline finish | Baseline duration | Total slack | Free slack | Text1 | Text2 |
| --- | --- | --- | --- | --- | --- | --- | --- | --- | --- | --- | --- | --- | --- | --- |
| 200 | 3.2.8 | **STM EMC Testing** |  | 13d | 2003-02-05 | 2003-02-24 | 188 | 2002-11-04 | 2002-11-21 | 13d | 1d | 0d | RAL | STM |
| 201 | 3.2.8.1 | Instrument Preparation for EMC Tests |  | 3d | 2003-02-05 | 2003-02-10 |  | 2002-11-04 | 2002-11-07 | 3d | 1d | 0d | RAL | STM |
| 202 | 3.2.8.2 | Instrument Placed in Transport Container and packing |  | 3d | 2003-02-10 | 2003-02-13 | 201 | 2002-11-07 | 2002-11-12 | 3d | 1d | 0d | RAL | STM |
| 203 | 3.2.8.3 | Transport to facility |  | 2d | 2003-02-13 | 2003-02-17 | 202 | 2002-11-12 | 2002-11-14 | 2d | 1d | 0d | RAL | STM |
| 204 | 3.2.8.4 | EMC Testing |  | 5d | 2003-02-17 | 2003-02-24 | 203 | 2002-11-14 | 2002-11-21 | 5d | 1d |  | RAL | STM |
| 205 | 3.2.9 | **STM Cold Vibration** |  | 28d | 2003-02-24 | 2003-04-03 | 200 | 2002-11-21 | 2003-01-10 | 28d | 1d | 0d | RAL | STM |
| 206 | 3.2.9.1 | Cold Vibration Test Readiness Review |  | 1d | 2003-02-24 | 2003-02-25 |  |  |  |  | 28d |  | RAL | STM |
| 207 | 3.2.9.2 | Instrument preparation for Vibration |  | 3d | 2003-02-24 | 2003-02-27 |  | 2002-11-21 | 2002-11-26 | 3d | 1d | 0d | RAL | STM |
| 208 | 3.2.9.3 | Instrument Placed in Transport Container(s) and packing |  | 3d | 2003-02-27 | 2003-03-04 | 207 | 2002-11-26 | 2002-11-29 | 3d | 1d | 0d | RAL | STM |
| 209 | 3.2.9.4 | Transport to facility |  | 2d | 2003-03-04 | 2003-03-06 | 208 | 2002-11-29 | 2002-12-03 | 2d | 1d | 0d | RAL | STM |
| 210 | 3.2.9.5 | Cold Vibration Campaign |  | 15d | 2003-03-06 | 2003-03-27 | 209 | 2002-12-03 | 2002-12-24 | 15d | 1d | 0d | RAL | STM |
| 211 | 3.2.9.6 | Instrument Placed in Transport Container and packing |  | 3d | 2003-03-27 | 2003-04-01 | 210 | 2002-12-24 | 2003-01-08 | 3d | 1d | 0d | RAL | STM |
| 212 | 3.2.9.7 | Transport to RAL |  | 2d | 2003-04-01 | 2003-04-03 | 211 | 2003-01-08 | 2003-01-10 | 2d | 1d |  | RAL | STM |
| 213 | 3.2.10 | **STM Cold Verification** |  | 15.5d | 2003-04-03 | 2003-04-24 | 205 | 2003-01-10 | 2003-01-31 | 15.5d | 1d | 0d | RAL | STM |
| 214 | 3.2.10.1 | Integrate into Cryostat and Thermometry |  | 3d | 2003-04-03 | 2003-04-08 |  | 2003-01-10 | 2003-01-15 | 3d | 1d | 0d | RAL | STM |
| 215 | 3.2.10.2 | Pump Down |  | 1d | 2003-04-08 | 2003-04-09 | 214 | 2003-01-15 | 2003-01-16 | 1d | 1d | 0d | RAL | STM |
| 216 | 3.2.10.3 | Cooldown |  | 2d | 2003-04-09 | 2003-04-11 | 215 | 2003-01-16 | 2003-01-20 | 2d | 1d | 0d | RAL | STM |
| 217 | 3.2.10.4 | Thermal verification and Cold Alignment Tests |  | 5d | 2003-04-11 | 2003-04-18 | 216 | 2003-01-20 | 2003-01-27 | 5d | 1d | 0d | RAL | STM |
| 218 | 3.2.10.5 | Warm up and let up to ambient pressure |  | 3d | 2003-04-18 | 2003-04-23 | 217 | 2003-01-27 | 2003-01-30 | 3d | 1d | 0d | RAL | STM |
| 219 | 3.2.10.6 | De-integrate Instrument from Cryostat and return to Integration Area |  | 1.5d | 2003-04-23 | 2003-04-24 | 218 | 2003-01-30 | 2003-01-31 | 1.5d | 1d |  | RAL | STM |
| 220 | 3.2.11 | **STM De-Integration** |  | 6d | 2003-04-25 | 2003-05-02 | 213 | 2003-02-03 | 2003-02-10 | 6d | 1d | 0d | RAL | STM |
| 221 | 3.2.11.1 | Instrument unpacking and preparation |  | 1d | 2003-04-25 | 2003-04-25 |  | 2003-02-03 | 2003-02-03 | 1d | 1d | 0d | RAL | STM |
| 222 | 3.2.11.2 | Structure into MGSE and removal of covers |  | 2d | 2003-04-28 | 2003-04-29 | 221 | 2003-02-04 | 2003-02-05 | 2d | 1d | 0d | RAL | STM |
| 223 | 3.2.11.3 | Removal of Subsystem STMs |  | 3d | 2003-04-30 | 2003-05-02 | 222 | 2003-02-06 | 2003-02-10 | 3d | 1d |  | RAL | STM |
| 224 | 3.2.12 | CQM Structure and FTBs available | milestone | 0d | 2003-05-02 | 2003-05-02 | 220 | 2003-02-10 | 2003-02-10 | 0d | 1d | 0d | RAL | STM |
| 225 | 3.2.13 | Review Preparation |  | 5d | 2003-04-25 | 2003-05-01 | 213 | 2003-02-03 | 2003-02-07 | 5d | 2d | 0d | RAL | STM |
| 226 | 3.2.14 | STM Review | milestone | 0d | 2003-05-01 | 2003-05-01 | 225 | 2003-02-07 | 2003-02-07 | 0d | 2d | 1d | RAL | STM |

| ID | WBS | Task | Type | Duration | Start | Finish | Predecessors | Baseline start | Baseline finish | Baseline duration | Total slack | Free slack | Text2 | Text1 |
| --- | --- | --- | --- | --- | --- | --- | --- | --- | --- | --- | --- | --- | --- | --- |
| 227 | 3.3 | **Cryogenic Qualification Model AIV** |  | 229d | 2002-11-01 | 2003-09-29 |  | 2002-06-01 | 2003-05-28 | 250d | 93d |  | CQM |  |
| 228 | 3.3.1 | **CQM Integration** |  | 146.5d | 2002-11-01 | 2003-06-05 |  | 2002-06-01 | 2003-03-14 | 196.5d | 1d | 0d | CQM |  |
| 229 | 3.3.1.1 | **CQM FPU Subsystem Deliveries** |  | 32d | 2003-01-11 | 2003-02-25 |  | 2002-12-20 | 2002-12-24 | 3d | 60.5d |  | CQM |  |
| 230 | 3.3.1.1.1 | CQM Filters, Dichroics and Beamsplitters Delivery | milestone | 0d | 2003-02-21 | 2003-02-21 | 549 | 2002-12-20 | 2002-12-20 | 0d | 49d | 0d | CQM | QMW |
| 231 | 3.3.1.1.2 | CQM Filters, Dichroics and Beamsplitters Acceptance |  | 3d | 2003-02-21 | 2003-02-25 | 230 | 2002-12-20 | 2002-12-24 | 3d | 49d | 48d | CQM | RAL |
| 232 | 3.3.1.1.3 | CQM BDAs Delivery | milestone | 0d | 2003-01-11 | 2003-01-11 | 550 | 2002-12-20 | 2002-12-20 | 0d | 78d | 0d | CQM | JPL |
| 233 | 3.3.1.1.4 | CQM BDAs Acceptance |  | 3d | 2003-01-13 | 2003-01-15 | 232 | 2002-12-20 | 2002-12-24 | 3d | 78d | 23d | CQM | RAL |
| 234 | 3.3.1.1.5 | CQM SMECm Delivery | milestone | 0d | 2003-01-11 | 2003-01-11 | 551 | 2002-12-20 | 2002-12-20 | 0d | 89.5d | 0d | CQM | LAM |
| 235 | 3.3.1.1.6 | CQM SMECm Acceptance |  | 3d | 2003-01-13 | 2003-01-15 | 234 | 2002-12-20 | 2002-12-24 | 3d | 89.5d | 34.5d | CQM | RAL |
| 236 | 3.3.1.1.7 | CQM SCAL Delivery | milestone | 0d | 2003-01-11 | 2003-01-11 | 552 | 2002-12-20 | 2002-12-20 | 0d | 89.5d | 0d | CQM | QMW |
| 237 | 3.3.1.1.8 | CQM SCAL Acceptance |  | 3d | 2003-01-13 | 2003-01-15 | 236 | 2002-12-20 | 2002-12-24 | 3d | 89.5d | 34.5d | CQM | RAL |
| 238 | 3.3.1.1.9 | CQM Shutter Delivery | milestone | 0d | 2003-01-11 | 2003-01-11 | 553 | 2002-12-20 | 2002-12-20 | 0d | 89.5d | 0d | CQM | USK |
| 239 | 3.3.1.1.10 | CQM Shutter Acceptance |  | 3d | 2003-01-13 | 2003-01-15 | 238 | 2002-12-20 | 2002-12-24 | 3d | 89.5d | 34.5d | CQM | RAL |
| 240 | 3.3.1.1.11 | CQM BSMm Delivery | milestone | 0d | 2003-01-11 | 2003-01-11 | 554 | 2002-12-20 | 2002-12-20 | 0d | 89.5d | 0d | CQM | ATC |
| 241 | 3.3.1.1.12 | CQM BSMm Acceptance |  | 3d | 2003-01-13 | 2003-01-15 | 240 | 2002-12-20 | 2002-12-24 | 3d | 89.5d | 34.5d | CQM | RAL |
| 242 | 3.3.1.1.13 | CQM FPU RF Filters Delivery | milestone | 0d | 2003-01-11 | 2003-01-11 | 555 | 2002-12-20 | 2002-12-20 | 0d | 85d | 0d | CQM | ATC |
| 243 | 3.3.1.1.14 | CQM FPU RF Filters Acceptance |  | 3d | 2003-01-13 | 2003-01-15 | 242 | 2002-12-20 | 2002-12-24 | 3d | 85d | 30d | CQM | RAL |
| 244 | 3.3.1.2 | **CQM FPU Integration** |  | 21.5d | 2003-05-05 | 2003-06-03 | 231, 224, 226 | 2003-02-11 | 2003-03-12 | 21.5d | 1d | 0d | CQM | RAL |
| 245 | 3.3.1.2.1 | **Photometer Detector Box Integration** |  | 4d | 2003-05-05 | 2003-05-08 | 233 | 2003-02-11 | 2003-02-14 | 4d | 1d | 0d |  |  |
| 246 | 3.3.1.2.1.1 | PLW BDA Integration and Alignment |  | 1d | 2003-05-05 | 2003-05-05 |  | 2003-02-11 | 2003-02-11 | 1d | 1d | 0d |  |  |
| 247 | 3.3.1.2.1.2 | PMW BDA Integration and Alignment |  | 1d | 2003-05-06 | 2003-05-06 | 246 | 2003-02-12 | 2003-02-12 | 1d | 1d | 0d |  |  |
| 248 | 3.3.1.2.1.3 | PSW BDA Integration and Alignment |  | 1d | 2003-05-07 | 2003-05-07 | 247 | 2003-02-13 | 2003-02-13 | 1d | 1d | 0d |  |  |
| 249 | 3.3.1.2.1.4 | Dichroic and Filter Integration |  | 1d | 2003-05-08 | 2003-05-08 | 248 | 2003-02-14 | 2003-02-14 | 1d | 1d |  |  |  |
| 250 | 3.3.1.2.2 | **Spectrometer Detector Box Integration** |  | 3d | 2003-05-09 | 2003-05-13 | 245, 233 | 2003-02-17 | 2003-02-19 | 3d | 1d | 0d |  |  |
| 251 | 3.3.1.2.2.1 | SLW BDA Integration and Alignment |  | 1d | 2003-05-09 | 2003-05-09 |  | 2003-02-17 | 2003-02-17 | 1d | 1d | 0d |  |  |
| 252 | 3.3.1.2.2.2 | SSW BDA Integration and Alignment |  | 1d | 2003-05-12 | 2003-05-12 | 251 | 2003-02-18 | 2003-02-18 | 1d | 1d | 0d |  |  |
| 253 | 3.3.1.2.2.3 | Filter Integration |  | 1d | 2003-05-13 | 2003-05-13 | 252 | 2003-02-19 | 2003-02-19 | 1d | 1d |  |  |  |

| ID | WBS | Task | Type | Duration | Start | Finish | Predecessors | Baseline start | Baseline finish | Baseline duration | Total slack | Free slack | Text1 | Text2 |
| --- | --- | --- | --- | --- | --- | --- | --- | --- | --- | --- | --- | --- | --- | --- |
| 254 | 3.3.1.2.3 | **Detector Box Integration with Structure** |  | 4.5d | 2003-05-14 | 2003-05-20 | 250, 245, 243 | 2003-02-20 | 2003-02-26 | 4.5d | 1d | 0d |  |  |
| 255 | 3.3.1.2.3.1 | FPU RF Filters Integration |  | 1d | 2003-05-14 | 2003-05-14 |  | 2003-02-20 | 2003-02-20 | 1d | 2d | 1d |  |  |
| 256 | 3.3.1.2.3.2 | SMECm Optical Dummy Integration |  | 1d | 2003-05-14 | 2003-05-14 |  | 2003-02-20 | 2003-02-20 | 1d | 1d | 0d |  |  |
| 257 | 3.3.1.2.3.3 | Photometer Detector Box Integration and Alignement |  | 1d | 2003-05-15 | 2003-05-15 | 256 | 2003-02-21 | 2003-02-21 | 1d | 1d | 0d |  |  |
| 258 | 3.3.1.2.3.4 | Photometer Detector Harness Integration |  | 1d | 2003-05-16 | 2003-05-16 | 257, 255 | 2003-02-24 | 2003-02-24 | 1d | 1d | 0d |  |  |
| 259 | 3.3.1.2.3.5 | Spectrometer Detector Box Integration and Alignement |  | 1d | 2003-05-19 | 2003-05-19 | 258 | 2003-02-25 | 2003-02-25 | 1d | 1d | 0d |  |  |
| 260 | 3.3.1.2.3.6 | Spectrometer Detector Harness Integration |  | 0.5d | 2003-05-20 | 2003-05-20 | 259 | 2003-02-26 | 2003-02-26 | 0.5d | 1d |  |  |  |
| 261 | 3.3.1.2.4 | **Subsystem Integration** |  | 10d | 2003-05-20 | 2003-06-03 | 254, 241, 239, 237, 235 | 2003-02-26 | 2003-03-12 | 10d | 1d |  |  |  |
| 262 | 3.3.1.2.4.1 | Replace BSMm STM with CQM |  | 2d | 2003-05-20 | 2003-05-22 | 241 | 2003-02-26 | 2003-02-28 | 2d | 1d | 0d |  |  |
| 263 | 3.3.1.2.4.2 | Photometer Filters Integration |  | 1d | 2003-05-22 | 2003-05-23 | 262 | 2003-02-28 | 2003-03-03 | 1d | 1d | 0d |  |  |
| 264 | 3.3.1.2.4.3 | Replace SMECm Optical Dummy with CQM |  | 3d | 2003-05-23 | 2003-05-28 | 263 | 2003-03-03 | 2003-03-06 | 3d | 1d | 0d |  |  |
| 265 | 3.3.1.2.4.4 | SCAL Integration |  | 1d | 2003-05-28 | 2003-05-29 | 264 | 2003-03-06 | 2003-03-07 | 1d | 1d | 0d |  |  |
| 266 | 3.3.1.2.4.5 | Spectrometer Filter and Beamsplitter Integration |  | 1d | 2003-05-29 | 2003-05-30 | 265 | 2003-03-07 | 2003-03-10 | 1d | 1d | 0d |  |  |
| 267 | 3.3.1.2.4.6 | Shutter Integration |  | 1d | 2003-05-30 | 2003-06-02 | 266 | 2003-03-10 | 2003-03-11 | 1d | 1d | 0d | RAL | CQM |
| 268 | 3.3.1.2.4.7 | Cover Assembly |  | 1d | 2003-06-02 | 2003-06-03 | 267 | 2003-03-11 | 2003-03-12 | 1d | 1d |  |  |  |
| 269 | 3.3.1.3 | **CQM FTB Subsystem Deliveries** |  | 3d | 2003-02-01 | 2003-02-05 |  | 2002-12-20 | 2002-12-24 | 3d | 76.5d | 0d |  | CQM |
| 270 | 3.3.1.3.1 | CQM JFET Modules Delivery | milestone | 0d | 2003-02-01 | 2003-02-01 | 556 | 2002-12-20 | 2002-12-20 | 0d | 76.5d | 0d | JPL | CQM |
| 271 | 3.3.1.3.2 | CQM JFET Modules Acceptance |  | 3d | 2003-02-03 | 2003-02-05 | 270 | 2002-12-20 | 2002-12-24 | 3d | 76.5d |  | RAL | CQM |
| 272 | 3.3.1.3.3 | CQM FTB RF Filter Modules Delivery | milestone | 0d | 2003-02-01 | 2003-02-01 | 557 | 2002-12-20 | 2002-12-20 | 0d | 76.5d | 0d | JPL | CQM |
| 273 | 3.3.1.3.4 | CQM FTB RF Filter Modules Acceptance |  | 3d | 2003-02-03 | 2003-02-05 | 272 | 2002-12-20 | 2002-12-24 | 3d | 76.5d |  | RAL | CQM |
| 274 | 3.3.1.4 | **CQM FTB Integration** |  | 8d | 2003-02-06 | 2003-02-17 | 269 | 2003-01-06 | 2003-01-15 | 8d | 76.5d | 21.5d |  |  |
| 275 | 3.3.1.4.1 | JFET Module Integration |  | 2d | 2003-02-06 | 2003-02-07 |  | 2003-01-06 | 2003-01-07 | 2d | 76.5d | 0d |  |  |
| 276 | 3.3.1.4.2 | RF Filter Modules Integration |  | 1d | 2003-02-10 | 2003-02-10 | 275 | 2003-01-08 | 2003-01-08 | 1d | 76.5d | 0d |  |  |
| 277 | 3.3.1.4.3 | FTB Final Integration |  | 5d | 2003-02-11 | 2003-02-17 | 276 | 2003-01-09 | 2003-01-15 | 5d | 76.5d |  |  |  |

| ID | WBS | Task | Type | Duration | Start | Finish | Predecessors | Baseline start | Baseline finish | Baseline duration | Total slack | Free slack | Text1 | Text2 |
| --- | --- | --- | --- | --- | --- | --- | --- | --- | --- | --- | --- | --- | --- | --- |
| 278 | 3.3.1.5 | **FPU/FTB Integration with FOB Simulator** |  | 2d | 2003-06-03 | 2003-06-05 | 274, 244 | 2003-03-12 | 2003-03-14 | 2d | 1d |  |  |  |
| 279 | 3.3.1.5.1 | FPU/FTB Integration |  | 1d | 2003-06-03 | 2003-06-04 |  | 2003-03-12 | 2003-03-13 | 1d | 1d | 0d |  |  |
| 280 | 3.3.1.5.2 | Alignment of SOR to FOR |  | 1d | 2003-06-04 | 2003-06-05 | 279 | 2003-03-13 | 2003-03-14 | 1d | 1d |  |  |  |
| 281 | 3.3.1.6 | **CQM Warm electronics Deliveries** |  | 60d | 2002-12-01 | 2003-03-05 |  | 2002-06-01 | 2002-07-03 | 23d | 15d | 0d |  |  |
| 282 | 3.3.1.6.1 | QM1 DRCU Delivery to RAL | milestone | 0d | 2003-03-03 | 2003-03-03 | 563 | 2002-07-01 | 2002-07-01 | 0d | 15d | 0d | SAp | CQM |
| 283 | 3.3.1.6.2 | QM1 DRCU Acceptance |  | 3d | 2003-03-03 | 2003-03-05 | 282 | 2002-07-01 | 2002-07-03 | 3d | 15d |  | RAL | CQM |
| 284 | 3.3.1.6.3 | QM1 WIH Delivery to RAL | milestone | 0d | 2003-03-03 | 2003-03-03 | 564 | 2002-07-01 | 2002-07-01 | 0d | 15d | 0d | SAp | CQM |
| 285 | 3.3.1.6.4 | QM1 WIH Acceptance |  | 3d | 2003-03-03 | 2003-03-05 | 284 | 2002-07-01 | 2002-07-03 | 3d | 15d |  | RAL | CQM |
| 286 | 3.3.1.6.5 | FPU Simulator#1 Delivery to RAL | milestone | 0d | 2002-12-01 | 2002-12-01 | 565 | 2002-06-01 | 2002-06-01 | 0d | 72d | 0d | SAp | CQM |
| 287 | 3.3.1.6.6 | FPU Simulator#1 Acceptance |  | 3d | 2002-12-02 | 2002-12-04 | 286 | 2002-06-03 | 2002-06-05 | 3d | 72d |  | RAL | CQM |
| 288 | 3.3.1.7 | Test Facility Available | milestone | 0d | 2002-11-01 | 2002-11-01 | 546 |  |  |  | 96d | 24d | RAL |  |
| 289 | 3.3.1.8 | **CQM Warm Electronics Integration** |  | 30d | 2003-03-05 | 2003-04-16 | 79, 281, 288 | 2002-08-28 | 2002-10-09 | 30d | 15d | 0d | RAL | CQM |
| 290 | 3.3.1.8.1 | Warm Electronics Integration Test |  | 4w | 2003-03-06 | 2003-04-02 |  | 2002-08-29 | 2002-09-25 | 4w | 15d | 0d | RAL | CQM |
| 291 | 3.3.1.8.2 | EGSE#3 Available | milestone | 0d | 2003-03-05 | 2003-03-05 | 566 | 2002-08-28 | 2002-08-28 | 0d | 35d | 20d | RAL | CQM |
| 292 | 3.3.1.8.3 | QM DPU Delivery to RAL | milestone | 0d | 2003-03-05 | 2003-03-05 | 574 | 2003-01-01 | 2003-01-01 | 0d | 25d | 0d | IFSI | EQM |
| 293 | 3.3.1.8.4 | QM DPU Acceptance |  | 2w | 2003-03-06 | 2003-03-19 | 292 | 2003-01-06 | 2003-01-08 | 3d | 25d | 10d | RAL | EQM |
| 294 | 3.3.1.8.5 | Test Facility Integration |  | 2w | 2003-04-03 | 2003-04-16 | 290, 291, 293 | 2002-09-26 | 2002-10-09 | 2w | 15d | 0d | RAL | CQM |
| 295 | 3.3.1.8.6 | AVM DPU Release for Delivery | milestone | 0d | 2003-04-16 | 2003-04-16 | 294 |  |  |  | 15d |  |  |  |
| 296 | 3.3.2 | CQM Test Readiness Review | milestone | 1d | 2003-06-05 | 2003-06-06 | 228, 289 | 2003-03-14 | 2003-03-17 | 1d | 1d | 0d | RAL | CQM |
| 297 | 3.3.3 | **CQM Verification** |  | 75.5d | 2003-06-06 | 2003-09-19 | 296 | 2003-03-17 | 2003-05-28 | 52.5d | 1d |  |  |  |
| 298 | 3.3.3.1 | **Instrument Integration I** |  | 7d | 2003-06-06 | 2003-06-17 |  | 2003-03-17 | 2003-03-28 | 9d | 1d | 0d | RAL | CQM |
| 299 | 3.3.3.1.1 | FPUFTB Preparation and Transport to Cryolab |  | 1d | 2003-06-06 | 2003-06-09 |  | 2003-03-17 | 2003-03-18 | 1d | 1d | 0d | RAL | CQM |
| 300 | 3.3.3.1.2 | FPU/FTB Integration into Cryostat |  | 2d | 2003-06-09 | 2003-06-11 | 299 | 2003-03-18 | 2003-03-20 | 2d | 1d | 0d | RAL |  |
| 301 | 3.3.3.1.3 | FPU/FTB Integration with Warm Electronics |  | 1d | 2003-06-11 | 2003-06-12 | 300 | 2003-03-20 | 2003-03-21 | 1d | 1d | 0d | RAL |  |
| 302 | 3.3.3.1.4 | Warm Functional Test I |  | 3d | 2003-06-12 | 2003-06-17 | 301 | 2003-03-21 | 2003-03-28 | 5d | 1d |  | RAL | CQM |

| ID | WBS | Task | Type | Duration | Start | Finish | Predecessors | Baseline start | Baseline finish | Baseline duration | Total slack | Free slack | Text1 | Text2 |
| --- | --- | --- | --- | --- | --- | --- | --- | --- | --- | --- | --- | --- | --- | --- |
| 303 | 3.3.3.2 | **CQM Instrument Cold Test** |  | 14d | 2003-06-17 | 2003-07-07 | 298 | 2003-03-28 | 2003-04-17 | 14d | 1d | 0d | RAL | CQM |
| 304 | 3.3.3.2.1 | Pumpdown |  | 1d | 2003-06-17 | 2003-06-18 |  | 2003-03-28 | 2003-03-31 | 1d | 1d | 0d |  |  |
| 305 | 3.3.3.2.2 | Cooldown |  | 2d | 2003-06-18 | 2003-06-20 | 304 | 2003-03-31 | 2003-04-02 | 2d | 1d | 0d | RAL | CQM |
| 306 | 3.3.3.2.3 | Cold Functional Test I |  | 1d | 2003-06-20 | 2003-06-23 | 305 | 2003-04-02 | 2003-04-03 | 1d | 1d | 0d | RAL | CQM |
| 307 | 3.3.3.2.4 | Thermal Performance Verification |  | 3d | 2003-06-23 | 2003-06-26 | 306 | 2003-04-03 | 2003-04-08 | 3d | 1d | 0d | RAL | CQM |
| 308 | 3.3.3.2.5 | Cold Functional Test II |  | 2d | 2003-06-26 | 2003-06-30 | 307 | 2003-04-08 | 2003-04-10 | 2d | 1d | 0d | RAL | CQM |
| 309 | 3.3.3.2.6 | FIR Alignment Verification |  | 5d | 2003-06-30 | 2003-07-07 | 308 | 2003-04-10 | 2003-04-17 | 5d | 1d |  |  |  |
| 310 | 3.3.3.3 | CQM Interim Review | milestone | 1d | 2003-07-07 | 2003-07-08 | 303 | 2003-04-17 | 2003-04-18 | 1d | 1d | 0d |  |  |
| 311 | 3.3.3.4 | PFM BDA Delivery | milestone | 0d | 2003-06-06 | 2003-06-06 | 567 | 2003-03-17 | 2003-03-17 | 0d | 20d | 0d |  |  |
| 312 | 3.3.3.5 | PFM BDA Acceptance |  | 3d | 2003-06-06 | 2003-06-11 | 311 | 2003-03-17 | 2003-03-20 | 3d | 20d | 19d |  |  |
| 313 | 3.3.3.6 | **Instrument Reconfiguration** |  | 12.5d | 2003-07-08 | 2003-07-24 | 312, 310 | 2003-04-18 | 2003-05-06 | 12.5d | 1d | 0d |  |  |
| 314 | 3.3.3.6.1 | Warmup |  | 3d | 2003-07-08 | 2003-07-11 |  | 2003-04-18 | 2003-04-23 | 3d | 1d | 0d |  |  |
| 315 | 3.3.3.6.2 | FPU/FTB De-integration from Cryostat |  | 1.5d | 2003-07-11 | 2003-07-14 | 314 | 2003-04-23 | 2003-04-24 | 1.5d | 1d | 0d |  |  |
| 316 | 3.3.3.6.3 | FPU/FTB Preparation and transport to AIV Facility |  | 0.5d | 2003-07-15 | 2003-07-15 | 315 | 2003-04-25 | 2003-04-25 | 0.5d | 1d | 0d |  |  |
| 317 | 3.3.3.6.4 | FPU De-integration and mount on GSE |  | 1d | 2003-07-15 | 2003-07-16 | 316 | 2003-04-25 | 2003-04-28 | 1d | 1d | 0d |  |  |
| 318 | 3.3.3.6.5 | Remove Covers |  | 0.5d | 2003-07-16 | 2003-07-16 | 317 | 2003-04-28 | 2003-04-28 | 0.5d | 1d | 0d |  |  |
| 319 | 3.3.3.6.6 | Fit PFM BDA |  | 3d | 2003-07-17 | 2003-07-21 | 318 | 2003-04-29 | 2003-05-01 | 3d | 1d | 0d |  |  |
| 320 | 3.3.3.6.7 | Re-integration and install Covers |  | 1d | 2003-07-22 | 2003-07-22 | 319 | 2003-05-02 | 2003-05-02 | 1d | 1d | 0d |  |  |
| 321 | 3.3.3.6.8 | FPU Integration to FOB Simulator |  | 1d | 2003-07-23 | 2003-07-23 | 320 | 2003-05-05 | 2003-05-05 | 1d | 1d | 0d |  |  |
| 322 | 3.3.3.6.9 | SOR to FOR Verification |  | 1d | 2003-07-24 | 2003-07-24 | 321 | 2003-05-06 | 2003-05-06 | 1d | 1d |  |  |  |
| 323 | 3.3.3.7 | **Instrument Integration II** |  | 4d | 2003-07-25 | 2003-07-30 | 313 | 2003-05-07 | 2003-05-28 | 16d | 1d | 0d |  |  |
| 324 | 3.3.3.7.1 | FPU/FTB Preparation and transport to Cryolab |  | 0.5d | 2003-07-25 | 2003-07-25 |  |  |  |  | 1d | 0d |  |  |
| 325 | 3.3.3.7.2 | FPU/FTB Integration into Cryosta |  | 2d | 2003-07-25 | 2003-07-29 | 324 |  |  |  | 1d | 0d |  |  |
| 326 | 3.3.3.7.3 | FPU/FTB Integration with Warm Electronics |  | 0.5d | 2003-07-29 | 2003-07-29 | 325 |  |  |  | 1d | 0d |  |  |
| 327 | 3.3.3.7.4 | Warm Functional Test II |  | 1d | 2003-07-30 | 2003-07-30 | 326 |  |  |  | 1d |  |  |  |

| ID | WBS | Task | Type | Duration | Start | Finish | Predecessors | Baseline start | Baseline finish | Baseline duration | Total slack | Free slack | Text1 | Text2 |
| --- | --- | --- | --- | --- | --- | --- | --- | --- | --- | --- | --- | --- | --- | --- |
| 328 | 3.3.3.8 | **Instrument Cold Verification** |  | 37d | 2003-07-31 | 2003-09-19 | 323 | 2003-05-07 | 2003-05-13 | 5d | 1d | 0d |  |  |
| 329 | 3.3.3.8.1 | Pumpdown |  | 1d | 2003-07-31 | 2003-07-31 |  |  |  |  | 1d | 0d |  |  |
| 330 | 3.3.3.8.2 | Cooldown |  | 2d | 2003-08-01 | 2003-08-04 | 329 |  |  |  | 1d | 0d |  |  |
| 331 | 3.3.3.8.3 | Cold Functional Test III |  | 2d | 2003-08-05 | 2003-08-06 | 330 | 2003-05-14 | 2003-05-20 | 5d | 1d | 0d |  |  |
| 332 | 3.3.3.8.4 | Subsystem Performance Verification |  | 5d | 2003-08-07 | 2003-08-13 | 331 |  |  |  | 1d | 0d |  |  |
| 333 | 3.3.3.8.5 | Instrument Performance Verification |  | 10d | 2003-08-14 | 2003-08-27 | 332 |  |  |  | 1d | 0d |  |  |
| 334 | 3.3.3.8.6 | Instrument Observing Mode Verification |  | 10d | 2003-08-28 | 2003-09-10 | 333 |  |  |  | 1d | 0d |  |  |
| 335 | 3.3.3.8.7 | Cold Functional Test IV |  | 2d | 2003-09-11 | 2003-09-12 | 334 |  |  |  | 1d | 0d |  |  |
| 336 | 3.3.3.8.8 | Warmup |  | 3d | 2003-09-15 | 2003-09-17 | 335 | 2003-05-21 | 2003-05-26 | 4d | 1d | 0d |  |  |
| 337 | 3.3.3.8.9 | FPU/FTB De-integration from Cryostat |  | 1.5d | 2003-09-18 | 2003-09-19 | 336 | 2003-05-27 | 2003-05-28 | 2d | 1d | 0d | RAL | CQM |
| 338 | 3.3.3.8.10 | FPU/FTB Preparation and transport to AIV facility |  | 0.5d | 2003-09-19 | 2003-09-19 | 337 |  |  |  | 1d |  |  |  |
| 339 | 3.3.3.9 | Critical Design Reviews | milestone | 2d | 2003-09-11 | 2003-09-12 | 334 | 2003-05-07 | 2003-05-08 | 2d | 12d | 11d | RAL | CQM |
| 340 | 3.3.4 | **CQM Delivery Preparation** |  | 6d | 2003-09-22 | 2003-09-29 | 328 | 2003-05-07 | 2003-05-15 | 7d | 1d |  | RAL | CQM |
| 341 | 3.3.4.1 | Mass properties Measurement |  | 2d | 2003-09-22 | 2003-09-23 |  | 2003-05-09 | 2003-05-12 | 2d | 878d | 0d | RAL | CQM |
| 342 | 3.3.4.2 | Packing and shipment |  | 3d | 2003-09-24 | 2003-09-26 | 341 | 2003-05-13 | 2003-05-14 | 2d | 878d |  | RAL | CQM |
| 343 | 3.3.4.3 | Preparation of Delivery Data Package |  | 5d | 2003-09-22 | 2003-09-26 |  | 2003-05-07 | 2003-05-13 | 5d | 1d | 0d | RAL | CQM |
| 344 | 3.3.4.4 | CQM Readiness Review | milestone | 1d | 2003-09-29 | 2003-09-29 | 343 | 2003-05-14 | 2003-05-15 | 2d | 1d | 0d | RAL | CQM |
| 345 | 3.3.5 | Delivery of CQM to ESA | milestone | 0d | 2003-09-29 | 2003-09-29 | 344, 339 | 2003-05-15 | 2003-05-15 | 0d | 1d |  | RAL | CQM |
| 346 | 3.4 | **Warm Electronics Qualification Model** |  | 171d | 2003-06-01 | 2004-02-04 |  | 2003-01-01 | 2003-03-05 | 43d | 10d | 0d |  | EQM |
| 347 | 3.4.1 | QM2 DRCU Delivery to RAL | milestone | 0d | 2004-01-05 | 2004-01-05 | 577 | 2003-01-20 | 2003-01-20 | 0d | 10d | 0d | SAp | EQM |
| 348 | 3.4.2 | QM2 DRCU Acceptance |  | 3d | 2004-01-05 | 2004-01-07 | 347 | 2003-01-20 | 2003-01-22 | 3d | 10d | 0d | RAL | EQM |
| 349 | 3.4.3 | QM2 WIH Delivery to RAL | milestone | 0d | 2004-01-05 | 2004-01-05 | 578 | 2003-01-20 | 2003-01-20 | 0d | 10d | 0d | SAp | EQM |
| 350 | 3.4.4 | QM2 WIH Acceptance |  | 3d | 2004-01-05 | 2004-01-07 | 349 | 2003-01-20 | 2003-01-22 | 3d | 10d | 0d | RAL | EQM |
| 351 | 3.4.5 | FPU Simulator#2 Delivery to RAL | milestone | 0d | 2003-06-01 | 2003-06-01 | 579 | 2003-01-20 | 2003-01-20 | 0d | 158d | 0d | SAp | EQM |
| 352 | 3.4.6 | FPU Simulator#2 Acceptance |  | 3d | 2003-06-02 | 2003-06-04 | 351 | 2003-01-20 | 2003-01-22 | 3d | 158d | 148d | RAL | EQM |
| 353 | 3.4.7 | QM Warm Electronics Integration Test |  | 4w | 2004-01-08 | 2004-02-04 | 293, 348, 350, 352 | 2003-02-06 | 2003-03-05 | 4w | 10d |  | RAL | EQM |
| 354 | 3.5 | WE Critical Design Review | milestone | 0d | 2004-02-04 | 2004-02-04 | 346 | 2003-03-05 | 2003-03-05 | 0d | 792d | 0d | RAL | EQM |

| ID | WBS | Task | Type | Duration | Start | Finish | Predecessors | Baseline start | Baseline finish | Baseline duration | Total slack | Free slack | Text2 | Text1 |
| --- | --- | --- | --- | --- | --- | --- | --- | --- | --- | --- | --- | --- | --- | --- |
| 355 | 3.6 | **Proto-Flight Model AIV** |  | 332d | 2003-07-15 | 2004-10-29 |  | 2003-07-11 | 2004-06-14 | 235d | -42d | 0d | PFM |  |
| 356 | 3.6.1 | **PFM Integration** |  | 155d | 2003-07-15 | 2004-02-25 |  | 2003-07-11 | 2003-12-04 | 105d | 10d | 0d | PFM |  |
| 357 | 3.6.1.1 | **PFM FPU Integration** |  | 123d | 2003-07-15 | 2004-01-12 |  | 2003-07-11 | 2003-11-14 | 91d | 28d | 0d | PFM |  |
| 358 | 3.6.1.1.1 | **PFM FPU Subsystem Deliveries** |  | 100d | 2003-07-15 | 2003-12-01 |  | 2003-07-11 | 2003-10-03 | 61d | 40d |  | PFM |  |
| 359 | 3.6.1.1.1.1 | PFM Structure Delivery | milestone | 0d | 2003-07-15 | 2003-07-15 | 585 | 2003-07-11 | 2003-07-11 | 0d | 60d | 0d | PFM | MSSL |
| 360 | 3.6.1.1.1.2 | PFM Structure Acceptance |  | 3d | 2003-07-15 | 2003-07-17 | 359 | 2003-07-11 | 2003-07-15 | 3d | 60d | 19d | PFM | RAL |
| 361 | 3.6.1.1.1.3 | PFM Thermal Straps Delivery | milestone | 0d | 2003-08-11 | 2003-08-11 | 586 | 2003-07-11 | 2003-07-11 | 0d | 41d | 0d | PFM | MSSL |
| 362 | 3.6.1.1.1.4 | PFM Thermal Straps Acceptance |  | 3d | 2003-08-11 | 2003-08-13 | 361 | 2003-07-11 | 2003-07-15 | 3d | 41d | 0d | PFM | RAL |
| 363 | 3.6.1.1.1.5 | PFM Mirrors Delivery to RAL | milestone | 0d | 2003-08-01 | 2003-08-01 | 587 | 2003-07-11 | 2003-07-11 | 0d | 57d | 0d | PFM | LAM |
| 364 | 3.6.1.1.1.6 | PFM Mirrors Acceptance |  | 3d | 2003-08-01 | 2003-08-05 | 363 | 2003-07-11 | 2003-07-15 | 3d | 57d | 16d | PFM | RAL |
| 365 | 3.6.1.1.1.7 | PFM Cooler Delivery to RAL | milestone | 0d | 2003-08-01 | 2003-08-01 | 588 | 2003-07-11 | 2003-07-11 | 0d | 72d | 0d | PFM | Grenoble |
| 366 | 3.6.1.1.1.8 | PFM Cooler Acceptance |  | 3d | 2003-08-01 | 2003-08-05 | 365 | 2003-07-11 | 2003-07-15 | 3d | 72d | 31d | PFM | RAL |
| 367 | 3.6.1.1.1.9 | PFM Filters, Dichroics and Beamsplitters Delivery to RAL | milestone | 0d | 2003-08-01 | 2003-08-01 | 589 | 2003-10-01 | 2003-10-01 | 0d | 122d | 0d | PFM | QMW |
| 368 | 3.6.1.1.1.10 | PFM Filters, Dichroics and Beamsplitters Acceptance |  | 3d | 2003-08-01 | 2003-08-05 | 367 | 2003-10-01 | 2003-10-03 | 3d | 122d | 94d | PFM | RAL |
| 369 | 3.6.1.1.1.11 | PFM BSMm Delivery to RAL | milestone | 0d | 2003-10-01 | 2003-10-01 | 591 | 2003-10-01 | 2003-10-01 | 0d | 74d | 0d | PFM | ATC |
| 370 | 3.6.1.1.1.12 | PFM BSMm Acceptance |  | 3d | 2003-10-01 | 2003-10-03 | 369 | 2003-10-01 | 2003-10-03 | 3d | 74d | 46d | PFM | RAL |
| 371 | 3.6.1.1.1.13 | PFM SMECm Delivery to RAL | milestone | 0d | 2003-10-01 | 2003-10-01 | 592 | 2003-10-01 | 2003-10-01 | 0d | 71d | 0d | PFM | LAM |
| 372 | 3.6.1.1.1.14 | PFM SMECm Acceptance |  | 3d | 2003-10-01 | 2003-10-03 | 371 | 2003-10-01 | 2003-10-03 | 3d | 71d | 43d | PFM | RAL |
| 373 | 3.6.1.1.1.15 | PFM BDAs Delivery to RAL | milestone | 0d | 2003-10-01 | 2003-10-01 | 590 | 2003-09-20 | 2003-09-20 | 0d | 61d | 0d | PFM | JPL |
| 374 | 3.6.1.1.1.16 | PFM BDAs Acceptance |  | 3d | 2003-10-01 | 2003-10-03 | 373 | 2003-09-22 | 2003-09-24 | 3d | 61d | 20d | PFM | RAL |
| 375 | 3.6.1.1.1.17 | PFM SCAL Delivery to RAL | milestone | 0d | 2003-11-27 | 2003-11-27 | 594 | 2003-10-01 | 2003-10-01 | 0d | 28d | 0d | PFM | QMW |
| 376 | 3.6.1.1.1.18 | PFM SCAL Acceptance |  | 3d | 2003-11-27 | 2003-12-01 | 375 | 2003-10-01 | 2003-10-03 | 3d | 28d | 0d | PFM | RAL |
| 377 | 3.6.1.1.1.19 | PFM Shutter Delivery to RAL | milestone | 0d | 2003-10-01 | 2003-10-01 | 593 | 2003-10-01 | 2003-10-01 | 0d | 77d | 0d | PFM | USK |
| 378 | 3.6.1.1.1.20 | PFM Shutter Acceptance |  | 3d | 2003-10-01 | 2003-10-03 | 377 | 2003-10-01 | 2003-10-03 | 3d | 77d | 49d | PFM | RAL |
| 379 | 3.6.1.1.1.21 | PFM FPU RF Filter Modules Delivery to RAL | milestone | 0d | 2003-10-22 | 2003-10-22 | 595 | 2003-10-01 | 2003-10-01 | 0d | 66d | 0d | PFM | JPL |
| 380 | 3.6.1.1.1.22 | PFM FPU RF Filter Modules Acceptance |  | 3d | 2003-10-22 | 2003-10-24 | 379 | 2003-10-01 | 2003-10-03 | 3d | 66d | 38d | PFM | RAL |
| 381 | 3.6.1.1.2 | Structure Initial Integration |  | 10d | 2003-08-14 | 2003-08-27 | 360, 362 | 2003-07-16 | 2003-07-29 | 10d | 41d | 0d | PFM |  |
| 382 | 3.6.1.1.3 | Mirror/OGSE Integration and Warm Optical Alignment Verification |  | 15d | 2003-08-28 | 2003-09-17 | 381, 364 | 2003-07-30 | 2003-08-19 | 15d | 41d | 0d | PFM |  |
| 383 | 3.6.1.1.4 | Cooler Integration |  | 4d | 2003-09-18 | 2003-09-23 | 382, 366 | 2003-08-20 | 2003-08-25 | 4d | 41d | 0d | PFM |  |
| 384 | 3.6.1.1.5 | Structure Integration Completion |  | 5d | 2003-09-24 | 2003-09-30 | 383 | 2003-08-26 | 2003-09-01 | 5d | 41d | 0d | PFM |  |
| 385 | 3.6.1.1.6 | Integration into Cryostat |  | 2d | 2003-10-01 | 2003-10-02 | 384 | 2003-09-02 | 2003-09-03 | 2d | 41d | 0d | PFM |  |
| 386 | 3.6.1.1.7 | Cooldown |  | 4d | 2003-10-03 | 2003-10-08 | 385 | 2003-09-04 | 2003-09-09 | 4d | 41d | 0d | PFM |  |
| 387 | 3.6.1.1.8 | Cold optical alignment checks |  | 5d | 2003-10-09 | 2003-10-15 | 386 | 2003-09-10 | 2003-09-16 | 5d | 41d | 0d | PFM |  |
| 388 | 3.6.1.1.9 | Thermal Performance Checks |  | 5d | 2003-10-16 | 2003-10-22 | 387 | 2003-09-17 | 2003-09-23 | 5d | 41d | 0d | PFM |  |
| 389 | 3.6.1.1.10 | Warmup |  | 4d | 2003-10-23 | 2003-10-28 | 388 | 2003-09-24 | 2003-09-29 | 4d | 41d | 0d | PFM |  |
| 390 | 3.6.1.1.11 | De-integrate optical/mass dummies |  | 3d | 2003-10-29 | 2003-10-31 | 389 | 2003-09-30 | 2003-10-02 | 3d | 41d | 0d | PFM |  |
| 391 | 3.6.1.1.12 | BDAs Integration and Alignment |  | 8d | 2003-11-03 | 2003-11-12 | 374, 390 | 2003-10-03 | 2003-10-14 | 8d | 41d | 13d | PFM |  |
| 392 | 3.6.1.1.13 | SCAL Integration and Alignment |  | 2d | 2003-12-02 | 2003-12-03 | 376, 391 | 2003-10-15 | 2003-10-16 | 2d | 28d | 0d | PFM |  |
| 393 | 3.6.1.1.14 | SMECm Integration and Aligment |  | 3d | 2003-12-04 | 2003-12-08 | 372, 392 | 2003-10-17 | 2003-10-21 | 3d | 28d | 0d | PFM |  |
| 394 | 3.6.1.1.15 | BSMm Integration and Alignment |  | 3d | 2003-12-09 | 2003-12-11 | 370, 393 | 2003-10-22 | 2003-10-24 | 3d | 28d | 0d | PFM |  |
| 395 | 3.6.1.1.16 | Shutter Integration |  | 2d | 2003-12-12 | 2003-12-15 | 378, 394 | 2003-10-27 | 2003-10-28 | 2d | 28d | 0d | PFM |  |
| 396 | 3.6.1.1.17 | Filters, Dichroics and Beamsplitters Integration |  | 2d | 2003-12-16 | 2003-12-17 | 395, 368 | 2003-10-29 | 2003-10-30 | 2d | 28d | 0d | PFM |  |
| 397 | 3.6.1.1.18 | RF Filter Modules Integration |  | 3d | 2003-12-18 | 2003-12-22 | 380, 396 | 2003-10-31 | 2003-11-04 | 3d | 28d | 0d | PFM |  |
| 398 | 3.6.1.1.19 | Structure Final Integration |  | 1d | 2003-12-23 | 2003-12-23 | 397 | 2003-11-05 | 2003-11-05 | 1d | 28d | 0d | PFM |  |
| 399 | 3.6.1.1.20 | Bakeout |  | 5d | 2003-12-24 | 2004-01-08 | 398 | 2003-11-06 | 2003-11-12 | 5d | 28d | 0d | PFM |  |
| 400 | 3.6.1.1.21 | Final Filter Integration |  | 2d | 2004-01-09 | 2004-01-12 | 399 | 2003-11-13 | 2003-11-14 | 2d | 28d |  | PFM |  |

| ID | WBS | Task | Type | Duration | Start | Finish | Predecessors | Baseline start | Baseline finish | Baseline duration | Total slack | Free slack | Constraint | Text2 | Text1 |
| --- | --- | --- | --- | --- | --- | --- | --- | --- | --- | --- | --- | --- | --- | --- | --- |
| 401 | 3.6.1.2 | **PFM FTB Integration** |  | 13d | 2003-10-22 | 2003-11-07 |  | 2003-10-22 | 2003-11-07 | 13d | 69d | 41d |  | PFM |  |
| 402 | 3.6.1.2.1 | **PFM FTB Subsystem Deliveries** |  | 3d | 2003-10-22 | 2003-10-24 |  | 2003-10-22 | 2003-10-24 | 3d | 69d |  |  | PFM |  |
| 403 | 3.6.1.2.1.1 | PFM FTB Enclosure Delivery to RAL | milestone | 0d | 2003-10-22 | 2003-10-22 | 596 | 2003-10-22 | 2003-10-22 | 0d | 69d | 0d |  | PFM | MSSL |
| 404 | 3.6.1.2.1.2 | PFM FTB Enclosure Acceptance |  | 3d | 2003-10-22 | 2003-10-24 | 403 | 2003-10-22 | 2003-10-24 | 3d | 69d | 0d |  | PFM | RAL |
| 405 | 3.6.1.2.1.3 | PFM FTB RF Filter Modules Delivery | milestone | 0d | 2003-10-22 | 2003-10-22 | 598 | 2003-10-22 | 2003-10-22 | 0d | 74d | 0d |  | PFM | JPL |
| 406 | 3.6.1.2.1.4 | PFM FTB RF Filter Modules Acceptance |  | 3d | 2003-10-22 | 2003-10-24 | 405 | 2003-10-22 | 2003-10-24 | 3d | 74d | 5d |  | PFM | RAL |
| 407 | 3.6.1.2.1.5 | PFM JFET Modules Delivery | milestone | 0d | 2003-10-22 | 2003-10-22 | 597 | 2003-10-22 | 2003-10-22 | 0d | 69d | 0d |  | PFM | JPL |
| 408 | 3.6.1.2.1.6 | PFM JFET Modules Acceptance |  | 3d | 2003-10-22 | 2003-10-24 | 407 | 2003-10-22 | 2003-10-24 | 3d | 69d | 0d |  | PFM | RAL |
| 409 | 3.6.1.2.2 | JFET Module Integration |  | 5d | 2003-10-27 | 2003-10-31 | 404, 408 | 2003-10-27 | 2003-10-31 | 5d | 69d | 0d |  | PFM |  |
| 410 | 3.6.1.2.3 | RF Filter Module Integration |  | 2d | 2003-11-03 | 2003-11-04 | 409, 406 | 2003-11-03 | 2003-11-04 | 2d | 69d | 0d |  | PFM |  |
| 411 | 3.6.1.2.4 | FTB Final Integration |  | 3d | 2003-11-05 | 2003-11-07 | 410 | 2003-11-05 | 2003-11-07 | 3d | 69d |  |  | PFM |  |
| 412 | 3.6.1.3 | **PFM Instrument Integration** |  | 32d | 2004-01-13 | 2004-02-25 |  | 2003-10-01 | 2003-12-04 | 47d | 10d |  | start no earlier than 2003-10-01 | PFM | RAL |
| 413 | 3.6.1.3.1 | QM WE Integration into Test Facility |  | 2w | 2004-02-05 | 2004-02-18 | 346 | 2003-10-01 | 2003-10-14 | 2w | 10d |  |  | PFM | RAL |
| 414 | 3.6.1.3.2 | FPU Integration into Test Cryostat |  | 2d | 2004-01-13 | 2004-01-14 | 357 | 2003-11-17 | 2003-11-18 | 2d | 28d | 0d |  | PFM | RAL |
| 415 | 3.6.1.3.3 | FTB Integration into Test Cryostat and with FPU |  | 2d | 2004-01-15 | 2004-01-16 | 414, 401 | 2003-11-19 | 2003-11-20 | 2d | 28d | 0d |  | PFM | RAL |
| 416 | 3.6.1.3.4 | FPU/FTB Electrical Integration with Cryoharness |  | 5d | 2004-01-19 | 2004-01-23 | 415 | 2003-11-21 | 2003-11-27 | 5d | 28d | 18d |  | PFM | RAL |
| 417 | 3.6.1.3.5 | Warm Functional Tests I |  | 5d | 2004-02-19 | 2004-02-25 | 416, 413 | 2003-11-28 | 2003-12-04 | 5d | 10d |  |  | PFM | RAL |
| 418 | 3.6.2 | PFM Test Readiness Review | milestone | 1d | 2004-02-26 | 2004-02-26 | 356, 345 | 2003-12-05 | 2003-12-05 | 1d | 10d | 0d |  | PFM | RAL |
| 419 | 3.6.3 | **PFM Verification** |  | 66d | 2004-02-27 | 2004-05-28 | 418 | 2003-12-08 | 2004-03-24 | 71d | 10d |  |  | PFM |  |
| 420 | 3.6.3.1 | **PFM Instrument Cold Tests I** |  | 21d | 2004-02-27 | 2004-03-26 |  | 2003-12-08 | 2004-01-14 | 21d | 10d | 0d |  | PFM |  |
| 421 | 3.6.3.1.1 | Cool down |  | 4d | 2004-02-27 | 2004-03-03 |  | 2003-12-08 | 2003-12-11 | 4d | 10d | 0d |  | PFM |  |
| 422 | 3.6.3.1.2 | Interface Checks |  | 2d | 2004-03-04 | 2004-03-05 | 421 | 2003-12-12 | 2003-12-15 | 2d | 10d | 0d |  | PFM |  |
| 423 | 3.6.3.1.3 | Cold Functional Tests I |  | 5d | 2004-03-08 | 2004-03-12 | 422 | 2003-12-16 | 2003-12-22 | 5d | 10d | 0d |  | PFM |  |
| 424 | 3.6.3.1.4 | Pre-vibration Performance Tests |  | 5d | 2004-03-15 | 2004-03-19 | 423 | 2003-12-23 | 2004-01-07 | 5d | 10d | 0d |  | PFM |  |
| 425 | 3.6.3.1.5 | Warm Up |  | 4d | 2004-03-22 | 2004-03-25 | 424 | 2004-01-08 | 2004-01-13 | 4d | 10d | 0d |  | PFM |  |
| 426 | 3.6.3.1.6 | Warm Functional Tests II |  | 1d | 2004-03-26 | 2004-03-26 | 425 | 2004-01-14 | 2004-01-14 | 1d | 10d |  |  | PFM |  |

| ID | WBS | Task | Type | Duration | Start | Finish | Predecessors | Baseline start | Baseline finish | Baseline duration | Total slack | Free slack | Text2 | Text1 |
| --- | --- | --- | --- | --- | --- | --- | --- | --- | --- | --- | --- | --- | --- | --- |
| 427 | 3.6.3.2 | **PFM Cold Vibration** |  | 34d | 2004-03-29 | 2004-05-13 | 420 | 2004-01-15 | 2004-03-09 | 39d | 10d | 0d | PFM |  |
| 428 | 3.6.3.2.1 | FPU/FTB Packing and preparation |  | 5d | 2004-03-29 | 2004-04-02 |  | 2004-01-15 | 2004-01-21 | 5d | 10d | 0d | PFM |  |
| 429 | 3.6.3.2.2 | Ship FPU/FTB to Cold Vibration Facility |  | 2d | 2004-04-05 | 2004-04-06 | 428 | 2004-01-22 | 2004-01-23 | 2d | 10d | 0d | PFM |  |
| 430 | 3.6.3.2.3 | Delivery of FPU/FTB to Cold Vibration Facility | milestone | 0d | 2004-04-06 | 2004-04-06 | 429 | 2004-01-23 | 2004-01-23 | 0d | 10d | 0d | PFM |  |
| 431 | 3.6.3.2.4 | Delivery of FPU/FTB from Cold Vibration Facility | milestone | 0d | 2004-05-04 | 2004-05-04 | 600 | 2004-02-27 | 2004-02-27 | 0d | 10d | 0d | PFM |  |
| 432 | 3.6.3.2.5 | FPU/FTB Integration into Test Cryostat |  | 3d | 2004-05-05 | 2004-05-07 | 431 | 2004-03-01 | 2004-03-03 | 3d | 10d | 0d | PFM |  |
| 433 | 3.6.3.2.6 | FPU/FTB Integration with Cryoharness |  | 3d | 2004-05-10 | 2004-05-12 | 432 | 2004-03-04 | 2004-03-08 | 3d | 10d | 0d | PFM |  |
| 434 | 3.6.3.2.7 | Warm Functional Tests III |  | 1d | 2004-05-13 | 2004-05-13 | 433 | 2004-03-09 | 2004-03-09 | 1d | 10d |  | PFM |  |
| 435 | 3.6.3.3 | **PFM Instrument Cold Tests II** |  | 11d | 2004-05-14 | 2004-05-28 | 427 | 2004-03-10 | 2004-03-24 | 11d | 10d |  | PFM |  |
| 436 | 3.6.3.3.1 | Cool Down |  | 3d | 2004-05-14 | 2004-05-18 |  | 2004-03-10 | 2004-03-12 | 3d | 10d | 0d | PFM |  |
| 437 | 3.6.3.3.2 | Cold Functional Tests II |  | 3d | 2004-05-19 | 2004-05-21 | 436 | 2004-03-15 | 2004-03-17 | 3d | 10d | 0d | PFM |  |
| 438 | 3.6.3.3.3 | Post-vibration Performance Tests |  | 5d | 2004-05-24 | 2004-05-28 | 437 | 2004-03-18 | 2004-03-24 | 5d | 10d |  | PFM |  |
| 439 | 3.6.4 | **PFM Warm Electronics Integration** |  | 117d | 2004-03-01 | 2004-08-10 |  | 2004-03-01 | 2004-03-17 | 13d | -42d | 0d | PFM | RAL |
| 440 | 3.6.4.1 | PFM DPU Delivery to RAL | milestone | 0d | 2004-03-01 | 2004-03-01 | 601 | 2004-03-01 | 2004-03-01 | 0d | 62d | 0d | PFM | IFSI |
| 441 | 3.6.4.2 | PFM DPU Acceptance |  | 3d | 2004-03-01 | 2004-03-03 | 440 | 2004-03-01 | 2004-03-03 | 3d | 62d | 0d | PFM | RAL |
| 442 | 3.6.4.3 | PFM DPU Verification |  | 1w | 2004-03-04 | 2004-03-10 | 441 | 2004-03-04 | 2004-03-10 | 1w | 62d | 6d | PFM | RAL |
| 443 | 3.6.4.4 | PFM DRCU Delivery to RAL | milestone | 0d | 2004-07-30 | 2004-07-30 | 602 | 2004-03-01 | 2004-03-01 | 0d | -42d | 0d | PFM | SAp |
| 444 | 3.6.4.5 | PFM DRCU Acceptance |  | 3d | 2004-07-30 | 2004-08-03 | 443 | 2004-03-01 | 2004-03-03 | 3d | -42d | 0d | PFM | RAL |
| 445 | 3.6.4.6 | PFM WIH Delivery to RAL | milestone | 0d | 2004-07-30 | 2004-07-30 | 603 | 2004-03-01 | 2004-03-01 | 0d | -42d | 0d | PFM | SAp |
| 446 | 3.6.4.7 | PFM WIH Acceptance |  | 3d | 2004-07-30 | 2004-08-03 | 445 | 2004-03-01 | 2004-03-03 | 3d | -42d | 0d | PFM | RAL |
| 447 | 3.6.4.8 | PFM DRCU Verification |  | 1w | 2004-08-04 | 2004-08-10 | 446, 444, 442 | 2004-03-11 | 2004-03-17 | 1w | -42d | 0d | PFM | RAL |
| 448 | 3.6.4.9 | PFM WE Available for PFM Calibration | milestone | 0d | 2004-08-10 | 2004-08-10 | 447 | 2004-03-17 | 2004-03-17 | 0d | -42d | 0d | PFM | RAL |
| 449 | 3.6.5 | **PFM Instrument Calibration** |  | 46d | 2004-08-11 | 2004-10-13 | 439, 419 | 2004-03-25 | 2004-05-27 | 46d | -42d | 0d | PFM |  |
| 450 | 3.6.5.1 | Integrate PFM WE into Test Facility |  | 2d | 2004-08-11 | 2004-08-12 |  | 2004-03-25 | 2004-03-26 | 2d | -42d | 0d | PFM | RAL |
| 451 | 3.6.5.2 | Cold Functional Tests III |  | 2d | 2004-08-13 | 2004-08-16 | 450 | 2004-03-29 | 2004-03-30 | 2d | -42d | 0d |  |  |
| 452 | 3.6.5.3 | Warm Electronics Thermal Range Tests |  | 5d | 2004-08-17 | 2004-08-23 | 451 | 2004-03-31 | 2004-04-06 | 5d | -42d | 0d | PFM |  |
| 453 | 3.6.5.4 | Calibration |  | 30d | 2004-08-24 | 2004-10-04 | 452 | 2004-04-07 | 2004-05-18 | 30d | -42d | 0d | PFM |  |
| 454 | 3.6.5.5 | Cold Functional Test IV |  | 3d | 2004-10-05 | 2004-10-07 | 453 | 2004-05-19 | 2004-05-21 | 3d | -42d | 0d | PFM |  |
| 455 | 3.6.5.6 | Warm Up |  | 4d | 2004-10-08 | 2004-10-13 | 454 | 2004-05-24 | 2004-05-27 | 4d | -42d | 0d | PFM |  |

| ID | WBS | Task | Type | Duration | Start | Finish | Predecessors | Baseline start | Baseline finish | Baseline duration | Total slack | Free slack | Constraint | Text2 | Text1 |
| --- | --- | --- | --- | --- | --- | --- | --- | --- | --- | --- | --- | --- | --- | --- | --- |
| 456 | 3.6.6 | **PFM Delivery Preparation** |  | 12d | 2004-10-14 | 2004-10-29 | 449 | 2004-05-28 | 2004-06-14 | 12d | -42d | 0d |  | PFM |  |
| 457 | 3.6.6.1 | Warm Functional Test III |  | 1d | 2004-10-14 | 2004-10-14 |  | 2004-05-28 | 2004-05-28 | 1d | -35d | 0d |  | PFM |  |
| 458 | 3.6.6.2 | Mass properties Measurement |  | 2d | 2004-10-15 | 2004-10-18 | 457 | 2004-05-31 | 2004-06-01 | 2d | -35d | 0d |  | PFM |  |
| 459 | 3.6.6.3 | Packing and shipment |  | 2d | 2004-10-19 | 2004-10-20 | 458 | 2004-06-02 | 2004-06-03 | 2d | -35d | 0d |  | PFM |  |
| 460 | 3.6.6.4 | Preparation of Delivery Data Package |  | 2w | 2004-10-14 | 2004-10-27 |  | 2004-05-28 | 2004-06-10 | 2w | -42d | 0d |  | PFM |  |
| 461 | 3.6.6.5 | PFM Readiness Review | milestone | 2d | 2004-10-28 | 2004-10-29 | 460 | 2004-06-11 | 2004-06-14 | 2d | -42d | 0d |  | PFM |  |
| 462 | 3.6.7 | Delivery of PFM to ESA | milestone | 0d | 2004-10-29 | 2004-10-29 | 456 | 2004-06-14 | 2004-06-14 | 0d | -42d | 0d |  | PFM |  |
| 463 | 3.7 | **Flight Spare Model** |  | 381d | 2004-06-01 | 2005-11-29 |  | 1997-07-01 | 2005-09-29 | 2119d | 18d |  |  | FS |  |
| 464 | 3.7.1 | Return of CQM to RAL | milestone | 0d | 2004-06-01 | 2004-06-01 |  |  |  |  | 18d | 0d | start no earlier than 2004-06-01 |  |  |
| 465 | 3.7.2 | Refurbishment of CQM Subsystems |  | 30w | 2004-06-01 | 2005-01-10 | 464 |  |  |  | 18d | 0d |  |  |  |
| 466 | 3.7.3 | **FS Integration** |  | 105d | 2005-01-10 | 2005-06-06 | 465 | 1997-07-01 | 2005-03-17 | 1979d | 18d | 0d |  | FS |  |
| 467 | 3.7.3.1 | FPU Integration |  | 105d | 2005-01-11 | 2005-06-06 |  | 1997-07-01 | 2005-02-11 | 1955d | 18d |  |  |  |  |
| 468 | 3.7.3.2 | **Warm Electronics Integration** |  | 23d | 2005-01-10 | 2005-02-10 |  | 2004-03-26 | 2005-03-17 | 244d | 100d | 82d |  | FS |  |
| 469 | 3.7.3.2.1 | QM DPU Available for FS Assembly | milestone | 0d | 2005-01-10 | 2005-01-10 | 450 | 2004-03-26 | 2004-03-26 | 0d | 118d | 0d |  | FS | RAL |
| 470 | 3.7.3.2.2 | Pack and Ship QM DPU to IFSI |  | 1w | 2005-01-11 | 2005-01-17 | 469 | 2004-03-29 | 2004-04-02 | 1w | 118d | 0d |  | FS | RAL |
| 471 | 3.7.3.2.3 | Delivery of QM DPU to IFSI | milestone | 0d | 2005-01-17 | 2005-01-17 | 470 | 2004-04-02 | 2004-04-02 | 0d | 118d | 0d |  | FS | RAL |
| 472 | 3.7.3.2.4 | QM2 DRCU Available for FS Assembly | milestone | 0d | 2005-01-10 | 2005-01-10 | 450 | 2004-03-26 | 2004-03-26 | 0d | 118d | 0d |  | FS | RAL |
| 473 | 3.7.3.2.5 | Pack and Ship QM2 DRCU to Sap |  | 1w | 2005-01-11 | 2005-01-17 | 472 | 2004-03-29 | 2004-04-02 | 1w | 118d | 0d |  | FS | RAL |
| 474 | 3.7.3.2.6 | Delivery of QM2 DRCU to Sap | milestone | 0d | 2005-01-17 | 2005-01-17 | 473 | 2004-04-02 | 2004-04-02 | 0d | 118d | 0d |  | FS | RAL |
| 475 | 3.7.3.2.7 | FS DPU Delivery to RAL | milestone | 0d | 2005-01-10 | 2005-01-10 | 618 | 2004-09-23 | 2004-09-23 | 0d | 100d | 0d |  | FS | IFSI |
| 476 | 3.7.3.2.8 | FS DPU Acceptance |  | 3d | 2005-01-11 | 2005-01-13 | 475 | 2004-09-24 | 2004-09-28 | 3d | 100d | 0d |  | FS | RAL |
| 477 | 3.7.3.2.9 | FS DRCU Delivery to RAL | milestone | 0d | 2005-01-10 | 2005-01-10 | 619 | 2005-02-14 | 2005-02-14 | 0d | 100d | 0d |  | FS | SAp |
| 478 | 3.7.3.2.10 | FS DRCU Acceptance |  | 3d | 2005-01-11 | 2005-01-13 | 477 | 2005-02-15 | 2005-02-17 | 3d | 100d | 0d |  |  |  |
| 479 | 3.7.3.2.11 | FS WE Integration and Test |  | 4w | 2005-01-14 | 2005-02-10 | 476, 478 | 2005-02-18 | 2005-03-17 | 4w | 100d | 82d |  |  |  |
| 480 | 3.7.4 | FS Test Readiness Review | milestone | 0d | 2005-06-06 | 2005-06-06 | 466 | 2005-02-11 | 2005-02-11 | 0d | 18d | 0d |  | FS |  |
| 481 | 3.7.5 | FS Verification |  | 66d | 2005-06-07 | 2005-09-06 | 480, 479, 468 | 2005-03-18 | 2005-07-27 | 18.8w | 18d | 0d |  | FS |  |
| 482 | 3.7.6 | FS Calibration |  | 46d | 2005-09-07 | 2005-11-09 | 481 | 2005-07-28 | 2005-09-09 | 6.4w | 18d | 0d |  | FS | RAL |

| ID | WBS | Task | Type | Duration | Start | Finish | Predecessors | Baseline start | Baseline finish | Baseline duration | Total slack | Free slack | Constraint | Text1 | Text2 |
| --- | --- | --- | --- | --- | --- | --- | --- | --- | --- | --- | --- | --- | --- | --- | --- |
| 483 | 2.3.3.3 | **FS Delivery** |  | 14d | 2005-11-10 | 2005-11-29 | 482 | 2005-09-12 | 2005-09-29 | 14d | 18d |  |  | RAL | FS |
| 484 | 3.7.7.1 | Warm up |  | 3d | 2005-11-10 | 2005-11-14 |  | 2005-09-12 | 2005-09-14 | 3d | 18d | 0d |  |  |  |
| 485 | 3.7.7.2 | Warm Functional Test |  | 2d | 2005-11-15 | 2005-11-16 | 484 | 2005-09-15 | 2005-09-16 | 2d | 18d | 0d |  |  |  |
| 486 | 3.7.7.3 | Mass Properties Measurement |  | 2d | 2005-11-17 | 2005-11-18 | 485 | 2005-09-19 | 2005-09-20 | 2d | 18d | 0d |  |  |  |
| 487 | 3.7.7.4 | Packing and Shipment |  | 1w | 2005-11-21 | 2005-11-25 | 486 | 2005-09-21 | 2005-09-27 | 1w | 18d | 0d |  |  |  |
| 488 | 3.7.7.5 | Preparation of Delivery Data Package |  | 2w | 2005-11-10 | 2005-11-23 |  | 2005-09-12 | 2005-09-23 | 2w | 20d | 2d |  |  |  |
| 489 | 3.7.7.6 | FS Readiness Review | milestone | 2d | 2005-11-28 | 2005-11-29 | 488, 487 | 2005-09-28 | 2005-09-29 | 2d | 18d | 0d |  | RAL | FS |
| 490 | 3.7.8 | FS Delivery to ESA | milestone | 0d | 2005-11-29 | 2005-11-29 | 489 | 2005-09-29 | 2005-09-29 | 0d | 18d |  |  | RAL | FS |
| 491 | 4 | **Major Milestones** |  | 2180d | 1997-07-01 | 2006-01-01 |  | 1997-07-01 | 2005-02-14 | 1956d | 310d |  |  |  | MS |
| 492 | 4.1 | Detector Selection | milestone | 0d | 1997-07-01 | 1997-07-01 |  | 1997-07-01 | 1997-07-01 | 0d | 2490d |  |  |  | MS |
| 493 | 4.2 | Cooler STM Delivery to RAL | milestone | 0d | 1997-07-01 | 1997-07-01 |  | 1997-07-01 | 1997-07-01 | 0d | 2490d |  |  | Grenoble | MS |
| 494 | 4.3 | Shutter STM Delivery to RAL | milestone | 0d | 1997-07-01 | 1997-07-01 |  | 1997-07-01 | 1997-07-01 | 0d | 2490d |  |  | USK | MS |
| 495 | 4.4 | Spectrometer Calibration Source STM Delivery to RAL | milestone | 0d | 1997-07-01 | 1997-07-01 |  | 1997-07-01 | 1997-07-01 | 0d | 2490d |  |  | QMW | MS |
| 496 | 4.5 | CQM RF Filter Modules Delivery to RAL | milestone | 0d | 1997-07-01 | 1997-07-01 |  | 1997-07-01 | 1997-07-01 | 0d | 2490d |  |  |  | MS |
| 497 | 4.6 | Deliver Simulink Model to LAM | milestone | 0d | 1997-07-01 | 1997-07-01 |  | 2000-08-11 | 2000-08-11 | 0d | 2490d |  |  | ATC | MS |
| 498 | 4.7 | Deliver Analogue Board Design Doc to LAM | milestone | 0d | 1997-07-01 | 1997-07-01 |  | 2000-08-11 | 2000-08-11 | 0d | 2490d |  |  | ATC | MS |
| 499 | 4.8 | Deliver Prototype2 to LAM | milestone | 0d | 1997-07-01 | 1997-07-01 |  | 2000-09-13 | 2000-09-13 | 0d | 2490d |  |  | ATC | MS |
| 500 | 4.9 | Deliver Analogue Board Detailed Design to LAM | milestone | 0d | 1997-07-01 | 1997-07-01 |  | 2000-09-22 | 2000-09-22 | 0d | 2490d |  |  | ATC | MS |
| 501 | 4.10 | Delta PDR | milestone | 2d | 2000-06-26 | 2000-06-27 |  | 2000-06-26 | 2000-06-27 | 2d | 0d |  | must start on 2000-06-26 | RAL | MS |
| 502 | 4.11 | Instrument Interface Review | milestone | 2d | 2000-11-28 | 2000-11-29 |  | 2000-11-28 | 2000-11-29 | 2d | 0d |  | must start on 2000-11-28 | RAL | MS |
| 503 | 4.12 | Structure, Optics, Cooler Detailed Design Review | milestone | 3d | 1997-07-01 | 1997-07-03 |  | 2001-03-19 | 2001-03-21 | 3d | 2487d |  |  |  | MS |
| 504 | 4.13 | SMEC, BSM Detailed Design Review | milestone | 0d | 1997-07-01 | 1997-07-01 |  | 2001-01-22 | 2001-01-22 | 0d | 2490d |  |  |  | MS |
| 505 | 4.14 | Shutter Detailed Design review | milestone | 1d | 1997-07-01 | 1997-07-01 |  | 2001-05-02 | 2001-05-02 | 1d | 2489d |  |  |  |  |
| 506 | 4.15 | WE Detailed Design Review | milestone | 3d | 2001-02-01 | 2001-02-05 |  | 2001-02-01 | 2001-02-05 | 3d | 0d |  | must start on 2001-02-01 |  | MS |
| 507 | 4.16 | Delivery of SCOS2000 v2.1 | milestone | 0w | 2001-01-01 | 2001-01-01 |  | 2001-01-01 | 2001-01-01 | 0w | 0d |  | must start on 2001-01-01 |  |  |
| 508 | 4.17 | Delivery of TM/TC Interface | milestone | 0w | 2001-03-01 | 2001-03-01 |  | 2001-03-01 | 2001-03-01 | 0w | 0d |  | must start on 2001-03-01 |  |  |
| 509 | 4.18 | Delivery of CDMS Simulator to IFSI | milestone | 0w | 2001-05-15 | 2001-05-15 |  | 2001-05-15 | 2001-05-15 | 0w | 0d |  | must start on 2001-05-15 |  |  |
| 510 | 4.19 | Delivery of Test Control from MPE | milestone | 0w | 2001-06-01 | 2001-06-01 |  | 2001-06-01 | 2001-06-01 | 0w | 0d |  | must start on 2001-06-01 |  |  |
| 511 | 4.20 | Delivery of MIB and Test Procedures to IFSI | milestone | 0w | 2001-07-01 | 2001-07-01 |  | 2001-07-01 | 2001-07-01 | 0w | 0d |  | must start on 2001-07-01 |  |  |
| 512 | 4.21 | Delivery of TEI from SRON | milestone | 0w | 2002-03-01 | 2002-03-01 |  | 2002-03-01 | 2002-03-01 | 0w | 0d |  | must start on 2002-03-01 |  |  |
| 513 | 4.22 | Deliver DM2 to LAM | milestone | 0d | 1997-07-01 | 1997-07-01 |  | 2001-03-30 | 2001-03-30 | 0d | 2490d |  |  | ATC | MS |
| 514 | 4.23 | CQM BSMm Delivery to LAM | milestone | 0d | 1997-07-01 | 1997-07-01 |  | 2002-03-13 | 2002-03-13 | 0d | 2490d |  |  | ATC | MS |
| 515 | 4.24 | CQM Arrays First Delivery to QMW | milestone | 0d | 1997-07-01 | 1997-07-01 |  | 1997-07-01 | 1997-07-01 | 0d | 2490d |  |  | JPL | MS |
| 516 | 4.25 | CQM Sparse Arrays Delivery to QMW | milestone | 0d | 1997-07-01 | 1997-07-01 |  | 1997-07-01 | 1997-07-01 | 0d | 2490d |  |  | JPL | MS |
| 517 | 4.26 | CQM JFET Modules Delivery to RAL | milestone | 0d | 1997-07-01 | 1997-07-01 |  | 2002-01-17 | 2002-01-17 | 0d | 2490d |  |  |  | MS |
| 518 | 4.27 | SMECm Simulator Delivery to SAp | milestone | 0d | 1997-07-01 | 1997-07-01 |  | 2001-02-20 | 2001-02-20 | 0d | 2490d |  |  | LAM | MS |
| 519 | 4.28 | MCU EM Delivery to Sap | milestone | 0d | 1997-07-01 | 1997-07-01 |  | 2001-09-21 | 2001-09-21 | 0d | 2490d |  |  | LAM | MS |
| 520 | 4.29 | QM1 MCU delivery to Sap | milestone | 0d | 1997-07-01 | 1997-07-01 |  | 2001-09-21 | 2001-09-21 | 0d | 2490d |  |  | LAM | MS |
| 521 | 4.30 | QM2 MCU Delivery to SAp | milestone | 0d | 1997-07-01 | 1997-07-01 |  | 2002-07-10 | 2002-07-10 | 0d | 2490d |  |  | LAM | MS |
| 522 | 4.31 | CQM Structure Delivery to RAL | milestone | 0d | 2002-08-13 | 2002-08-13 |  | 2002-07-01 | 2002-07-01 | 0d | 0d |  | must start on 2002-08-13 | MSSL | MS |
| 523 | 4.32 | CQM Thermal Straps Delivery to RAL | milestone | 0d | 2002-09-13 | 2002-09-13 |  | 2002-07-01 | 2002-07-01 | 0d | 0d |  | must start on 2002-09-13 | MSSL | MS |
| 524 | 4.33 | CQM Mirrors + OGSE Delivery to RAL | milestone | 0d | 2002-07-01 | 2002-07-01 |  | 2002-07-01 | 2002-07-01 | 0d | 0d |  | must start on 2002-07-01 | LAM | MS |
| 525 | 4.34 | STM Filters, Dichroics, Beamsplitters and OGSE Delivery to RAL | milestone | 0d | 2002-07-01 | 2002-07-01 |  | 2002-07-01 | 2002-07-01 | 0d | 0d |  | must start on 2002-07-01 | QMW | MS |
| 526 | 4.35 | STM BSMm Delivery to RAL | milestone | 0d | 2002-07-01 | 2002-07-01 |  | 2002-07-01 | 2002-07-01 | 0d | 0d |  | must start on 2002-07-01 | ATC | MS |
| 527 | 4.36 | CQM BSM Harness Delivery to RAL | milestone | 0d | 2002-07-01 | 2002-07-01 |  |  |  |  | 0d |  | must start on 2002-07-01 |  |  |
| 528 | 4.37 | Optical Dummy SMECm Delivery to RAL | milestone | 0d | 2002-07-01 | 2002-07-01 |  | 2002-07-01 | 2002-07-01 | 0d | 0d |  | must start on 2002-07-01 | LAM | MS |
| 529 | 4.38 | FOB Simulator Available | milestone | 0d | 2002-07-01 | 2002-07-01 |  | 2002-07-01 | 2002-07-01 | 0d | 0d |  | must start on 2002-07-01 |  |  |
| 530 | 4.39 | STM Cooler Delivery to RAL | milestone | 0d | 2002-08-01 | 2002-08-01 |  | 2002-07-01 | 2002-07-01 | 0d | 0d |  | must start on 2002-08-01 | Grenoble | MS |
| 531 | 4.40 | CQM Cooler Harness Delivery to RAL | milestone | 0d | 2002-08-01 | 2002-08-01 |  |  |  |  | 0d |  | must start on 2002-08-01 |  |  |
| 532 | 4.41 | STM BDAs Delivery to RAL | milestone | 0d | 2002-08-01 | 2002-08-01 |  | 2002-04-01 | 2002-04-01 | 0d | 0d |  | must start on 2002-08-01 | JPL | MS |
| 533 | 4.42 | CQM BDAs Harness Delivery to RAL | milestone | 0d | 2002-08-01 | 2002-08-01 |  |  |  |  | 0d |  | must start on 2002-08-01 |  |  |
| 534 | 4.43 | STM Shutter Delivery to RAL | milestone | 0d | 2002-08-01 | 2002-08-01 |  | 2002-04-10 | 2002-04-10 | 0d | 0d |  | must start on 2002-08-01 | USK | MS |
| 535 | 4.44 | CQM Shutter Harness Delivery to RAL | milestone | 0d | 2002-08-01 | 2002-08-01 |  |  |  |  | 0d |  | must start on 2002-08-01 |  |  |
| 536 | 4.45 | STM SCAL Delivery to RAL | milestone | 0d | 2002-08-01 | 2002-08-01 |  | 2002-04-10 | 2002-04-10 | 0d | 0d |  | must start on 2002-08-01 | QMW | MS |
| 537 | 4.46 | STM SCAL Harness Delivery to RAL | milestone | 0d | 2002-08-01 | 2002-08-01 |  |  |  |  | 0d |  | must start on 2002-08-01 |  |  |
| 538 | 4.47 | STM SMECm Delivery to RAL | milestone | 0d | 2002-08-01 | 2002-08-01 |  | 2002-07-01 | 2002-07-01 | 0d | 0d |  | must start on 2002-08-01 |  |  |
| 539 | 4.48 | STM SMECm Harness Delivery to RAL | milestone | 0d | 2002-08-01 | 2002-08-01 |  |  |  |  | 0d |  | must start on 2002-08-01 |  |  |
| 540 | 4.49 | CQM FPU RF FIlter Modules Delivery to RAL | milestone | 0d | 2002-08-01 | 2002-08-01 |  | 2002-07-01 | 2002-07-01 | 0d | 0d |  | must start on 2002-08-01 | JPL | MS |
| 541 | 4.50 | CQM Cooler Delivery to RAL | milestone | 0d | 2002-09-01 | 2002-09-01 |  | 2002-07-01 | 2002-07-01 | 0d | 0d |  | must start on 2002-09-01 |  |  |
| 542 | 4.51 | CQM FTB Enclosure Delivery to RAL | milestone | 0d | 2002-08-01 | 2002-08-01 |  | 2002-04-01 | 2002-04-01 | 0d | 0d |  | must start on 2002-08-01 | MSSL | MS |
| 543 | 4.52 | STM JFET Modules Delivery to RAL | milestone | 0d | 2002-08-01 | 2002-08-01 |  | 2002-04-01 | 2002-04-01 | 0d | 0d |  | must start on 2002-08-01 | JPL | MS |
| 544 | 4.53 | STM FTB RF Filter Modules Delivery to RAL | milestone | 0d | 2002-08-01 | 2002-08-01 |  | 2002-04-01 | 2002-04-01 | 0d | 0d |  | must start on 2002-08-01 | JPL | MS |
| 545 | 4.54 | STM Performance Confirmation Review | milestone | 2d | 2002-11-01 | 2002-11-04 |  | 2002-11-01 | 2002-11-04 | 2d | 0d |  | must start on 2002-11-01 |  | MS |
| 546 | 4.55 | Test Facility Available | milestone | 0d | 2002-11-01 | 2002-11-01 |  |  |  |  | 0d |  | must start on 2002-11-01 |  |  |
| 547 | 4.56 | CQM PCAL Delivery to ATC | milestone | 0d | 1997-07-01 | 1997-07-01 |  | 2001-10-18 | 2001-10-18 | 0d | 2490d |  |  | QMW | MS |
| 548 | 4.57 | STM Test Review | milestone | 0d | 1997-07-01 | 1997-07-01 |  | 1997-07-01 | 1997-07-01 | 0d | 2490d |  |  |  | MS |
| 549 | 4.58 | CQM Filters Dichroics and Beamsplitters Delivery to RAL | milestone | 0d | 2003-02-21 | 2003-02-21 |  | 2002-12-20 | 2002-12-20 | 0d | 0d |  | must start on 2003-02-21 | QMW | MS |
| 550 | 4.59 | CQM BDAs Delivery to RAL | milestone | 0d | 2003-01-11 | 2003-01-11 |  | 2002-12-20 | 2002-12-20 | 0d | 0d |  | must start on 2003-01-11 | JPL | MS |
| 551 | 4.60 | CQM SMECm Delivery to RAL | milestone | 0d | 2003-01-11 | 2003-01-11 |  | 2002-12-20 | 2002-12-20 | 0d | 0d |  | must start on 2003-01-11 | LAM | MS |
| 552 | 4.61 | CQM SCAL Delivery to RAL | milestone | 0d | 2003-01-11 | 2003-01-11 |  | 2002-12-20 | 2002-12-20 | 0d | 0d |  | must start on 2003-01-11 | QMW | MS |

| ID | WBS | Task | Type | Duration | Start | Finish | Predecessors | Baseline start | Baseline finish | Baseline duration | Total slack | Free slack | Constraint | Text1 | Text2 |
| --- | --- | --- | --- | --- | --- | --- | --- | --- | --- | --- | --- | --- | --- | --- | --- |
| 553 | 4.62 | CQM Shutter Delivery to RAL | milestone | 0d | 2003-01-11 | 2003-01-11 |  | 2002-12-20 | 2002-12-20 | 0d | 0d |  | must start on 2003-01-11 | USK | MS |
| 554 | 4.63 | CQM BSMm Delivery to RAL | milestone | 0d | 2003-01-11 | 2003-01-11 |  | 2002-12-20 | 2002-12-20 | 0d | 0d |  | must start on 2003-01-11 | ATC | MS |
| 555 | 4.64 | CQM FPU RF Filter Modules Delivery to RAL | milestone | 0d | 2003-01-11 | 2003-01-11 |  | 2002-12-20 | 2002-12-20 | 0d | 0d |  | must start on 2003-01-11 |  |  |
| 556 | 4.65 | CQM JFET Modules Delivery to RAL | milestone | 0d | 2003-02-01 | 2003-02-01 |  | 2002-12-20 | 2002-12-20 | 0d | 0d |  | must start on 2003-02-01 | JPL | MS |
| 557 | 4.66 | CQM FTB RF Filter Modules Delivery to RAL | milestone | 0d | 2003-02-01 | 2003-02-01 |  | 2002-12-20 | 2002-12-20 | 0d | 0d |  | must start on 2003-02-01 | JPL | MS |
| 558 | 4.67 | EGSE#1 Delivery to IFSI | milestone | 0d | 2001-07-01 | 2001-07-01 |  | 2001-07-01 | 2001-07-01 | 0d | 0d |  | must start on 2001-07-01 | PACS | MS |
| 559 | 4.68 | DRCU Simulator#1 Delivery to IFSI | milestone | 0d | 1997-07-01 | 1997-07-01 |  | 2001-05-01 | 2001-05-01 | 0d | 2490d |  |  | SO | MS |
| 560 | 4.69 | AVM DPU Delivery to RAL | milestone | 0d | 2002-06-01 | 2002-06-01 |  | 2002-06-01 | 2002-06-01 | 0d | 0d |  | must start on 2002-06-01 | IFSI | MS |
| 561 | 4.70 | DRCU Simulator#2 Delivery to RAL | milestone | 0d | 2002-06-01 | 2002-06-01 |  | 2002-06-01 | 2002-06-01 | 0d | 0d |  | must start on 2002-06-01 | SO | MS |
| 562 | 4.71 | EGSE#2 Available | milestone | 0d | 2002-06-01 | 2002-06-01 |  | 2002-08-01 | 2002-08-01 | 0d | 0d |  | must start on 2002-06-01 | RAL | MS |
| 563 | 4.72 | QM1 DRCU Delivery to RAL | milestone | 0d | 2003-03-03 | 2003-03-03 |  | 2002-07-01 | 2002-07-01 | 0d | 0d |  | must start on 2003-03-03 | SAp | MS |
| 564 | 4.73 | QM1 WIH Delivery to RAL | milestone | 0d | 2003-03-03 | 2003-03-03 |  | 2002-07-01 | 2002-07-01 | 0d | 0d |  | must start on 2003-03-03 | SAp | MS |
| 565 | 4.74 | FPU Simulator#1 Delivery to RAL | milestone | 0d | 2002-12-01 | 2002-12-01 |  | 2002-06-01 | 2002-06-01 | 0d | 0d |  | must start on 2002-12-01 | SAp | MS |
| 566 | 4.75 | EGSE#3 Available | milestone | 0d | 2002-12-01 | 2002-12-01 |  | 2002-08-01 | 2002-08-01 | 0d | 0d |  | must start on 2002-12-01 | RAL | MS |
| 567 | 4.76 | PFM BDA Delivery to RAL | milestone | 0d | 2003-04-01 | 2003-04-01 |  | 2003-02-01 | 2003-02-01 | 0d | 0d |  | must start on 2003-04-01 |  |  |
| 568 | 4.77 | OBS Maintenance Facility Delivery to RAL | milestone | 0w | 2002-06-01 | 2002-06-01 |  | 2002-06-01 | 2002-06-01 | 0w | 0d |  | must start on 2002-06-01 |  |  |
| 569 | 4.78 | Test Cryostat Commissioned | milestone | 0d | 2002-08-01 | 2002-08-01 |  | 2002-07-01 | 2002-07-01 | 0d | 0d |  | must start on 2002-08-01 | RAL | MS |
| 570 | 4.79 | Delivery of CQM FPU to Cold Vibration Facility | milestone | 0d | 1997-07-01 | 1997-07-01 |  | 1997-07-01 | 1997-07-01 | 0d | 2470d | 0d |  | RAL | MS |
| 571 | 4.80 | Delivery of Cold-Vibrated CQM FPU to RAL | milestone | 0d | 1997-07-28 | 1997-07-28 | 570FS+4w | 1997-07-28 | 1997-07-28 | 0d | 2470d |  |  | RAL | MS |
| 572 | 4.81 | Critical Design Reviews | milestone | 0d | 1997-07-01 | 1997-07-01 |  | 2003-03-01 | 2003-03-01 | 0d | 2490d |  |  |  | MS |
| 573 | 4.82 | CQM Delivery to ESA | milestone | 0d | 2003-10-01 | 2003-10-01 | 345 | 2003-04-01 | 2003-04-01 | 0d | 0d |  | must start on 2003-10-01 | RAL | MS |
| 574 | 4.83 | QM DPU Delivery to RAL | milestone | 0d | 2003-02-01 | 2003-02-01 |  | 2003-01-01 | 2003-01-01 | 0d | 0d |  | must start on 2003-02-01 | IFSI | MS |
| 575 | 4.84 | EGSE#4 Available | milestone | 0d | 2003-02-01 | 2003-02-01 |  |  |  |  | 0d |  | must start on 2003-02-01 |  |  |
| 576 | 4.85 | DRCU Simulator#3 to RAL | milestone | 0d | 2003-02-01 | 2003-02-01 |  | 2003-01-01 | 2003-01-01 | 0d | 0d |  | must start on 2003-02-01 | SO | MS |
| 577 | 4.86 | QM2 DRCU Delivery to RAL | milestone | 0d | 2004-01-05 | 2004-01-05 |  | 2003-01-20 | 2003-01-20 | 0d | 0d |  | must start on 2004-01-05 | SAp | MS |
| 578 | 4.87 | QM2 WIH Delivery to RAL | milestone | 0d | 2004-01-05 | 2004-01-05 |  | 2003-01-20 | 2003-01-20 | 0d | 0d |  | must start on 2004-01-05 | SAp | MS |
| 579 | 4.88 | FPU Simulator#2 Delivery to RAL | milestone | 0d | 2003-06-01 | 2003-06-01 |  | 2003-01-20 | 2003-01-20 | 0d | 0d |  | must start on 2003-06-01 | SAp | MS |
| 580 | 4.89 | WE Critical Design Review | milestone | 0d | 2004-02-04 | 2004-02-04 | 354 | 2003-03-05 | 2003-03-05 | 0d | 792d |  |  |  | MS |
| 581 | 4.90 | AVM Delivery to ESA | milestone | 0d | 2003-06-01 | 2003-06-01 | 96 | 2003-04-01 | 2003-04-01 | 0d | 0d |  | must finish on 2003-06-01 | RAL | MS |
| 582 | 4.91 | PFM BSMm Delivery to LAM | milestone | 0d | 1997-07-01 | 1997-07-01 |  | 2003-10-07 | 2003-10-07 | 0d | 2490d |  |  | ATC | MS |
| 583 | 4.92 | PFM MCU Delivery to SAp | milestone | 0d | 1997-07-01 | 1997-07-01 |  | 2003-07-18 | 2003-07-18 | 0d | 2490d |  |  | LAM | MS |
| 584 | 4.93 | PFM PCAL Delivery to ATC | milestone | 0d | 1997-07-01 | 1997-07-01 |  | 2003-07-22 | 2003-07-22 | 0d | 2490d |  |  | QMW | MS |
| 585 | 4.94 | PFM Structure Delivery to RAL | milestone | 0d | 2003-07-15 | 2003-07-15 |  | 2003-07-11 | 2003-07-11 | 0d | 0d |  | must start on 2003-07-15 | MSSL | MS |
| 586 | 4.95 | PFM Thermal Straps Delivery to RAL | milestone | 0d | 2003-08-11 | 2003-08-11 |  | 2003-07-11 | 2003-07-11 | 0d | 0d |  | must start on 2003-08-11 | MSSL | MS |
| 587 | 4.96 | PFM Mirrors Delivery to RAL | milestone | 0d | 2003-08-01 | 2003-08-01 |  | 2003-07-11 | 2003-07-11 | 0d | 0d |  | must start on 2003-08-01 | LAM | MS |
| 588 | 4.97 | PFM Cooler Delivery to RAL | milestone | 0d | 2003-08-01 | 2003-08-01 |  | 2003-07-11 | 2003-07-11 | 0d | 0d |  | must start on 2003-08-01 | Grenoble | MS |
| 589 | 4.98 | PFM Filters Dichroics and Beamsplitters Delivery to RAL | milestone | 0d | 2003-08-01 | 2003-08-01 |  | 2003-10-01 | 2003-10-01 | 0d | 0d |  | must start on 2003-08-01 | QMW | MS |
| 590 | 4.99 | PFM BDAs Delivery to RAL | milestone | 0d | 2003-10-01 | 2003-10-01 |  | 2003-09-20 | 2003-09-20 | 0d | 0d |  | must start on 2003-10-01 | JPL | MS |
| 591 | 4.100 | PFM BSMm Delivery to RAL | milestone | 0d | 2003-10-01 | 2003-10-01 |  | 2003-10-01 | 2003-10-01 | 0d | 0d |  | must start on 2003-10-01 | ATC | MS |
| 592 | 4.101 | PFM SMECm Delivery to RAL | milestone | 0d | 2003-10-01 | 2003-10-01 |  | 2003-10-01 | 2003-10-01 | 0d | 0d |  | must start on 2003-10-01 | LAM | MS |
| 593 | 4.102 | PFM Shutter Delivery to RAL | milestone | 0d | 2003-10-01 | 2003-10-01 |  | 2003-10-01 | 2003-10-01 | 0d | 0d |  | must start on 2003-10-01 | USK | MS |
| 594 | 4.103 | PFM SCAL Delivery to RAL | milestone | 0d | 2003-11-27 | 2003-11-27 |  | 2003-10-01 | 2003-10-01 | 0d | 0d |  | must start on 2003-11-27 | QMW | MS |
| 595 | 4.104 | PFM FPU RF Filter Modules Delivery to RAL | milestone | 0d | 2003-10-22 | 2003-10-22 |  | 2003-10-01 | 2003-10-01 | 0d | 0d |  | must start on 2003-10-22 | JPL | MS |
| 596 | 4.105 | PFM FTB Enclosure Delivery to RAL | milestone | 0d | 2003-10-22 | 2003-10-22 |  | 2003-10-22 | 2003-10-22 | 0d | 0d |  | must start on 2003-10-22 | MSSL | MS |
| 597 | 3.2.4 | PFM JFET Modules Delivered to RAL | milestone | 0d | 2003-10-22 | 2003-10-22 |  | 2003-10-22 | 2003-10-22 | 0d | 0d |  | must start on 2003-10-22 | JPL | MS |
| 598 | 4.107 | PFM FTB RF Filter Modules Delivery to RAL | milestone | 0d | 2003-10-22 | 2003-10-22 |  | 2003-10-22 | 2003-10-22 | 0d | 0d |  | must start on 2003-10-22 | JPL | MS |
| 599 | 4.108 | Delivery of PFM FPUFTB to Cold Vibration Facility | milestone | 0d | 2004-04-06 | 2004-04-06 | 430 | 2004-02-01 | 2004-02-01 | 0d | 10d | 0d |  | RAL | MS |
| 600 | 4.109 | Delivery of Cold-Vibrated PFM FPUFTB to RAL | milestone | 0d | 2004-05-04 | 2004-05-04 | 599FS+4w | 2004-02-27 | 2004-02-27 | 0d | 10d | 0d |  | RAL | MS |
| 601 | 4.110 | PFM DPU Delivery to RAL | milestone | 0d | 2004-03-01 | 2004-03-01 |  | 2004-03-01 | 2004-03-01 | 0d | 0d |  | must start on 2004-03-01 | IFSI | MS |
| 602 | 4.111 | PFM DRCU Delivery to RAL | milestone | 0d | 2004-07-30 | 2004-07-30 |  | 2004-03-01 | 2004-03-01 | 0d | 0d |  | must start on 2004-07-30 | SAp | MS |
| 603 | 4.112 | PFM WIH Delivery to RAL | milestone | 0d | 2004-07-30 | 2004-07-30 |  | 2004-03-01 | 2004-03-01 | 0d | 0d |  | must start on 2004-07-30 | SAp | MS |
| 604 | 4.113 | PFM Delivery to ESA | milestone | 0d | 2004-09-01 | 2004-09-01 | 462 | 2004-07-01 | 2004-07-01 | 0d | -42d | 0d | must finish on 2004-09-01 | RAL | MS |
| 605 | 4.114 | Return of CQM from ESA | milestone | 0d | 2004-10-07 | 2004-10-07 | 573FS+52w | 2004-04-07 | 2004-04-07 | 0d | 616d |  |  | ESA | MS |
| 606 | 4.115 | Delivery of QM DPU to IFSI | milestone | 0d | 2005-01-17 | 2005-01-17 | 471 | 2004-04-02 | 2004-04-02 | 0d | 554d |  |  | RAL | MS |
| 607 | 4.116 | Delivery of QM2 DRCU to SAp | milestone | 0d | 2005-01-17 | 2005-01-17 | 474 | 2004-04-02 | 2004-04-02 | 0d | 554d |  |  | RAL | MS |
| 608 | 4.117 | FS BSMm Delivery to LAM | milestone | 0d | 1997-07-01 | 1997-07-01 |  | 2004-02-06 | 2004-02-06 | 0d | 2490d |  |  | ATC | MS |
| 609 | 4.118 | FS PCAL Delivery to ATC | milestone | 0d | 1997-07-01 | 1997-07-01 |  | 2003-11-12 | 2003-11-12 | 0d | 2490d |  |  | QMW | MS |
| 610 | 4.119 | FS MCU Delivery to SAp | milestone | 0d | 1997-07-01 | 1997-07-01 |  | 2004-06-22 | 2004-06-22 | 0d | 2490d |  |  | LAM | MS |
| 611 | 4.120 | FS Structure Available for Integration | milestone | 0d | 1997-07-01 | 1997-07-01 |  | 2004-09-22 | 2004-09-22 | 0d | 2490d |  |  | MSSL | MS |
| 612 | 4.121 | FS Detector Arrays Delivery to RAL | milestone | 0d | 1997-07-01 | 1997-07-01 |  | 2004-09-02 | 2004-09-02 | 0d | 2490d |  |  | QMW | MS |
| 613 | 4.122 | FS SCAL Delivery to RAL | milestone | 0d | 1997-07-01 | 1997-07-01 |  | 2003-11-12 | 2003-11-12 | 0d | 2490d |  |  | QMW | MS |
| 614 | 4.123 | FS Cooler Delivery to RAL | milestone | 0d | 1997-07-01 | 1997-07-01 |  | 2004-03-10 | 2004-03-10 | 0d | 2490d |  |  | Grenoble | MS |
| 615 | 4.124 | FS Mirrors Delivery to RAL | milestone | 0d | 1997-07-01 | 1997-07-01 |  | 2003-08-15 | 2003-08-15 | 0d | 2490d |  |  | LAM | MS |
| 616 | 4.125 | FS SMECm Delivery to RAL | milestone | 0d | 1997-07-01 | 1997-07-01 |  | 2004-06-29 | 2004-06-29 | 0d | 2490d |  |  |  | MS |
| 617 | 4.126 | FS BSMm Delivery to RAL | milestone | 0d | 1997-07-01 | 1997-07-01 |  | 2004-06-29 | 2004-06-29 | 0d | 2490d |  |  | ATC | MS |
| 618 | 4.127 | FS DPU Delivery to RAL | milestone | 0d | 1997-07-01 | 1997-07-01 |  | 2004-09-23 | 2004-09-23 | 0d | 2031d | 1931d |  | IFSI | MS |
| 619 | 4.128 | FS DRCU Delivery to RAL | milestone | 0d | 1997-07-01 | 1997-07-01 |  | 2005-02-14 | 2005-02-14 | 0d | 2031d | 1931d |  |  |  |
| 620 | 4.129 | FS Filters Dichroics and Beamsplitters Delivery to RAL | milestone | 0d | 1997-07-01 | 1997-07-01 |  | 2004-06-18 | 2004-06-18 | 0d | 2490d |  |  | QMW | MS |
| 621 | 4.130 | FS Shutter delivery to RAL | milestone | 0d | 1997-07-01 | 1997-07-01 |  | 2005-01-25 | 2005-01-25 | 0d | 2490d |  |  |  |  |
| 622 | 4.131 | FS JFET Box Delivery to RAL | milestone | 0d | 1997-07-01 | 1997-07-01 |  | 2004-09-02 | 2004-09-02 | 0d | 2490d |  |  |  | MS |

| ID | WBS | Task | Type | Duration | Start | Finish | Predecessors | Baseline start | Baseline finish | Baseline duration | Total slack | Constraint | Text2 |
| --- | --- | --- | --- | --- | --- | --- | --- | --- | --- | --- | --- | --- | --- |
| 623 | 4.132 | FS RF Filter Modules Delivery to RAL | milestone | 0d | 1997-07-01 | 1997-07-01 |  | 1997-07-01 | 1997-07-01 | 0d | 2490d |  | MS |
| 624 | 4.133 | FS Availableto ESA | milestone | 0d | 2006-01-01 | 2006-01-01 | 490 |  |  |  | 0d | must finish on 2006-01-01 |  |
